# NGAO Detailed Design

Schedule from MS Project, 2005-10-03 to 2012-09-28, costs in $.
CARA

## Calendars

- Standard: Mon-Fri 08:00-12:00, 13:00-17:00; Sat-Sun off.

## Resources

| Resource | Group | Rate | Cost per use |
| --- | --- | --- | --- |
| MRI Wizinowich | WMKO |  |  |
| MRI Chin | WMKO |  |  |
| MRI Stalcup | WMKO |  |  |
| MRI Medeiros | WMKO |  |  |
| MRI Nance | WMKO |  |  |
| MRI Wetherell | WMKO |  |  |
| MRI Doyle | WMKO |  |  |
| MRI Agliam | WMKO |  |  |
| MRI Reed | WMKO |  |  |
| MRI Mogenson | WMKO |  |  |
| Wizinowich | WMKO | 75 |  |
| Chin | WMKO | 75 |  |
| Stalcup | WMKO | 75 |  |
| Medeiros | WMKO | 75 |  |
| Morrison | WMKO | 75 |  |
| Nance | WMKO | 75 |  |
| Wetherell | WMKO | 75 |  |
| Doyle | WMKO | 75 |  |
| Mogenson | WMKO | 75 |  |
| Reed | WMKO | 75 |  |
| MRI Laser Travel | WMKO |  |  |
| MRI Laser#1 Down Payment | WMKO |  |  |
| MRI Adkins | WMKO |  |  |
| MRI Grace | WMKO |  |  |
| MRI ChockJ | WMKO |  |  |
| Johnson | WMKO | 75 |  |
| LaVen | WMKO | 75 |  |
| Tsubota | WMKO | 75 |  |
| Shimko | WMKO | 75 |  |
| Grace | WMKO | 75 |  |
| MRI LaVen | WMKO |  |  |
| Agliam | WMKO | 75 |  |
| MRI Cooper | WMKO |  |  |
| Cooper | WMKO | 75 |  |
| ChockE | WMKO | 75 |  |
| Ward | WMKO | 75 |  |
| Dekany | CIT | 75 |  |
| Microgate ParaOsc | MG | 18000 |  |
| Contour Software Support | CSS | 4400 |  |
| MatLab | ML | 583 |  |
| Pollard | WMKO | 75 |  |
| Flat Field Source | WMKO | 1000 |  |
| Hyatt | WMKO | 75 |  |
| Martin | WMKO | 75 |  |
| Lyke | WMKO | 75 |  |
| PostD-OpsTools | WMKO | 75 |  |
| ChockJ | WMKO | 75 |  |
| Gavel | UCSC | 75 |  |
| Max (FL) | UCSC | 75 |  |
| Travel-Short |  | 950 |  |
| Travel-HI |  | 3000 |  |
| Travel-Inter |  | 4200 |  |
| Travel-Other |  | 2700 |  |
| Management-AssoSci | WMKO | 75 |  |
| Travel-CA |  | 1300 |  |
| Management-AssoAdmin | WMKO | 75 |  |
| Tyau | WMKO | 75 |  |
| Shared Infrastructure | WMKO | 102000 |  |
| Neyman | WMKO | 75 |  |
| SmithB | WMKO | 75 |  |
| Kupke | UCSC | 75 |  |
| Lockwood | UCSC | 75 |  |
| Reinig | UCSC | 75 |  |
| AOE Detailed Design | WMKO | 28600 |  |
| AOBCE Detailed Design | WMKO |  |  |
| AOE HVAC Design | WMKO |  |  |
| Adkins | WMKO | 75 |  |
| Velur | CIT | 75 |  |
| Delacroix | CIT | 75 |  |
| Conrad | WMKO | 75 |  |
| McGrath | UCSC | 75 |  |
| Lewis | JPL | 75 |  |
| Troy | JPL | 75 |  |
| Woillez | WMKO | 75 |  |
| Wallace | JPL | 75 |  |
| Jolissaint |  | 75 |  |
| McGrath Postdoc | UCSC | 75 |  |
| McGrath Research | UCSC | 75 |  |
| James | WMKO | 75 |  |
| Dillon | UCSC | 75 |  |
| UCSC Programmer | UCSC | 75 |  |
| RTC Programmer Contract |  | 100 |  |
| TE Board Final Design Contract |  | 62.5 |  |
| Timing board design-build contract |  | 100 |  |
| RTC Timing signal genrator |  |  | 5000 |
| RTC Data capture unit |  |  | 10000 |
| RTC Misc. test equipment |  |  | 15000 |
| RTC Cable breakouts |  | 1000 |  |
| RTC OS development license |  |  | 70000 |
| SmithR | CIT | 75 |  |
| Rahmer | CIT | 75 |  |
| Bartos | CIT | 75 |  |
| Croner | CIT | 75 |  |
| Fucik | CIT | 75 |  |

## Schedule

| ID | WBS | Task | Duration | Start | Finish | Predecessors | Total slack | Free slack | Constraint | Resources | Work | Cost |
| --- | --- | --- | --- | --- | --- | --- | --- | --- | --- | --- | --- | --- |
| 1 | 1 | **NGAO Design** | 1825d? | 2005-10-03 | 2012-09-28 |  | 0d |  |  |  | 76164.8h | 6,766,643 |
| 2 | 1.1 | Proposal | 195d? | 2005-10-03 | 2006-06-30 |  | 615d | 65d | start no earlier than 2005-10-03 |  |  |  |
| 3 | 1.2 | System Design | 413d? | 2006-10-02 | 2008-04-30 | 2 | 550d | 0d | start no earlier than 2006-10-02 |  |  |  |
| 4 | 1.3 | **Preliminary Design +** | 609d? | 2008-05-01 | 2010-08-31 |  | 543d |  |  |  | 220h | 16,500 |
| 5 | 1.3.1 | Preliminary Design | 565d? | 2008-05-01 | 2010-06-30 | 3 | 550d | 0d | start no earlier than 2008-05-01 |  |  |  |
| 6 | 1.3.2 | **Preliminary Design Revisions** | 44d? | 2010-07-01 | 2010-08-31 | 5 | 543d |  |  |  | 220h | 16,500 |
| 7 | 1.3.2.1 | Response to PDR Reviewer Report | 22d? | 2010-07-01 | 2010-07-30 |  | 565d |  | finish no earlier than 2010-07-30 | Wizinowich [22.7%]; Dekany; Gavel; Adkins; Chin | 120h | 9,000 |
| 8 | 1.3.2.2 | Plan Revisions | 32d? | 2010-07-19 | 2010-08-31 |  | 543d |  | start no earlier than 2010-07-19 | Wizinowich [15.6%]; Dekany; Gavel; Adkins; Chin | 100h | 7,500 |
| 9 | 1.3.2.3 | Wrap up of PDR Designs & Documentation | 37d? | 2010-07-12 | 2010-08-31 |  | 543d |  | finish no earlier than 2010-08-31 |  |  |  |
| 10 | 1.4 | **Detailed Design** | 543d? | 2010-09-01 | 2012-09-28 |  | 0d |  |  |  | 75944.8h | 6,750,143 |
| 11 | 1.4.1 | Design Placeholder | 1d? | 2010-10-01 | 2010-10-01 |  | 520d |  |  |  |  |  |
| 12 | 1.4.2 | **Project Management** | 543d? | 2010-09-01 | 2012-09-28 |  | 0d |  |  |  | 6516h | 723,700 |
| 13 | 1.4.2.1 | **Planning** | 450d? | 2010-11-01 | 2012-07-20 |  | 50d |  |  |  | 1720h | 132,000 |
| 14 | 1.4.2.1.1 | **Replans** | 240d? | 2010-11-01 | 2011-09-30 |  | 260d |  |  |  | 240h | 21,000 |
| 15 | 1.4.2.1.1.1 | Early PDR Plan Adjustments | 25d? | 2010-11-01 | 2010-12-03 |  | 475d |  | finish no earlier than 2010-12-03 | Wizinowich [20%] | 40h | 3,000 |
| 16 | 1.4.2.1.1.2 | Mid-DD Replan | 25d? | 2011-08-29 | 2011-09-30 |  | 260d |  | start no earlier than 2011-08-29 | Wizinowich [40%]; Dekany; Gavel; Chin; Travel-HI | 200h | 18,000 |
| 17 | 1.4.2.1.2 | **WMKO FY Plans** | 324d? | 2011-02-01 | 2012-04-27 |  | 110d |  |  |  | 80h | 6,000 |
| 18 | 1.4.2.1.2.1 | Support WMKO FY12 Planning | 64d? | 2011-02-01 | 2011-04-29 |  | 370d |  | start no earlier than 2011-02-01 | Wizinowich [4.7%]; Chin | 40h | 3,000 |
| 19 | 1.4.2.1.2.2 | Support WMKO FY13 Planning | 63d? | 2012-02-01 | 2012-04-27 |  | 110d |  | start no earlier than 2012-02-01 | Wizinowich [4.8%]; Chin | 40h | 3,000 |
| 20 | 1.4.2.1.3 | **Systems Engineering Management Plan** | 80d? | 2012-04-02 | 2012-07-20 |  | 50d |  |  |  | 1400h | 105,000 |
| 21 | 1.4.2.1.3.1 | **Project Plan** | 70d? | 2012-04-02 | 2012-07-06 |  | 60d |  |  |  | 1280h | 96,000 |
| 22 | 1.4.2.1.3.1.1 | PBS, WBS & Task Definition | 20d? | 2012-04-02 | 2012-04-27 |  | 110d |  | start no earlier than 2012-04-02 | Wizinowich [10%]; Dekany [10%]; Gavel [10%]; Chin [10%]; Velur [10%]; Neyman [10%]; Stalcup [10%]; Tsubota [10%]; Wetherell [10%]; Reinig [10%]; Lockwood [10%]; Kupke [10%]; Delacroix [10%] | 80h | 6,000 |
| 23 | 1.4.2.1.3.1.2 | Cost Estimation | 30d? | 2012-04-30 | 2012-06-08 |  | 80d |  | start no earlier than 2012-04-30 | Wizinowich [41.7%]; Dekany [40%]; Gavel [40%]; Chin [40%]; Velur [40%]; Neyman [40%]; Stalcup [40%]; Tsubota [40%]; Wetherell [40%]; Reinig [40%]; Lockwood [40%]; Kupke [40%]; Delacroix [40%] | 560h | 42,000 |
| 24 | 1.4.2.1.3.1.3 | Full Schedule (MS Project Plan) | 30d? | 2012-05-28 | 2012-07-06 |  | 60d |  | finish no earlier than 2012-07-06 | Wizinowich [50%]; Dekany [50%]; Gavel [50%]; Chin [50%]; Velur [50%]; Neyman [50%]; Stalcup [50%]; Tsubota [50%]; Wetherell [50%]; Reinig [50%]; Lockwood [50%]; Kupke [50%]; Delacroix [50%] | 640h | 48,000 |
| 25 | 1.4.2.1.3.2 | SEMP Document | 35d? | 2012-06-04 | 2012-07-20 |  | 49.5d | 9d | start no earlier than 2012-06-04 | Wizinowich [28.6%]; Dekany [50%]; Gavel [50%]; Chin [50%]; Adkins [50%] | 120h | 9,000 |

Notes:
- 13: X 1900

| ID | WBS | Task | Type | Duration | Start | Finish | Predecessors | Total slack | Constraint | Resources | Work | Cost |
| --- | --- | --- | --- | --- | --- | --- | --- | --- | --- | --- | --- | --- |
| 26 | 1.4.2.2 | **Project Management & Meetings** |  | 543d? | 2010-09-01 | 2012-09-28 |  | 0d |  |  | 1712h | 186,000 |
| 27 | 1.4.2.2.1 | Senior Management Activities |  | 543d? | 2010-09-01 | 2012-09-28 |  | 0d | finish no earlier than 2012-09-28 | Wizinowich [13.8%]; Dekany [10%]; Gavel [10%]; Adkins [10%]; Chin [10%] | 950h | 71,250 |
| 28 | 1.4.2.2.2 | Team Meetings |  | 522d? | 2010-09-01 | 2012-08-30 |  | 21d | finish no earlier than 2012-08-30 | Wizinowich [2%]; Dekany [2%]; Gavel [2%]; Adkins [2%]; Chin [2%]; Tsubota [2%]; Neyman [2%]; Velur [2%]; Lockwood [2%]; Kupke [2%]; Reinig [2%]; Delacroix [2%]; Wetherell [2%]; Stalcup [2%]; Lyke [2%]; Travel-HI [1200%]; Travel-CA [600%] | 744h | 99,600 |
| 29 | 1.4.2.2.3 | NSAT Meetings |  | 522d? | 2010-09-01 | 2012-08-30 |  | 21d | start no earlier than 2010-09-01 | Wizinowich [0.4%]; Travel-HI [200%]; Travel-CA [600%] | 18h | 15,150 |
| 30 | 1.4.2.3 | **Tracking & Reporting** |  | 543d? | 2010-09-01 | 2012-09-28 |  | 0d |  |  | 532h | 57,100 |
| 31 | 1.4.2.3.1 | Monthly Project Reports |  | 543d? | 2010-09-01 | 2012-09-28 |  | 0d | finish no earlier than 2012-09-28 | Wizinowich [2.5%]; Dekany [2%]; Gavel [2%]; Adkins [2%] | 216h | 16,200 |
| 32 | 1.4.2.3.2 | SSC Meetings |  | 543d? | 2010-09-01 | 2012-09-28 |  | 0d | start no earlier than 2010-09-01 | Wizinowich [2.9%]; Dekany [2%]; Gavel [2%]; Chin [2%]; Adkins [2%]; Travel-HI [300%]; Travel-CA [300%] | 216h | 29,100 |
| 33 | 1.4.2.3.3 | Other Presentations |  | 543d? | 2010-09-01 | 2012-09-28 |  | 0d | start no earlier than 2010-09-01 | Wizinowich [0.5%]; Dekany [0.5%]; Gavel [0.5%]; Chin [1%]; Tsubota [1%]; Neyman [1%]; Velur [1%]; Kupke [1%]; Travel-HI; Travel-CA | 100h | 11,800 |
| 34 | 1.4.2.4 | **Proposals & Fundraising** |  | 522d? | 2010-09-01 | 2012-08-30 |  | 21d |  |  | 40h | 3,000 |
| 35 | 1.4.2.4.1 | Advancement Support |  | 522d? | 2010-09-01 | 2012-08-30 |  | 21d | finish no earlier than 2012-08-30 | Wizinowich [1%] | 40h | 3,000 |
| 36 | 1.4.2.4.2 | TSIP 2010 Proposal |  | 13d? | 2010-09-01 | 2010-09-17 |  | 530d | start no earlier than 2010-09-01 |  |  |  |
| 37 | 1.4.2.4.3 | ATI 2010 Proposal |  | 35d? | 2010-09-20 | 2010-11-05 |  | 495d | finish no earlier than 2010-11-05 |  |  |  |
| 38 | 1.4.2.4.4 | MRI 2011 Proposal |  | 50d? | 2010-11-15 | 2011-01-21 |  | 440d | finish no earlier than 2011-01-21 |  |  |  |
| 39 | 1.4.2.4.5 | TSIP 2011 Proposal |  | 35d? | 2011-08-01 | 2011-09-16 |  | 270d | finish no earlier than 2011-09-16 |  |  |  |
| 40 | 1.4.2.4.6 | ATI 2011 Proposal |  | 47d? | 2011-09-01 | 2011-11-04 |  | 235d | finish no earlier than 2011-11-04 |  |  |  |
| 41 | 1.4.2.4.7 | MRI 2012 Proposal |  | 52d? | 2011-11-10 | 2012-01-20 |  | 180d | finish no earlier than 2012-01-20 |  |  |  |
| 42 | 1.4.2.5 | **Programmatic Risk Assessment & Mitigation** |  | 456d? | 2010-10-01 | 2012-06-29 |  | 65d |  |  | 180h | 19,500 |
| 43 | 1.4.2.5.1 | **Programmatic Risk Assessment** |  | 249d? | 2011-07-05 | 2012-06-15 |  | 75d |  |  | 60h | 4,500 |
| 44 | 1.4.2.5.1.1 | Programmatic Risk Assessment 1 |  | 19d? | 2011-07-05 | 2011-07-29 |  | 305d | start no earlier than 2011-07-05 | Wizinowich [13.2%]; Dekany [10%]; Gavel [10%]; Chin [10%] | 30h | 2,250 |
| 45 | 1.4.2.5.1.2 | Programmatic Risk Assessment 2 |  | 10d? | 2012-06-04 | 2012-06-15 |  | 75d | start no earlier than 2012-06-04 | Wizinowich [25%]; Dekany; Gavel; Chin | 30h | 2,250 |
| 46 | 1.4.2.5.2 | Risk Mitigation |  | 456d? | 2010-10-01 | 2012-06-29 |  | 65d | finish no earlier than 2012-06-29 | Wizinowich [2.7%]; Dekany; Gavel; Chin; Travel-HI [200%] | 120h | 15,000 |
| 47 | 1.4.2.6 | **Project Reviews** |  | 416d? | 2011-02-25 | 2012-09-28 |  | 0d |  |  | 1384h | 153,000 |
| 48 | 1.4.2.6.1 | **Subsystem Mini Design Reviews** |  | 412.25d | 2011-02-25 | 2012-09-25 |  | 3.75d |  |  | 720h | 54,000 |
| 49 | 1.4.2.6.1.1 | Mini-Review Reviewer Support |  | 394d | 2011-02-25 | 2012-08-29 |  | 22d | finish no earlier than 2012-08-29 | Wizinowich [5.7%]; Dekany [3%]; Gavel [3%]; Adkins [3%]; Chin [3%]; Neyman [3%]; Stalcup [3%]; Velur [3%]; Lockwood [3%]; Delacroix [3%]; Lyke [3%]; Conrad [3%]; Wetherell [3%]; Tsubota [3%]; Kupke [3%]; Pollard [3%] | 720h | 54,000 |
| 50 | 1.4.2.6.1.2 | AO Enclosures Mini Review | milestone | 0d | 2011-09-30 | 2011-09-30 | 177 | 260d |  |  |  |  |
| 51 | 1.4.2.6.1.3 | AO Opto-Mechanics Mini Review | milestone | 0d | 2011-04-29 | 2011-04-29 | 258 | 370d |  |  |  |  |
| 52 | 1.4.2.6.1.4 | LGS WFS Mini Review | milestone | 0d | 2012-06-27 | 2012-06-27 | 290 | 67d |  |  |  |  |
| 53 | 1.4.2.6.1.5 | NGS WFS Mini Review | milestone | 0d | 2012-03-28 | 2012-03-28 | 319 | 132.29d |  |  |  |  |
| 54 | 1.4.2.6.1.6 | LOWFS Mini Review | milestone | 0d | 2012-07-23 | 2012-07-23 | 513 | 49.75d |  |  |  |  |
| 55 | 1.4.2.6.1.7 | Alignment & Calibration Mini Review | milestone | 0d | 2011-03-30 | 2011-03-30 | 523 | 392.5d |  |  |  |  |
| 56 | 1.4.2.6.1.8 | RTC Mini Review | milestone | 0d | 2012-03-13 | 2012-03-13 | 581 | 143d |  |  |  |  |
| 57 | 1.4.2.6.1.9 | LGS Facility Mini Review | milestone | 0d | 2012-02-29 | 2012-02-29 | 701 | 152d |  |  |  |  |
| 58 | 1.4.2.6.1.10 | Control System Mini Review | milestone | 0d | 2012-09-25 | 2012-09-25 | 813 | 3.75d |  |  |  |  |
| 59 | 1.4.2.6.1.11 | Science Operations Tools Mini Review | milestone | 0d | 2012-08-13 | 2012-08-13 | 826 | 34d |  |  |  |  |
| 60 | 1.4.2.6.1.12 | Performance Mini Review | milestone | 0d | 2012-07-16 | 2012-07-16 | 957 | 55d |  |  |  |  |
| 61 | 1.4.2.6.1.13 | Telescope & Summit Eng Mini Review | milestone | 0d | 2012-08-29 | 2012-08-29 | 920 | 22.5d |  |  |  |  |
| 62 | 1.4.2.6.1.14 | AO System Lab & Tel I&T Mini Review | milestone | 0d | 2011-11-04 | 2011-11-04 | 518, 934 | 235d |  |  |  |  |
| 63 | 1.4.2.6.1.15 | LGS Facility Lab & Tel I&T Mini Review | milestone | 0d | 2012-06-07 | 2012-06-07 | 954 | 81d |  |  |  |  |
| 64 | 1.4.2.6.1.16 | Telescope LGS AO I&T Mini Review | milestone | 0d | 2012-06-21 | 2012-06-21 | 955 | 71d |  |  |  |  |

Notes:
- 26: X3300
- 30: X1339
- 34: X40
- 42: X180

| ID | WBS | Task | Type | Duration | Start | Finish | Predecessors | Total slack | Free slack | Constraint | Resources | Work | Cost |
| --- | --- | --- | --- | --- | --- | --- | --- | --- | --- | --- | --- | --- | --- |
| 65 | 1.4.2.6.2 | **Detailed Design Review** |  | 185d? | 2012-01-16 | 2012-09-28 |  | 0d |  |  |  | 664h | 99,000 |
| 66 | 1.4.2.6.2.1 | Review Setup (Date, Participants, Charter) |  | 32d? | 2012-01-16 | 2012-02-28 |  | 153d |  | finish no earlier than 2012-02-28 | Wizinowich [7.8%] | 20h | 1,500 |
| 67 | 1.4.2.6.2.2 | Detailed Design Report |  | 10d? | 2012-07-16 | 2012-07-27 |  | 44.5d | 4d | finish no earlier than 2012-07-27 | Wizinowich; Dekany; Gavel; Adkins [50%] | 100h | 7,500 |
| 68 | 1.4.2.6.2.3 | Review Package Distributed |  | 0.5d? | 2012-08-03 | 2012-08-03 | 67, 25, 137 | 40.5d |  | start no earlier than 2012-08-03 | Wizinowich | 4h | 300 |
| 69 | 1.4.2.6.2.4 | Reviewer Comments Received | milestone | 0d | 2012-08-17 | 2012-08-17 |  | 31d |  | start no earlier than 2012-08-17 |  |  |  |
| 70 | 1.4.2.6.2.5 | Reviewer Comments Addressed |  | 5d? | 2012-08-20 | 2012-08-24 |  | 25d |  | finish no earlier than 2012-08-24 | Wizinowich; Dekany [50%]; Gavel [50%]; Adkins [50%]; Chin [50%]; Neyman [50%]; Velur [50%]; Kupke [50%]; Lockwood [50%]; Tsubota [50%]; Wetherell [50%]; Reinig [50%] | 120h | 9,000 |
| 71 | 1.4.2.6.2.6 | DDR Presentation Preparation |  | 10d? | 2012-08-13 | 2012-08-24 |  | 25d |  | start no earlier than 2012-08-13 | Wizinowich [40%]; Dekany [40%]; Gavel [40%]; Chin [40%]; Neyman [10%]; Tsubota [10%]; Wetherell [10%]; Stalcup [10%]; Lyke [10%]; Kupke [10%]; Lockwood [10%]; Reinig [10%]; Delacroix [10%]; Velur [10%] | 120h | 9,000 |
| 72 | 1.4.2.6.2.7 | Detailed Design Review |  | 2d? | 2012-08-30 | 2012-08-31 |  | 20d | 0d | start no earlier than 2012-08-30 | Wizinowich; Dekany; Gavel; Adkins; Chin; Tsubota; Neyman; Velur; Kupke; Reinig; Lyke; Delacroix; Lockwood; Wetherell; Morrison; Travel-HI [1500%]; Travel-Inter | 240h | 67,200 |
| 73 | 1.4.2.6.2.8 | Reviewer Report Received | milestone | 0d | 2012-09-17 | 2012-09-17 |  | 10d |  | start no earlier than 2012-09-17 |  |  |  |
| 74 | 1.4.2.6.2.9 | Response to Reviewer Report |  | 9d? | 2012-09-18 | 2012-09-28 |  | 0d |  | start no earlier than 2012-09-18 | Wizinowich [33.3%]; Dekany; Gavel; Adkins; Chin | 60h | 4,500 |
| 75 | 1.4.2.7 | **Project Support** |  | 514d? | 2010-09-01 | 2012-08-21 |  | 28d |  |  |  | 948h | 173,100 |
| 76 | 1.4.2.7.1 | Administrative Support |  | 24emo | 2010-09-01 | 2012-08-21 |  | 115.12d |  | start no earlier than 2010-09-01 | Management-AssoAdmin; Tyau [4.2%]; Management-AssoSci; Ward [0.6%] | 948h | 71,100 |
| 77 | 1.4.2.7.2 | Shared Infrastructure |  | 498d? | 2010-09-01 | 2012-07-27 |  | 45d |  | finish no earlier than 2012-07-27 | Shared Infrastructure |  | 102,000 |
| 78 | 1.4.3 | **Systems Engineering** |  | 499d? | 2010-09-01 | 2012-07-30 |  | 44d |  |  |  | 16732h | 1,348,583 |
| 79 | 1.4.3.1 | **Science Case Development** |  | 450d | 2010-10-01 | 2012-06-22 |  | 71d |  |  |  | 5420h | 447,200 |
| 80 | 1.4.3.1.1 | Science Requirements |  | 12emo | 2010-10-01 | 2011-09-26 |  | 295.12d | 0d |  | McGrath [14.8%]; Max (FL) [1.6%]; Travel-Short [600%]; McGrath Postdoc [5.6%]; McGrath Research [5.6%] | 2380h | 184,200 |
| 81 | 1.4.3.1.2 | Science Observing Planning and Execution |  | 9emo | 2011-09-26 | 2012-06-22 | 80 | 295.12d |  |  | McGrath [15.1%]; Max (FL) [2.5%]; McGrath Research [7.4%] | 1620h | 121,500 |
| 82 | 1.4.3.1.3 | Science Inputs to other WBS |  | 21emo | 2010-10-01 | 2012-06-22 |  | 295.12d |  |  | McGrath [2%]; Max (FL) [1.2%]; Travel-Short [600%]; Travel-HI [200%] | 480h | 47,700 |
| 83 | 1.4.3.1.4 | Science Competitiveness |  | 21emo | 2010-10-01 | 2012-06-22 |  | 295.12d |  |  | McGrath [0.8%]; Max (FL) [1.6%]; Travel-Inter [200%]; Travel-Other [200%] | 360h | 40,800 |
| 84 | 1.4.3.1.5 | User Community Liason |  | 21emo | 2010-10-01 | 2012-06-22 |  | 295.12d |  |  | McGrath [0.5%]; Max (FL) [1.6%]; Travel-Short [200%] | 320h | 25,900 |
| 85 | 1.4.3.1.6 | NGAO Science Advisory Team |  | 21emo | 2010-10-01 | 2012-06-22 |  | 295.12d |  |  | McGrath [0.8%]; Max (FL) [0.9%]; Travel-Short [800%] | 260h | 27,100 |
| 86 | 1.4.3.2 | **System & Functional Requirements** |  | 478d? | 2010-09-01 | 2012-06-29 |  | 65d |  |  |  | 1727h | 133,925 |
| 87 | 1.4.3.2.1 | Requirement Updates in Database |  | 474d? | 2010-09-01 | 2012-06-25 |  | 69d |  | finish no earlier than 2012-06-25 | Neyman; Lewis [2.8%]; Ward [10%]; Contour Software Support | 283h | 25,625 |
| 88 | 1.4.3.2.2 | Traceability Matrices |  | 35d? | 2010-11-29 | 2011-01-14 |  | 445d |  | finish no earlier than 2011-01-14 | Lewis [22.9%]; Dekany | 120h | 9,000 |
| 89 | 1.4.3.2.3 | Compliance Matrices |  | 40d? | 2012-04-30 | 2012-06-22 |  | 70d |  | finish no earlier than 2012-06-22 | Neyman [20%]; Dekany | 120h | 9,000 |
| 90 | 1.4.3.2.4 | Finalize Subsystem Requirements |  | 80d? | 2012-01-30 | 2012-05-18 |  | 95d |  | finish no earlier than 2012-05-18 | Neyman; Dekany | 658h | 49,350 |
| 91 | 1.4.3.2.5 | Observing Operations Concept Document |  | 405d? | 2010-12-13 | 2012-06-29 |  | 65d |  | finish no earlier than 2012-06-29 | Wizinowich [10%]; Lyke [15%]; Conrad [10%] | 546h | 40,950 |

Notes:
- 75: X3591
- 86: In the beginning 1st 10 months

| ID | WBS | Task | Duration | Start | Finish | Total slack | Constraint | Resources | Work | Cost |
| --- | --- | --- | --- | --- | --- | --- | --- | --- | --- | --- |
| 92 | 1.4.3.3 | **Systems Engineering Analysis** | 465d? | 2010-10-04 | 2012-07-13 | 55d | start no earlier than 2010-10-01 |  | 7825h | 617,458 |
| 93 | 1.4.3.3.1 | **Performance Tools & Budgets** | 455d? | 2010-10-18 | 2012-07-13 | 55d |  | Travel-CA [800%] | 2950h | 231,650 |
| 94 | 1.4.3.3.1.1 | Wavefront Error Budget & Tool | 425d? | 2010-10-18 | 2012-06-01 | 85d | finish no earlier than 2012-06-01 | Dekany [50%]; Troy [2.4%]; Neyman [50%] | 140h | 10,500 |
| 95 | 1.4.3.3.1.2 | Photometric Error Budget Tool | 140d? | 2011-02-14 | 2011-08-26 | 285d | finish no earlier than 2011-08-26 | Dekany [50%]; Troy [16.1%] | 260h | 19,500 |
| 96 | 1.4.3.3.1.3 | Astrometric Error Budget Tool | 140d? | 2011-02-14 | 2011-08-26 | 285d | start no earlier than 2011-02-14 | Wizinowich [50%]; Woillez [17.9%]; Dekany [50%] | 260h | 19,500 |
| 97 | 1.4.3.3.1.4 | High Contrast Error Budget Tool | 110d? | 2010-11-15 | 2011-04-15 | 380d | finish no earlier than 2011-04-15 | Stalcup [9.1%]; Adkins [75%]; Dekany [50%] | 140h | 10,500 |
| 98 | 1.4.3.3.1.5 | Performance Flowdown Budget Tool | 415d? | 2010-11-01 | 2012-06-01 | 85d | finish no earlier than 2012-06-01 | Dekany [1.2%]; Wizinowich [50%]; Velur [62.5%]; Kupke [50%]; Neyman [50%] | 90h | 6,750 |
| 99 | 1.4.3.3.1.6 | Transmission & Background Budgets | 65d? | 2012-01-16 | 2012-04-13 | 120d | start no earlier than 2012-01-16 | Gavel [50%]; Kupke [15.4%]; Velur [15.4%]; Wallace [50%]; Dekany [50%] | 280h | 21,000 |
| 100 | 1.4.3.3.1.7 | WFS Slope Error Budget | 65d? | 2012-01-16 | 2012-04-13 | 120d | start no earlier than 2012-01-16 | Dekany [7.7%]; Velur [7.7%]; Troy [7.7%]; Gavel [50%] | 140h | 10,500 |
| 101 | 1.4.3.3.1.8 | Non-Correctable WFE Budget | 65d? | 2012-01-16 | 2012-04-13 | 120d | start no earlier than 2012-01-16 | Dekany [50%]; Gavel [50%]; Troy [15.4%] | 140h | 10,500 |
| 102 | 1.4.3.3.1.9 | Calibration Budget | 65d? | 2012-01-16 | 2012-04-13 | 120d | start no earlier than 2012-01-16 | Neyman [23.1%]; Dekany [50%] | 140h | 10,500 |
| 103 | 1.4.3.3.1.10 | NCP Tip-Tilt Budget | 65d? | 2012-01-16 | 2012-04-13 | 120d | start no earlier than 2012-01-16 | Gavel [7.7%]; Lockwood [50%]; Kupke [7.7%]; Dekany [50%]; Wallace [50%] | 140h | 10,500 |
| 104 | 1.4.3.3.1.11 | Observing Efficiency Budgets | 65d? | 2012-01-16 | 2012-04-13 | 120d | start no earlier than 2012-01-16 | Lyke [40%]; Conrad [23.1%]; Neyman [50%]; Tsubota [50%]; Adkins [50%]; LaVen [50%] | 390h | 29,250 |
| 105 | 1.4.3.3.1.12 | Uptime Budget | 12.5d? | 2012-05-15 | 2012-05-31 | 86d | finish no earlier than 2012-05-31 | Lyke [62.5%]; Neyman [50%]; Tsubota [50%]; Velur [50%]; Reinig [50%] | 130h | 9,750 |
| 106 | 1.4.3.3.1.13 | **Science Case Performance Summary** | 250d? | 2011-08-01 | 2012-07-13 | 55d |  |  | 260h | 19,500 |
| 107 | 1.4.3.3.1.13.1 | Science Case Performance Summary v1 | 25d? | 2011-08-01 | 2011-09-02 | 280d | finish no earlier than 2011-09-02 | Dekany [40%]; Troy [62.5%] | 100h | 7,500 |
| 108 | 1.4.3.3.1.13.2 | Science Case Performance Summary v2 | 35d? | 2012-05-28 | 2012-07-13 | 55d | finish no earlier than 2012-07-13 | Dekany [42.9%]; Troy [95.8%] | 160h | 12,000 |
| 109 | 1.4.3.3.1.14 | **Performance Prediction Tool** | 215d? | 2011-01-03 | 2011-10-28 | 240d |  |  | 440h | 33,000 |
| 110 | 1.4.3.3.1.14.1 | Performance Prediction Tool Requirements & Architecture | 85d? | 2011-01-03 | 2011-04-29 | 370d | finish no earlier than 2011-04-29 | Lyke [25%]; Conrad [25%]; Stalcup [7.4%]; Neyman | 150h | 11,250 |
| 111 | 1.4.3.3.1.14.2 | Performance Predictor Software Design | 120d? | 2011-05-16 | 2011-10-28 | 240d | finish no earlier than 2011-10-28 | Lyke [25%]; Conrad [20.8%]; Stalcup; Neyman; Morrison [15.6%] | 290h | 21,750 |
| 112 | 1.4.3.3.2 | **System Engineering Infrastructure Budgets** | 315d? | 2010-11-01 | 2012-01-13 | 185d |  |  | 260h | 22,500 |
| 113 | 1.4.3.3.2.1 | System Engineering Power/Heat/Cooling Budget | 315d? | 2010-11-01 | 2012-01-13 | 185d | finish no earlier than 2012-01-13 | Wetherell [3.2%]; Chin; Velur [5.7%]; Lockwood; Pollard [87.5%]; Travel-HI | 130h | 12,750 |
| 114 | 1.4.3.3.2.2 | System Engineering Mass Budget | 315d? | 2010-11-01 | 2012-01-13 | 185d | finish no earlier than 2012-01-13 | Pollard [2%]; Delacroix [8.5%]; Lockwood; Chin | 130h | 9,750 |
| 115 | 1.4.3.3.3 | System Engineering Modeling & Analysis | 420d? | 2010-10-04 | 2012-05-11 | 100d | finish no earlier than 2012-05-11 | Dekany [25%]; Neyman [50%]; MatLab; Gavel; Travel-CA [400%]; Travel-HI; Lewis [50%] | 2430h | 191,033 |

Notes:
- 92: In the beginning 1st 10 months

| ID | WBS | Task | Duration | Start | Finish | Predecessors | Total slack | Free slack | Constraint | Resources | Work | Cost |
| --- | --- | --- | --- | --- | --- | --- | --- | --- | --- | --- | --- | --- |
| 116 | 1.4.3.3.4 | **PSF Reconstruction** | 458.75d? | 2010-10-04 | 2012-07-05 |  | 61.25d |  |  |  | 2185h | 172,275 |
| 117 | 1.4.3.3.4.1 | Define PSF Metrics | 130d? | 2010-10-04 | 2011-04-01 |  | 390d |  | start no earlier than 2010-10-04 | Conrad [11.5%]; Wizinowich [25%] | 140h | 10,500 |
| 118 | 1.4.3.3.4.2 | NGS Off-axis Algorithm | 30d? | 2010-12-27 | 2011-02-04 |  | 61.25d | 0d | finish no earlier than 2011-02-04 | Neyman [50%]; Jolissaint [50%]; Travel-Inter | 140h | 14,700 |
| 119 | 1.4.3.3.4.3 | NGS Off-axis Demonstration | 22.5d? | 2011-02-07 | 2011-03-09 | 118 | 61.25d | 0d |  | Conrad [50%]; Jolissaint [50%] | 130h | 9,750 |
| 120 | 1.4.3.3.4.4 | LGS On-axis Algorithm | 127.5d? | 2011-03-09 | 2011-09-02 | 119 | 61.25d | 0d |  | Neyman [50%]; Jolissaint [56.9%] | 660h | 49,500 |
| 121 | 1.4.3.3.4.5 | LGS On-axis Demonstration | 25d? | 2011-09-05 | 2011-10-07 | 120 | 61.25d | 0d |  | Conrad [50%]; Jolissaint [50%]; Travel-Inter | 180h | 17,700 |
| 122 | 1.4.3.3.4.6 | LGS Off-axis Algorithm | 75d? | 2011-10-10 | 2012-01-20 | 121 | 61.25d | 0d |  | Neyman [50%]; Jolissaint [50%] | 340h | 25,500 |
| 123 | 1.4.3.3.4.7 | LGS Off-axis Demonstration | 21.25d? | 2012-01-23 | 2012-02-21 | 122 | 61.25d | 0d |  | Conrad [50%]; Jolissaint [50%] | 125h | 9,375 |
| 124 | 1.4.3.3.4.8 | Full NGAO Algorithm | 67.5d? | 2012-02-21 | 2012-05-24 | 123 | 61.25d | 0d |  | Neyman [50%]; Jolissaint [50%] | 310h | 23,250 |
| 125 | 1.4.3.3.4.9 | Final PSF Report | 30d? | 2012-05-24 | 2012-07-05 | 124 | 61.25d |  |  | Neyman [50%]; Jolissaint [50%]; Conrad [50%] | 160h | 12,000 |
| 126 | 1.4.3.4 | **System Engineering Interface Control** | 286d | 2010-10-01 | 2011-11-05 |  | 235d |  |  |  | 950h | 71,250 |
| 127 | 1.4.3.4.1 | External Interface Control | 13.33emo | 2010-10-01 | 2011-11-05 |  | 985.12d |  |  | Dekany [25%]; Neyman [2.2%] | 228h | 17,100 |
| 128 | 1.4.3.4.2 | Internal Interface Control | 13.33emo | 2010-10-01 | 2011-11-05 |  | 985.12d |  |  | Dekany [25%]; Neyman [7.1%] | 722h | 54,150 |
| 129 | 1.4.3.5 | **Configuration Control** | 477d | 2010-10-01 | 2012-07-30 |  | 42d |  |  |  | 230h | 17,250 |
| 130 | 1.4.3.5.1 | CC Board Activities | 22.28emo | 2010-10-01 | 2012-07-30 |  | 180d |  | start no earlier than 2010-10-01 | Neyman [0.7%]; Dekany [0.2%]; Gavel [0.2%]; Wizinowich [0.2%] | 200h | 15,000 |
| 131 | 1.4.3.5.2 | Configuration Management | 22.28emo | 2010-10-01 | 2012-07-30 |  | 180d |  | start no earlier than 2010-10-01 | Neyman [0.2%] | 30h | 2,250 |
| 132 | 1.4.3.6 | **Technical Risk Assessment & Mitigation** | 430d? | 2010-10-04 | 2012-05-25 |  | 90d |  |  |  | 480h | 54,000 |
| 133 | 1.4.3.6.1 | Technical Risk Assessment v1 | 15d? | 2011-04-04 | 2011-04-22 |  | 375d |  | start no earlier than 2011-04-04 | Wizinowich [16.7%]; Dekany [10%]; Gavel [10%]; Chin [10%]; Neyman [10%] | 52h | 3,900 |
| 134 | 1.4.3.6.2 | Technical Risk Assessment v2 | 15d? | 2012-05-07 | 2012-05-25 |  | 90d |  | finish no earlier than 2012-05-25 | Wizinowich [13.3%]; Dekany [10%]; Gavel [10%]; Chin [10%]; Neyman [10%] | 48h | 3,600 |
| 135 | 1.4.3.6.3 | **Technical Risk Mitigation** | 125d? | 2010-10-04 | 2011-03-25 |  | 395d |  |  |  | 380h | 46,500 |
| 136 | 1.4.3.6.3.1 | Parametric Oscillator | 125d? | 2010-10-04 | 2011-03-25 |  | 395d |  | finish no earlier than 2011-03-25 | Microgate ParaOsc; Tsubota [25%]; Stalcup [50%]; LaVen [26%]; Neyman [50%] | 380h | 46,500 |
| 137 | 1.4.3.7 | Design Manual | 20d? | 2012-06-25 | 2012-07-22 | 72FF-1.33emo | 49.5d | 9d | start no earlier than 2012-06-11 | Wizinowich [25%]; Dekany [25%]; Gavel [25%]; Chin [25%] | 100h | 7,500 |
| 138 | 1.4.4 | **AO System** | 543d? | 2010-09-01 | 2012-09-28 |  | 0d |  |  |  | 27399.8h | 3,028,685 |
| 139 | 1.4.4.1 | **AO Enclosures** | 261d? | 2010-10-01 | 2011-09-30 |  | 157.96d | 0d |  |  | 822h | 149,350 |
| 140 | 1.4.4.1.1 | **Nasmyth Enclosure** | 256d? | 2010-10-01 | 2011-09-26 |  | 161d | 5d |  |  | 418h | 86,810 |
| 141 | 1.4.4.1.1.1 | AO Enc Planning and Reporting | 12emo | 2010-10-01 | 2011-09-26 |  | 679.08d |  |  | Pollard [0.5%] | 46h | 3,450 |

Notes:
- 126: In the beginning 1st 10 months
- 129: Throughout 20 months
- 136: This should happen first year.
- 140: Subcontractor for SWx design rate: $85/hr

| ID | WBS | Task | Duration | Start | Finish | Predecessors | Total slack | Free slack | Constraint | Resources | Work | Cost |
| --- | --- | --- | --- | --- | --- | --- | --- | --- | --- | --- | --- | --- |
| 142 | 1.4.4.1.1.2 | **AO Enc Engineering Tasks** | 79.94d | 2010-10-01 | 2011-01-20 |  | 331d | 0d |  |  | 348h | 81,220 |
| 143 | 1.4.4.1.1.2.1 | AO Enc Requirements Review | 1emo | 2010-10-01 | 2010-10-31 |  | 1393.08d | 3d |  | Pollard [0.6%] | 4h | 980 |
| 144 | 1.4.4.1.1.2.2 | **AO Enclosure design** | 35.5d | 2010-11-01 | 2010-12-20 |  | 331.96d | 18.44d |  |  | 120h | 58,000 |
| 145 | 1.4.4.1.1.2.2.1 | AO Enc Mechanical Design | 80h | 2010-11-01 | 2010-11-15 | 143 | 331.96d | 0d |  | James [25%]; AOE Detailed Design | 20h | 33,500 |
| 146 | 1.4.4.1.1.2.2.2 | AO Enc Electronics Racks System Design | 24h | 2010-11-15 | 2010-11-18 | 145 | 331.96d | 0d |  | James [50%] | 12h | 2,940 |
| 147 | 1.4.4.1.1.2.2.3 | AO Enc Bench and Instrument Integration | 80h | 2010-11-18 | 2010-12-02 | 146 | 331.96d | 0d |  | James [50%] | 40h | 9,800 |
| 148 | 1.4.4.1.1.2.2.4 | AO Enc Gowning Room Design | 16h | 2010-12-02 | 2010-12-06 | 147 | 331.96d | 0d |  | James [50%] | 8h | 1,960 |
| 149 | 1.4.4.1.1.2.2.5 | AO Enc Cable tray system design | 40h | 2010-12-06 | 2010-12-13 | 148 | 331.96d | 0d |  | James [50%] | 20h | 4,900 |
| 150 | 1.4.4.1.1.2.2.6 | AO Enc Utilities | 40h | 2010-12-13 | 2010-12-20 | 149 | 331.96d | 0d |  | James [50%] | 20h | 4,900 |
| 151 | 1.4.4.1.1.2.3 | **AO Enc Environmental Control System** | 18.44d | 2010-12-20 | 2011-01-13 |  | 331.96d | 0d |  |  | 200h | 20,440 |
| 152 | 1.4.4.1.1.2.3.1 | AO Enc Air Quality Control System | 67.5h | 2010-12-20 | 2010-12-30 | 150 | 331.96d | 0d |  | James [88.3%]; Nance [44.4%] | 80h | 8,040 |
| 153 | 1.4.4.1.1.2.3.2 | AO Enc Temperature Control/Heat Removal System | 80h | 2010-12-30 | 2011-01-13 | 152 | 331.96d |  |  | James; Nance [50%]; AOE HVAC Design | 120h | 12,400 |
| 154 | 1.4.4.1.1.2.4 | AO Enc Request for Quote for COTS & Manufactured Parts | 40h | 2011-01-13 | 2011-01-20 | 144, 151 | 331.96d |  |  | James [60%] | 24h | 1,800 |
| 155 | 1.4.4.1.1.3 | **AO Enc System Engineering Tasks** | 7.06d? | 2011-01-20 | 2011-01-31 |  | 331.96d |  |  |  | 24h | 2,140 |
| 156 | 1.4.4.1.1.3.1 | AO Enc Installation Plan | 16h? | 2011-01-20 | 2011-01-24 | 142 | 331.96d | 0d |  | Pollard [87.5%] | 8h | 600 |
| 157 | 1.4.4.1.1.3.2 | AO Enc Documentation | 16h? | 2011-01-25 | 2011-01-26 | 156 | 331.96d | 0d |  | Pollard [50%] | 8h | 600 |
| 158 | 1.4.4.1.1.3.3 | AO Enc DDR Preparation | 24h | 2011-01-27 | 2011-01-31 | 157 | 331.96d |  |  | Pollard [33.3%] | 8h | 940 |
| 159 | 1.4.4.1.2 | **AO Bench Cold Enclosure** | 261d? | 2010-10-01 | 2011-09-30 |  | 157.96d | 0d |  |  | 404h | 62,540 |
| 160 | 1.4.4.1.2.1 | Cold Enc Planning and Reporting | 13.05mo | 2010-10-01 | 2011-09-30 |  | 157.96d |  | finish no earlier than 2011-09-30 | Pollard [1.1%] | 24h | 1,800 |
| 161 | 1.4.4.1.2.2 | **Cold Enc Engineering Tasks** | 205.5d | 2010-10-01 | 2011-07-15 |  | 206.96d | 0d |  |  | 340h | 56,700 |
| 162 | 1.4.4.1.2.2.1 | Cold Enc Requirements Review | 1emo | 2010-10-01 | 2010-10-31 |  | 871.08d | 0d |  | Pollard [0.6%] | 4h | 300 |
| 163 | 1.4.4.1.2.2.2 | **AOBCE Enclosure design** | 184.5d | 2010-10-31 | 2011-07-15 |  | 206.96d |  |  |  | 336h | 56,400 |
| 164 | 1.4.4.1.2.2.2.1 | Cold Enc Mechanical Design | 6emo | 2010-10-31 | 2011-04-29 | 162 | 871.08d | 0d |  | Pollard [0.9%]; AOBCE Detailed Design | 40h | 8,200 |
| 165 | 1.4.4.1.2.2.2.2 | **Cold Enc Environmental Control System Design** | 30d | 2011-04-29 | 2011-06-09 |  | 206.96d |  |  |  | 120h | 35,000 |
| 166 | 1.4.4.1.2.2.2.2.1 | Cold Enc Air Quality Control System | 10d | 2011-04-29 | 2011-05-12 | 164 | 206.96d | 0d |  | Nance [50%] | 40h | 8,200 |
| 167 | 1.4.4.1.2.2.2.2.2 | Cold Enc Temperature Control System | 10d | 2011-05-13 | 2011-05-26 | 166 | 206.96d | 0d |  | Nance [50%] | 40h | 13,400 |
| 168 | 1.4.4.1.2.2.2.2.3 | Cold Enc Heat Removal System | 10d | 2011-05-27 | 2011-06-09 | 167 | 206.96d | 0d |  | Nance [50%] | 40h | 13,400 |

Notes:
- 152: Subcontractor SWx
- 153: Subcontract SWx
- 159: Subcontractor for SWx design rate: $85/hr
- 166: Subcontractor SWx
- 167: Subcontract SWx
- 168: Subcontract SWx

| ID | WBS | Task | Type | Duration | Start | Finish | Predecessors | Total slack | Free slack | Resources | Work | Cost |
| --- | --- | --- | --- | --- | --- | --- | --- | --- | --- | --- | --- | --- |
| 169 | 1.4.4.1.2.2.2.3 | **Cold Enc Interface with AO enclosure** |  | 20d | 2011-06-10 | 2011-07-07 |  | 206.96d |  |  | 160h | 12,000 |
| 170 | 1.4.4.1.2.2.2.3.1 | Cold Enc Utilities Interface Design |  | 10d | 2011-06-10 | 2011-06-23 | 168 | 206.96d | 0d | Pollard [50%]; Nance [50%] | 80h | 6,000 |
| 171 | 1.4.4.1.2.2.2.3.2 | Cold Enc Mechanical Interface Design |  | 10d | 2011-06-24 | 2011-07-07 | 170 | 206.96d | 0d | Pollard [50%]; Nance [50%] | 80h | 6,000 |
| 172 | 1.4.4.1.2.2.2.4 | Cold Enc Request for Quote for COTS & Manufactured Parts |  | 5d | 2011-07-08 | 2011-07-15 | 171 | 206.96d |  | Nance [200%]; Pollard [20%] | 16h | 1,200 |
| 173 | 1.4.4.1.2.3 | **Cold Enc System Engineering Tasks** |  | 6.5d? | 2011-07-15 | 2011-07-25 |  | 206.96d |  |  | 40h | 4,040 |
| 174 | 1.4.4.1.2.3.1 | Cold Enc Installation Plan |  | 16h? | 2011-07-15 | 2011-07-19 | 161 | 206.96d | 0d | Pollard [75%]; Nance | 16h | 1,200 |
| 175 | 1.4.4.1.2.3.2 | Cold Enc Documentation |  | 20h? | 2011-07-20 | 2011-07-22 | 174 | 206.96d | 0d | Pollard [75%]; Nance | 16h | 1,200 |
| 176 | 1.4.4.1.2.3.3 | Cold Enc DDR Preparation |  | 12h | 2011-07-22 | 2011-07-25 | 175 | 206.96d |  | Pollard [33.3%]; Nance [33.3%] | 8h | 1,640 |
| 177 | 1.4.4.1.3 | AO Enclosure Mini-Review | milestone | 0d | 2011-09-30 | 2011-09-30 | 140, 159 | 157.96d | 0d |  |  |  |
| 178 | 1.4.4.2 | **AO Bench** |  | 452d? | 2010-10-01 | 2012-06-25 |  | 69d |  |  | 7576h | 568,200 |
| 179 | 1.4.4.2.1 | **AO Bench Support Structure (Mechanical)** |  | 150d | 2010-10-01 | 2011-04-28 |  | 370d | 0d |  | 1260h | 94,500 |
| 180 | 1.4.4.2.1.1 | AOB Custom Optical Table Specification with Vendors |  | 60d | 2010-10-01 | 2010-12-23 |  | 370d | 0d | Lockwood; Gavel [5%] | 504h | 37,800 |
| 181 | 1.4.4.2.1.2 | AOB Kinematic System and Hardware |  | 40d | 2010-12-24 | 2011-02-17 | 180 | 370d | 0d | Lockwood; Gavel [5%] | 336h | 25,200 |
| 182 | 1.4.4.2.1.3 | AOB Structural Pads and Restraints |  | 40d | 2011-02-18 | 2011-04-14 | 181 | 370d | 0d | Lockwood; Gavel [5%] | 336h | 25,200 |
| 183 | 1.4.4.2.1.4 | AOB Simulator Deck |  | 10d | 2011-04-15 | 2011-04-28 | 182 | 370d |  | Lockwood; Gavel [5%] | 84h | 6,300 |
| 184 | 1.4.4.2.2 | **Entrance & Exit Windows** |  | 98d | 2011-09-22 | 2012-02-06 |  | 74d |  |  | 756h | 56,700 |
| 185 | 1.4.4.2.2.1 | **Windows Optical** |  | 60d | 2011-09-22 | 2011-12-14 | 228 | 112d | 0d |  | 504h | 37,800 |
| 186 | 1.4.4.2.2.1.1 | Windows Coating Design |  | 30d | 2011-09-22 | 2011-11-02 |  | 112d | 0d | Kupke; Gavel [5%] | 252h | 18,900 |
| 187 | 1.4.4.2.2.1.2 | Specify Entrance Window |  | 5d | 2011-11-03 | 2011-11-09 | 186 | 112d | 0d | Kupke; Gavel [5%] | 42h | 3,150 |
| 188 | 1.4.4.2.2.1.3 | Specify LGS and DSM Windows |  | 25d | 2011-11-10 | 2011-12-14 | 187 | 112d |  | Kupke; Gavel [5%] | 210h | 15,750 |
| 189 | 1.4.4.2.2.2 | **Mechanical** |  | 30d | 2011-12-27 | 2012-02-06 | 236 | 69d | 0d |  | 252h | 18,900 |
| 190 | 1.4.4.2.2.2.1 | Windows Custom Mounting Interface |  | 30d | 2011-12-27 | 2012-02-06 |  | 69d |  | Lockwood; Gavel [5%] | 252h | 18,900 |
| 191 | 1.4.4.2.3 | **Rotator** |  | 108d | 2011-12-15 | 2012-05-14 |  | 69d |  |  | 756h | 56,700 |
| 192 | 1.4.4.2.3.1 | **Rotator Optical** |  | 20d | 2011-12-15 | 2012-01-11 | 185 | 112d | 0d |  | 168h | 12,600 |
| 193 | 1.4.4.2.3.1.1 | Rotator Optical Alignment Design |  | 20d | 2011-12-15 | 2012-01-11 |  | 112d |  | Kupke; Gavel [5%] | 168h | 12,600 |

Notes:
- 179: 8
- 184: 5
- 191: 6

| ID | WBS | Task | Duration | Start | Finish | Predecessors | Total slack | Free slack | Resources | Work | Cost |
| --- | --- | --- | --- | --- | --- | --- | --- | --- | --- | --- | --- |
| 194 | 1.4.4.2.3.2 | **Rotator Mechanical** | 70d | 2012-02-07 | 2012-05-14 | 189 | 69d | 0d |  | 588h | 44,100 |
| 195 | 1.4.4.2.3.2.1 | Rotator Custom Stage and Mount for Cal Fold | 30d | 2012-02-07 | 2012-03-19 |  | 69d | 0d | Lockwood; Gavel [5%] | 252h | 18,900 |
| 196 | 1.4.4.2.3.2.2 | Rotator K-Mirror Cells | 20d | 2012-03-20 | 2012-04-16 | 195 | 69d | 0d | Lockwood; Gavel [5%] | 168h | 12,600 |
| 197 | 1.4.4.2.3.2.3 | Rotator Rotating Structure | 20d | 2012-04-17 | 2012-05-14 | 196 | 69d |  | Lockwood; Gavel [5%] | 168h | 12,600 |
| 198 | 1.4.4.2.4 | **Wide Field Relay (WFR)** | 105d | 2010-10-01 | 2011-02-24 |  | 69d |  |  | 882h | 66,150 |
| 199 | 1.4.4.2.4.1 | **WFR Optical** | 60d | 2010-10-01 | 2010-12-23 |  | 69d | 0d |  | 504h | 37,800 |
| 200 | 1.4.4.2.4.1.1 | WFR OAPs | 40d | 2010-10-01 | 2010-11-25 |  | 69d | 0d | Kupke; Gavel [5%] | 336h | 25,200 |
| 201 | 1.4.4.2.4.1.2 | WFR Woofer DM Coating | 20d | 2010-11-26 | 2010-12-23 | 200 | 69d | 0d | Kupke; Gavel [5%] | 168h | 12,600 |
| 202 | 1.4.4.2.4.2 | **WFR Mechanical** | 45d | 2010-12-24 | 2011-02-24 |  | 69d | 0d |  | 378h | 28,350 |
| 203 | 1.4.4.2.4.2.1 | WFR 1st Turning Mirror Mount | 5d | 2010-12-24 | 2010-12-30 | 201 | 69d | 0d | Lockwood; Gavel [5%] | 42h | 3,150 |
| 204 | 1.4.4.2.4.2.2 | WFR OAP Mounts | 30d | 2010-12-31 | 2011-02-10 | 203 | 69d | 0d | Lockwood; Gavel [5%] | 252h | 18,900 |
| 205 | 1.4.4.2.4.2.3 | WFR Woofer DM | 10d | 2011-02-11 | 2011-02-24 | 204 | 69d |  | Kupke; Lockwood [5%] | 84h | 6,300 |
| 206 | 1.4.4.2.5 | **LGS WFS Feed** | 88d | 2011-04-08 | 2011-08-09 |  | 69d |  |  | 437h | 32,775 |
| 207 | 1.4.4.2.5.1 | **LGS WFS Feed Optical** | 40d | 2011-04-08 | 2011-06-02 | 217 | 112d | 0d |  | 202h | 15,150 |
| 208 | 1.4.4.2.5.1.1 | LGS Dichroic | 5d | 2011-04-08 | 2011-04-14 |  | 112d | 0d | Kupke; Gavel [5%] | 42h | 3,150 |
| 209 | 1.4.4.2.5.1.2 | LGS WFS Feed Fold Mirror | 5d | 2011-04-15 | 2011-04-21 | 208 | 112d | 0d | Kupke; Gavel [5%] | 34h | 2,550 |
| 210 | 1.4.4.2.5.1.3 | LGS WFS Feed Focusing Lens | 30d | 2011-04-22 | 2011-06-02 | 209 | 112d |  | Kupke [50%]; Gavel [50%] | 126h | 9,450 |
| 211 | 1.4.4.2.5.2 | **LGS WFS Feed Mechanical** | 29d | 2011-06-30 | 2011-08-09 | 221 | 69d | 0d |  | 235h | 17,625 |
| 212 | 1.4.4.2.5.2.1 | LGS Dichroic Mount | 10d | 2011-06-30 | 2011-07-13 |  | 69d | 0d | Lockwood; Gavel [5%] | 84h | 6,300 |
| 213 | 1.4.4.2.5.2.2 | LGS Dichroic Insertion Mechanism | 10d | 2011-07-14 | 2011-07-27 | 212 | 69d | 0d | Lockwood; Gavel [5%] | 84h | 6,300 |
| 214 | 1.4.4.2.5.2.3 | LGS WFS Feed Fold Mount | 4d | 2011-07-28 | 2011-08-02 | 213 | 69d | 0d | Lockwood; Gavel [5%] | 33h | 2,475 |
| 215 | 1.4.4.2.5.2.4 | LGS WFS Feed Focusing Lens Mount | 5d | 2011-08-03 | 2011-08-09 | 214 | 69d |  | Lockwood; Gavel [5%] | 34h | 2,550 |
| 216 | 1.4.4.2.6 | **Narrow Field Relay (NFR)** | 134d | 2010-12-24 | 2011-06-29 |  | 69d |  |  | 1327h | 99,525 |
| 217 | 1.4.4.2.6.1 | **NFR Optical** | 75d | 2010-12-24 | 2011-04-07 | 199 | 112d | 0d |  | 588h | 44,100 |
| 218 | 1.4.4.2.6.1.1 | NFR Turning Mirror | 5d | 2010-12-24 | 2010-12-30 |  | 112d | 0d | Kupke; Gavel [5%] | 42h | 3,150 |
| 219 | 1.4.4.2.6.1.2 | NFR OAPs | 60d | 2010-12-31 | 2011-03-24 | 218 | 112d | 0d | Kupke; Gavel [5%] | 504h | 37,800 |
| 220 | 1.4.4.2.6.1.3 | NFR Optics Support for Mechanical | 10d | 2011-03-25 | 2011-04-07 | 219 | 112d |  | Kupke [50%]; Gavel [50%] | 42h | 3,150 |

Notes:
- 198: Happen 1st
- 206: 3rd
- 216: Happen 1st.

| ID | WBS | Task | Duration | Start | Finish | Predecessors | Total slack | Free slack | Resources | Work | Cost |
| --- | --- | --- | --- | --- | --- | --- | --- | --- | --- | --- | --- |
| 221 | 1.4.4.2.6.2 | **Mechanical** | 89d | 2011-02-25 | 2011-06-29 | 202 | 69d | 0d |  | 739h | 55,425 |
| 222 | 1.4.4.2.6.2.1 | NFR Optical Table Platform & LOWFS Interface | 20d | 2011-02-25 | 2011-03-24 |  | 69d | 0d | Lockwood; Gavel [5%] | 168h | 12,600 |
| 223 | 1.4.4.2.6.2.2 | NFR Turning Mirror Mount | 4d | 2011-03-25 | 2011-03-30 | 222 | 69d | 0d | Lockwood; Gavel [5%] | 33h | 2,475 |
| 224 | 1.4.4.2.6.2.3 | NFR OAP Mounts | 5d | 2011-03-31 | 2011-04-06 | 223 | 69d | 0d | Lockwood; Gavel [5%] | 34h | 2,550 |
| 225 | 1.4.4.2.6.2.4 | NFR Tweeter Stage | 40d | 2011-04-07 | 2011-06-01 | 224 | 69d | 0d | Lockwood; Gavel [5%] | 336h | 25,200 |
| 226 | 1.4.4.2.6.2.5 | NFR MEMS Cable Relief System | 20d | 2011-06-02 | 2011-06-29 | 225 | 69d |  | Lockwood; Gavel [5%] | 168h | 12,600 |
| 227 | 1.4.4.2.7 | **Optical Switchyard (SY)** | 147d? | 2011-06-03 | 2011-12-26 |  | 69d |  |  | 1252h | 93,900 |
| 228 | 1.4.4.2.7.1 | **SY Optical** | 79d? | 2011-06-03 | 2011-09-21 | 207 | 112d | 0d |  | 437h | 32,775 |
| 229 | 1.4.4.2.7.1.1 | Support SY Mechanical Design | 5d | 2011-06-03 | 2011-06-09 |  | 112d | 0d | Kupke; Gavel [5%] | 42h | 3,150 |
| 230 | 1.4.4.2.7.1.2 | Specify IF Dichroic | 10d | 2011-06-10 | 2011-06-23 | 229 | 112d | 0d | Kupke; Gavel [5%] | 84h | 6,300 |
| 231 | 1.4.4.2.7.1.3 | Specify IF Field Steering Mirrors | 10d? | 2011-06-24 | 2011-07-07 | 230 | 112d | 0d | Kupke; Gavel | 84h | 6,300 |
| 232 | 1.4.4.2.7.1.4 | Support IF DSM Modifications | 20d | 2011-07-08 | 2011-08-04 | 231 | 112d | 0d | Kupke [50%]; Gavel [50%] | 84h | 6,300 |
| 233 | 1.4.4.2.7.1.5 | Specify NGS WFS Dichroic | 20d | 2011-08-05 | 2011-09-01 | 232 | 112d | 0d | Kupke [50%]; Gavel [50%] | 84h | 6,300 |
| 234 | 1.4.4.2.7.1.6 | Specify Acquisition & Instrument Fold Mirrors | 4d | 2011-09-02 | 2011-09-07 | 233 | 112d | 0d | Kupke [50%]; Gavel [50%] | 17h | 1,275 |
| 235 | 1.4.4.2.7.1.7 | Specify NGS WFS Focusing Lens | 10d | 2011-09-08 | 2011-09-21 | 234 | 112d |  | Kupke [50%]; Gavel [50%] | 42h | 3,150 |
| 236 | 1.4.4.2.7.2 | **SY Mechanical** | 99d | 2011-08-10 | 2011-12-26 | 211 | 69d | 0d |  | 815h | 61,125 |
| 237 | 1.4.4.2.7.2.1 | Specify Flat Mirror Mount | 5d | 2011-08-10 | 2011-08-16 |  | 69d | 0d | Lockwood; Gavel [5%] | 34h | 2,550 |
| 238 | 1.4.4.2.7.2.2 | IF Dichroic Mechanism | 15d | 2011-08-17 | 2011-09-06 | 237 | 69d | 0d | Lockwood; Gavel [5%] | 126h | 9,450 |
| 239 | 1.4.4.2.7.2.3 | IF DSM Field Selector | 30d | 2011-09-07 | 2011-10-18 | 238 | 69d | 0d | Lockwood; Gavel [5%] | 252h | 18,900 |
| 240 | 1.4.4.2.7.2.4 | Acquisition Camera Fold Mount & Mechanism | 30d | 2011-10-19 | 2011-11-29 | 239 | 69d | 0d | Lockwood; Gavel [5%] | 252h | 18,900 |
| 241 | 1.4.4.2.7.2.5 | NGS WFS Dichroic Mechanism | 14d | 2011-11-30 | 2011-12-19 | 240 | 69d | 0d | Lockwood; Gavel [5%] | 117h | 8,775 |
| 242 | 1.4.4.2.7.2.6 | NGS WFS Focusing Lens Mount | 5d | 2011-12-20 | 2011-12-26 | 241 | 69d |  | Lockwood; Gavel [5%] | 34h | 2,550 |
| 243 | 1.4.4.2.8 | **Atmospheric Dispersion Corrector** | 118d | 2012-01-12 | 2012-06-25 |  | 69d |  |  | 882h | 66,150 |
| 244 | 1.4.4.2.8.1 | **ADC Optical** | 75d | 2012-01-12 | 2012-04-25 | 192 | 112d |  |  | 630h | 47,250 |
| 245 | 1.4.4.2.8.1.1 | **Vis ADC** | 35d | 2012-01-12 | 2012-02-29 |  | 112d |  |  | 294h | 22,050 |
| 246 | 1.4.4.2.8.1.1.1 | Vis ADC Tolerancing | 5d | 2012-01-12 | 2012-01-18 |  | 112d | 0d | Kupke; Gavel [5%] | 42h | 3,150 |
| 247 | 1.4.4.2.8.1.1.2 | Vis ADC Selection | 20d | 2012-01-19 | 2012-02-15 | 246 | 112d | 0d | Kupke; Gavel [5%] | 168h | 12,600 |
| 248 | 1.4.4.2.8.1.1.3 | Vis ADC Acceptance Tests | 10d | 2012-02-16 | 2012-02-29 | 247 | 112d | 0d | Kupke; Gavel [5%] | 84h | 6,300 |

Notes:
- 227: 4th
- 243: 7

| ID | WBS | Task | Duration | Start | Finish | Predecessors | Total slack | Free slack | Resources | Work | Cost |
| --- | --- | --- | --- | --- | --- | --- | --- | --- | --- | --- | --- |
| 249 | 1.4.4.2.8.1.2 | **IR ADC** | 40d | 2012-03-01 | 2012-04-25 |  | 112d |  |  | 336h | 25,200 |
| 250 | 1.4.4.2.8.1.2.1 | IR ADC Thermal Analysis | 5d | 2012-03-01 | 2012-03-07 | 248 | 112d | 0d | Kupke; Gavel [5%] | 42h | 3,150 |
| 251 | 1.4.4.2.8.1.2.2 | IR ADC Tolerencing | 5d | 2012-03-08 | 2012-03-14 | 250 | 112d | 0d | Kupke; Gavel [5%] | 42h | 3,150 |
| 252 | 1.4.4.2.8.1.2.3 | IR ADC Thermal Vendor Selection | 20d | 2012-03-15 | 2012-04-11 | 251 | 112d | 0d | Kupke; Gavel [5%] | 168h | 12,600 |
| 253 | 1.4.4.2.8.1.2.4 | IR ADC Thermal Acceptance Tests | 10d | 2012-04-12 | 2012-04-25 | 252 | 112d |  | Kupke; Gavel [5%] | 84h | 6,300 |
| 254 | 1.4.4.2.8.2 | **ADC Mechanical** | 30d | 2012-05-15 | 2012-06-25 | 194 | 69d |  |  | 252h | 18,900 |
| 255 | 1.4.4.2.8.2.1 | ADC Rotation Stage | 5d | 2012-05-15 | 2012-05-21 |  | 69d | 0d | Lockwood; Gavel [5%] | 42h | 3,150 |
| 256 | 1.4.4.2.8.2.2 | ADC Mount System | 20d | 2012-05-22 | 2012-06-18 | 255 | 69d | 0d | Lockwood; Gavel [5%] | 168h | 12,600 |
| 257 | 1.4.4.2.8.2.3 | ADC Translation Stage | 5d | 2012-06-19 | 2012-06-25 | 256 | 69d |  | Lockwood; Gavel [5%] | 42h | 3,150 |
| 258 | 1.4.4.2.9 | AO Bench Mini Design Review | 1d | 2011-04-29 | 2011-04-29 | 179 | 370d | 0d | Gavel; Kupke; Lockwood | 24h | 1,800 |
| 259 | 1.4.4.3 | **LGSWFS Assembly** | 454d? | 2010-10-01 | 2012-06-27 |  | 67d |  |  | 2810h | 210,750 |
| 260 | 1.4.4.3.1 | **LGSWFS Management and Planning** | 452d | 2010-10-01 | 2012-06-25 |  | 69d |  |  | 360h | 27,000 |
| 261 | 1.4.4.3.1.1 | LGSWFS Management | 452d | 2010-10-01 | 2012-06-25 |  | 69d |  | Dekany [2.8%] | 100h | 7,500 |
| 262 | 1.4.4.3.1.2 | LGSWFS Team Meetings | 452d | 2010-10-01 | 2012-06-25 |  | 69d |  | Velur [1.8%]; Delacroix [1.8%]; Fucik [1.8%] | 200h | 15,000 |
| 263 | 1.4.4.3.1.3 | LGSWFS Liaise with RTC and detector team/ vendors to make sure that the design is consistent. | 452d | 2010-10-01 | 2012-06-25 |  | 69d |  | Velur [0.8%]; Delacroix [0.8%] | 60h | 4,500 |
| 264 | 1.4.4.3.2 | **LGSWFS Engineering** | 436.88d? | 2010-10-01 | 2012-06-04 |  | 67.12d | 14.12d |  | 2026h | 151,950 |
| 265 | 1.4.4.3.2.1 | **LGSWFS (Optical and mechanical) design of the LGS WFS (fixed + patrolling WFS's) wavefront sensor assembly.** | 150.62d? | 2010-10-01 | 2011-04-29 |  | 67.12d |  |  | 498h | 37,350 |
| 266 | 1.4.4.3.2.1.1 | LGSWFS Optical design of the Fixed LGSWFS | 36.25d? | 2010-10-01 | 2010-11-22 |  | 67.12d | 0d | Velur [40%]; Fucik [40%] | 132h | 9,900 |
| 267 | 1.4.4.3.2.1.2 | LGSWFS Optical design of the Patrolling LGSWFS | 31.25d? | 2010-11-22 | 2011-01-04 | 266 | 67.12d | 0d | Velur [40%] | 100h | 7,500 |
| 268 | 1.4.4.3.2.1.3 | LGSWFS Mechanical Design of the Fixed LGSWFS | 44.06d? | 2011-01-04 | 2011-03-07 | 267 | 367.38d | 0d | Delacroix [40%] | 141h | 10,575 |
| 269 | 1.4.4.3.2.1.4 | LGSWFS Mechanical design of the Patrolling LGSWFS | 39.06d? | 2011-03-07 | 2011-04-29 | 268 | 367.38d |  | Delacroix [40%] | 125h | 9,375 |
| 270 | 1.4.4.3.2.2 | **LGSWFS design of the OSM mechanism + fixed pick off arrangement** | 135d? | 2011-01-04 | 2011-07-12 |  | 67.12d |  |  | 448h | 33,600 |
| 271 | 1.4.4.3.2.2.1 | LGSWFS Optical design of the Fixed LGSWFS pick off (central LGSWFS and the 3 surrounding ones) | 30d? | 2011-01-04 | 2011-02-15 | 267 | 67.12d | 0d | Velur [40%]; Fucik [40%] | 112h | 8,400 |
| 272 | 1.4.4.3.2.2.2 | LGSWFS Optical design of the Patrolling LGSWFS pick-off | 25d? | 2011-02-15 | 2011-03-22 | 271 | 67.12d | 0d | Velur [40%] | 80h | 6,000 |
| 273 | 1.4.4.3.2.2.3 | LGSWFS Mechanical Design of the Fixed LGSWFS pick-off | 42.5d? | 2011-03-22 | 2011-05-19 | 272 | 67.12d | 0d | Delacroix [40%] | 136h | 10,200 |
| 274 | 1.4.4.3.2.2.4 | LGSWFS Mechanical design of the Patrolling LGSWFS pick-off | 37.5d? | 2011-05-20 | 2011-07-12 | 273 | 67.12d | 0d | Delacroix [40%] | 120h | 9,000 |
| 275 | 1.4.4.3.2.3 | LGSWFS Verify that all motorized components are compliant with NGAO software paradigm. Liaise with Supervisory control team to consolidate controllers and spare mechanisms. | 12.5d? | 2011-07-12 | 2011-07-28 | 274 | 67.12d | 0d | Velur [50%]; Delacroix [50%]; Fucik [50%] | 80h | 6,000 |

| ID | WBS | Task | Duration | Start | Finish | Predecessors | Total slack | Free slack | Resources | Work | Cost |
| --- | --- | --- | --- | --- | --- | --- | --- | --- | --- | --- | --- |
| 276 | 1.4.4.3.2.4 | **LGSWFS FEA and tolerance** | 125d? | 2011-07-28 | 2012-01-19 |  | 67.12d |  |  | 430h | 32,250 |
| 277 | 1.4.4.3.2.4.1 | LGSWFS Package and model the assembly (incl. FEA analysis) | 62.5d? | 2011-07-28 | 2011-10-25 | 275 | 67.12d | 0d | Velur [40%]; Delacroix [40%]; Fucik [40%] | 200h | 15,000 |
| 278 | 1.4.4.3.2.4.2 | LGSWFS Perform detailed tolerance analysis for the individual units and the entire assembly (incl. detailed analysis of the effect of introducing dichroics andADCs) | 62.5d? | 2011-10-25 | 2012-01-19 | 277 | 67.12d | 0d | Velur [40%]; Delacroix [40%]; Fucik [40%] | 230h | 17,250 |
| 279 | 1.4.4.3.2.5 | LGSWFS Specify and get quotes for the OSM assembly components | 15.62d? | 2012-01-19 | 2012-02-10 | 278 | 67.12d | 0d | Velur [40%]; Delacroix [40%]; Fucik [40%] | 60h | 4,500 |
| 280 | 1.4.4.3.2.6 | LGSWFS Specify and get quotes for optics, mounts, stages and detectors | 15.62d? | 2012-02-10 | 2012-03-05 | 279 | 67.12d | 0d | Velur [40%]; Delacroix [40%]; Fucik [40%] | 90h | 6,750 |
| 281 | 1.4.4.3.2.7 | LGSWFS Specify interfaces (optical, mechanical and electronics) | 15.62d? | 2012-03-05 | 2012-03-26 | 280 | 67.12d | 0d | Velur [40%]; Delacroix [40%]; Fucik [40%] | 80h | 6,000 |
| 282 | 1.4.4.3.2.8 | LGSWFS Reconcile the performance of detailed design with error budget. | 37.5d? | 2012-03-26 | 2012-05-17 | 281 | 84.12d | 0d | Velur [40%]; Delacroix [40%]; Fucik [40%] | 160h | 12,000 |
| 283 | 1.4.4.3.2.9 | LGSWFS Get shop drawings out for all components with bill of materials. | 50d? | 2012-03-26 | 2012-06-04 | 281 | 81.12d |  | Velur [40%]; Delacroix [40%]; Fucik [40%] | 180h | 13,500 |
| 284 | 1.4.4.3.3 | **LGSWFS Documentation and review** | 64.12d? | 2012-03-26 | 2012-06-24 |  | 67.12d |  |  | 400h | 30,000 |
| 285 | 1.4.4.3.3.1 | LGSWFS Define cabling plan. | 12.5d? | 2012-03-26 | 2012-04-12 | 281 | 67.12d | 0d | Velur [40%]; Delacroix [40%]; Fucik [40%] | 60h | 4,500 |
| 286 | 1.4.4.3.3.2 | LGSWFS Write a detailed alignment plan for the assembly | 25d? | 2012-04-12 | 2012-05-17 | 285 | 71.62d | 0d | Velur [40%]; Delacroix [40%]; Fucik [40%] | 80h | 6,000 |
| 287 | 1.4.4.3.3.3 | LGSWFS Develop a detailed I&T plan for the assembly. | 25d? | 2012-05-17 | 2012-06-21 | 286 | 71.62d |  | Velur [40%]; Delacroix [40%]; Fucik [40%] | 80h | 6,000 |
| 288 | 1.4.4.3.3.4 | LGSWFS Build a complete compliance matrix to test for conformance to requirements. | 12.5d? | 2012-05-17 | 2012-06-04 | 282 | 84.12d |  | Velur [40%]; Delacroix [40%]; Fucik [40%] | 60h | 4,500 |
| 289 | 1.4.4.3.3.5 | LGSWFS Document Support | 3emo | 2012-03-26 | 2012-06-24 | 285SS | 281d | 2d | Velur [40%]; Delacroix [4.6%]; Fucik [40%] | 120h | 9,000 |
| 290 | 1.4.4.3.4 | LGSWFS Mini Design Review | 3d | 2012-06-25 | 2012-06-27 | 264, 289 | 67d | 0d | Velur [33.3%]; Delacroix [33.3%]; Fucik [33.3%] | 24h | 1,800 |
| 291 | 1.4.4.4 | **NGSWFS Assembly** | 389d? | 2010-10-01 | 2012-03-28 |  | 132d |  |  | 1994h | 149,550 |
| 292 | 1.4.4.4.1 | **NGSWFS Management and Planning** | 389d | 2010-10-01 | 2012-03-28 |  | 132d | 0d |  | 240h | 18,000 |
| 293 | 1.4.4.4.1.1 | Subsystem Management | 389d | 2010-10-01 | 2012-03-28 |  | 132d |  | Dekany [2.6%] | 80h | 6,000 |
| 294 | 1.4.4.4.1.2 | NGSWFS Team Meetings | 389d | 2010-10-01 | 2012-03-28 |  | 132d |  | Delacroix [1%]; Velur [1%]; Fucik [1%]; Dekany [1%] | 120h | 9,000 |
| 295 | 1.4.4.4.1.3 | Liaise with RTC and detector team/ vendors to make sure that the design is consistent. | 389d | 2010-10-01 | 2012-03-28 |  | 132d |  | Velur [0.6%]; Delacroix [0.6%]; Fucik [1%] | 40h | 3,000 |
| 296 | 1.4.4.4.2 | **NGSWFS Engineering** | 198.21d? | 2010-10-01 | 2011-07-06 | 292SS | 132.29d |  |  | 1020h | 76,500 |
| 297 | 1.4.4.4.2.1 | **Steering mirror pick-off design** | 56.25d? | 2010-10-01 | 2010-12-20 |  | 464.75d |  |  | 230h | 17,250 |
| 298 | 1.4.4.4.2.1.1 | Detailed optical design of FSM pair | 25d? | 2010-10-01 | 2010-11-04 |  | 464.75d | 0d | Velur [40%] | 80h | 6,000 |
| 299 | 1.4.4.4.2.1.2 | Detailed mechanical design of FSM pair | 31.25d? | 2010-11-05 | 2010-12-20 | 298 | 464.75d |  | Delacroix [40%]; Fucik [40%] | 150h | 11,250 |

| ID | WBS | Task | Duration | Start | Finish | Predecessors | Total slack | Free slack | Constraint | Resources | Work | Cost |
| --- | --- | --- | --- | --- | --- | --- | --- | --- | --- | --- | --- | --- |
| 300 | 1.4.4.4.2.2 | **WFS design** | 66.96d? | 2010-10-01 | 2011-01-03 |  | 132.29d |  |  |  | 300h | 22,500 |
| 301 | 1.4.4.4.2.2.1 | Detailed optical design of the NGSWFS | 31.25d? | 2010-10-01 | 2010-11-15 |  | 132.29d | 0d |  | Velur [40%] | 100h | 7,500 |
| 302 | 1.4.4.4.2.2.2 | Detailed mechanical design of the NGSWFS | 35.71d? | 2010-11-15 | 2011-01-03 | 301 | 132.29d | 0d |  | Velur [40%]; Delacroix [40%]; Fucik [40%] | 200h | 15,000 |
| 303 | 1.4.4.4.2.3 | Ensure that all motion control components of the NGS WFS assembly are compliant with the motion control architecture of the system (this may involve changes in choice of stages or convincing the controls team to enhance the variety of stages that they sup | 6.25d? | 2011-01-03 | 2011-01-12 | 302 | 132.29d | 0d |  | Velur [40%]; Delacroix [40%]; Fucik [40%] | 30h | 2,250 |
| 304 | 1.4.4.4.2.4 | Detailed design of the NGS/TWFS field-steering mirror mechanism | 68.75d? | 2011-01-12 | 2011-04-18 | 303 | 132.29d | 0d |  | Velur [40%]; Delacroix [40%]; Fucik [40%] | 250h | 18,750 |
| 305 | 1.4.4.4.2.5 | Specify and get quotes for the motion control for the field-steering-mirror mechanism. | 6.25d? | 2011-04-18 | 2011-04-27 | 304 | 132.29d | 0d |  | Velur [40%]; Delacroix [40%]; Fucik [40%] | 20h | 1,500 |
| 306 | 1.4.4.4.2.6 | Specify and get quotes for optics, mounts, stages and detectors | 12.5d? | 2011-04-27 | 2011-05-13 | 305 | 132.29d | 0d |  | Velur [40%]; Delacroix [40%]; Fucik [40%] | 50h | 3,750 |
| 307 | 1.4.4.4.2.7 | Get shop drawings out for all components with bill of materials. | 37.5d? | 2011-05-13 | 2011-07-06 | 306 | 132.29d | 0d |  | Velur [40%]; Delacroix [40%]; Fucik [40%] | 140h | 10,500 |
| 308 | 1.4.4.4.3 | **NGSWFS FEA analysis and Tolerance** | 68.75d? | 2011-07-06 | 2011-10-10 | 307 | 132.29d |  |  |  | 260h | 19,500 |
| 309 | 1.4.4.4.3.1 | Package and model the assembly (incl. FEA analysis) | 31.25d? | 2011-07-06 | 2011-08-18 |  | 132.29d | 0d |  | Velur [40%]; Delacroix [40%]; Fucik [40%] | 120h | 9,000 |
| 310 | 1.4.4.4.3.2 | Perform detailed tolerance analysis for each of the units and the entire assembly (incl. detailed analysis of the effect of introducing dichroics andADCs) | 37.5d? | 2011-08-18 | 2011-10-10 | 309 | 132.29d | 0d |  | Velur [40%]; Delacroix [40%]; Fucik [40%] | 140h | 10,500 |
| 311 | 1.4.4.4.4 | **NGSWFS Documentation** | 118.75d? | 2011-10-10 | 2012-03-23 |  | 132.29d |  |  |  | 450h | 33,750 |
| 312 | 1.4.4.4.4.1 | Specify interfaces (optical, mechanical and electronics) | 9.38d? | 2011-10-10 | 2011-10-24 | 310 | 132.29d | 0d |  | Velur [40%]; Delacroix [40%]; Fucik [40%] | 50h | 3,750 |
| 313 | 1.4.4.4.4.2 | Define cabling plan. | 9.38d? | 2011-10-24 | 2011-11-04 | 312 | 132.29d | 0d |  | Velur [40%]; Delacroix [40%]; Fucik [40%] | 50h | 3,750 |
| 314 | 1.4.4.4.4.3 | Reconcile the performance of detailed design with error budget. | 25d? | 2011-11-04 | 2011-12-09 | 313 | 132.29d | 0d |  | Velur [40%]; Delacroix [40%]; Fucik [40%] | 90h | 6,750 |
| 315 | 1.4.4.4.4.4 | Write a detailed alignment plan for the assembly | 25d? | 2011-12-09 | 2012-01-13 | 314 | 132.29d | 0d |  | Velur [40%]; Delacroix [40%]; Fucik [40%] | 80h | 6,000 |
| 316 | 1.4.4.4.4.5 | Develop a detailed I&T plan for the assembly. | 25d? | 2012-01-13 | 2012-02-17 | 315 | 132.29d | 0d |  | Velur [40%]; Delacroix [40%]; Fucik [40%] | 80h | 6,000 |
| 317 | 1.4.4.4.4.6 | Build a complete compliance matrix to test for conformance to requirements. | 12.5d? | 2012-02-17 | 2012-03-07 | 316 | 132.29d | 0d |  | Velur [40%]; Delacroix [40%]; Fucik [40%] | 50h | 3,750 |
| 318 | 1.4.4.4.4.7 | Document Support | 12.5d? | 2012-03-07 | 2012-03-23 | 317 | 132.29d | 0d |  | Velur [40%]; Delacroix [40%]; Fucik [40%] | 50h | 3,750 |
| 319 | 1.4.4.4.5 | NGSWFS Mini Design Review | 3d | 2012-03-23 | 2012-03-28 | 318 | 132.29d | 0d |  | Delacroix [25%]; Dekany [25%]; Velur [25%]; Fucik [25%] | 24h | 1,800 |
| 320 | 1.4.4.5 | **LOWFS Assembly** | 521d? | 2010-10-01 | 2012-09-28 |  | 0d |  |  |  | 4333.8h | 325,035 |
| 321 | 1.4.4.5.1 | **LOWFS Management and Planning** | 521d | 2010-10-01 | 2012-09-28 |  | 0d |  |  |  | 699h | 52,425 |
| 322 | 1.4.4.5.1.1 | LOWFS Management | 521d | 2010-10-01 | 2012-09-28 |  | 0d |  | finish no earlier than 2012-09-28 | Dekany [7.6%] | 315h | 23,625 |
| 323 | 1.4.4.5.1.2 | LOWFS Team Meetings | 521d | 2010-10-01 | 2012-09-28 |  | 0d |  |  | Wallace [2.2%]; Croner [2.2%]; Bartos [2.2%]; Rahmer [2.2%]; SmithR [2%] | 384h | 28,800 |

| ID | WBS | Task | Duration | Start | Finish | Predecessors | Total slack | Free slack | Resources | Work | Cost |
| --- | --- | --- | --- | --- | --- | --- | --- | --- | --- | --- | --- |
| 324 | 1.4.4.5.2 | **LOWFS Subsystems Engineering** | 500d | 2010-10-01 | 2012-08-30 |  | 21d |  |  | 860h | 64,500 |
| 325 | 1.4.4.5.2.1 | Optical design tolerancing | 20d | 2010-10-01 | 2010-10-28 |  | 351d | 0d | Wallace [25%] | 40h | 3,000 |
| 326 | 1.4.4.5.2.2 | External mechanical interfaces | 250d | 2010-10-01 | 2011-09-15 |  | 21d | 0d | Bartos [10%] | 200h | 15,000 |
| 327 | 1.4.4.5.2.3 | External electrical interfaces | 20d | 2010-10-01 | 2010-10-28 |  | 501d |  | Rahmer | 160h | 12,000 |
| 328 | 1.4.4.5.2.4 | Thermal engineering of cryostats | 300d | 2010-10-01 | 2011-11-24 |  | 221d |  | Bartos [5%] | 120h | 9,000 |
| 329 | 1.4.4.5.2.5 | Subsystem I&T plan | 150d | 2010-10-29 | 2011-05-26 | 325 | 351d |  | Wallace [10%] | 120h | 9,000 |
| 330 | 1.4.4.5.2.6 | Subsystem test plan | 150d | 2010-10-01 | 2011-04-28 |  | 371d |  | SmithR [10%] | 120h | 9,000 |
| 331 | 1.4.4.5.2.7 | Design Report | 250d | 2011-09-16 | 2012-08-30 | 326 | 21d |  | Wallace [5%] | 100h | 7,500 |
| 332 | 1.4.4.5.3 | **LOWFS Support Structure** | 95d | 2010-10-01 | 2011-02-10 |  | 88d | 0d |  | 152h | 11,400 |
| 333 | 1.4.4.5.3.1 | LOWFS support structure detailed mechanical design | 50d | 2010-10-01 | 2010-12-09 |  | 88d | 0d | Bartos [20%] | 80h | 6,000 |
| 334 | 1.4.4.5.3.2 | LOWFS support structure FEA modelling | 20d | 2010-12-10 | 2011-01-06 | 333 | 88d | 0d | Bartos [20%] | 32h | 2,400 |
| 335 | 1.4.4.5.3.3 | LOWFS support structure shop drawings | 25d | 2011-01-07 | 2011-02-10 | 334 | 88d |  | Bartos [20%] | 40h | 3,000 |
| 336 | 1.4.4.5.4 | **LOWFS Pickoff Arm Assemblies** | 225.5d | 2011-02-11 | 2011-12-23 |  | 88d | 0d |  | 548.8h | 41,160 |
| 337 | 1.4.4.5.4.1 | **Pickoff Arm Mechanisms** | 47.5d | 2011-02-11 | 2011-04-19 | 332 | 88d | 0d |  | 152h | 11,400 |
| 338 | 1.4.4.5.4.1.1 | Crack and Level Motor Analysis | 10d | 2011-02-11 | 2011-02-24 |  | 88d | 0d | Bartos [40%] | 32h | 2,400 |
| 339 | 1.4.4.5.4.1.2 | Precision Motor Encoder Design | 25d | 2011-02-25 | 2011-03-31 | 338 | 88d | 0d | Bartos [40%] | 80h | 6,000 |
| 340 | 1.4.4.5.4.1.3 | Precision Motor Encoder Shop Drawings | 12.5d | 2011-04-01 | 2011-04-19 | 339 | 88d |  | Bartos [40%] | 40h | 3,000 |
| 341 | 1.4.4.5.4.2 | **Cantelever Arm Assembly** | 8d | 2011-04-19 | 2011-04-29 | 337 | 88d | 0d |  | 12.8h | 960 |
| 342 | 1.4.4.5.4.2.1 | Cantelever Arm Assembly detailed design | 4d | 2011-04-19 | 2011-04-25 |  | 88d | 0d | Bartos [20%] | 6.4h | 480 |
| 343 | 1.4.4.5.4.2.2 | Cantelever Arm Assembly shop drawings | 4d | 2011-04-25 | 2011-04-29 | 342 | 88d |  | Bartos [20%] | 6.4h | 480 |
| 344 | 1.4.4.5.4.3 | **Periscope Support Structure** | 22.5d | 2011-04-29 | 2011-05-31 | 341 | 88d | 0d |  | 72h | 5,400 |
| 345 | 1.4.4.5.4.3.1 | Periscope Support Structure detailed design | 10d | 2011-04-29 | 2011-05-13 |  | 88d | 0d | Bartos [40%] | 32h | 2,400 |
| 346 | 1.4.4.5.4.3.2 | Periscope Support Structure shop drawings | 5d | 2011-05-13 | 2011-05-20 | 345 | 88d | 0d | Bartos [40%] | 16h | 1,200 |
| 347 | 1.4.4.5.4.3.3 | Counterweight detailed design | 2.5d | 2011-05-20 | 2011-05-24 | 346 | 88d | 0d | Bartos [40%] | 8h | 600 |
| 348 | 1.4.4.5.4.3.4 | Counterweights shop drawings | 1.25d | 2011-05-25 | 2011-05-26 | 347 | 88d | 0d | Bartos [40%] | 4h | 300 |
| 349 | 1.4.4.5.4.3.5 | Limit switch mount detailed design | 2.5d | 2011-05-26 | 2011-05-30 | 348 | 88d | 0d | Bartos [40%] | 8h | 600 |
| 350 | 1.4.4.5.4.3.6 | Limit switch mount shop drawings | 1.25d | 2011-05-30 | 2011-05-31 | 349 | 88d |  | Bartos [40%] | 4h | 300 |

| ID | WBS | Task | Duration | Start | Finish | Predecessors | Total slack | Free slack | Resources | Work | Cost | Text1 |
| --- | --- | --- | --- | --- | --- | --- | --- | --- | --- | --- | --- | --- |
| 351 | 1.4.4.5.4.4 | **Limit Switch Track** | 17.5d | 2011-06-01 | 2011-06-24 | 344 | 218d |  |  | 56h | 4,200 |  |
| 352 | 1.4.4.5.4.4.1 | Limit Switch Track detailed design | 12.5d | 2011-06-01 | 2011-06-17 |  | 218d | 0d | Bartos [40%] | 40h | 3,000 |  |
| 353 | 1.4.4.5.4.4.2 | Limit Switch Track shop drawings | 5d | 2011-06-17 | 2011-06-24 | 352 | 218d |  | Bartos [40%] | 16h | 1,200 |  |
| 354 | 1.4.4.5.4.5 | **Focal Plane Pickoff Mirror** | 37.5d | 2011-06-01 | 2011-07-22 | 344 | 88d | 0d |  | 84h | 6,300 |  |
| 355 | 1.4.4.5.4.5.1 | Focal Plane Pickoff Mirror specification | 10d | 2011-06-01 | 2011-06-14 |  | 88d | 0d | Wallace [10%] | 8h | 600 |  |
| 356 | 1.4.4.5.4.5.2 | Focal Plane Pickoff Mirror coating specificiation | 5d | 2011-06-15 | 2011-06-21 | 355 | 88d | 0d | Wallace [10%] | 4h | 300 |  |
| 357 | 1.4.4.5.4.5.3 | Mount detailed design | 15d | 2011-06-22 | 2011-07-12 | 356 | 88d | 0d | Bartos [40%] | 48h | 3,600 |  |
| 358 | 1.4.4.5.4.5.4 | Mount shop drawings | 7.5d | 2011-07-13 | 2011-07-22 | 357 | 88d |  | Bartos [40%] | 24h | 1,800 |  |
| 359 | 1.4.4.5.4.6 | **Collimating Lens** | 37.5d | 2011-07-22 | 2011-09-13 | 354 | 88d | 0d |  | 48h | 3,600 |  |
| 360 | 1.4.4.5.4.6.1 | Collimating Lens specification | 20d | 2011-07-22 | 2011-08-19 |  | 88d | 0d | Wallace [10%] | 16h | 1,200 |  |
| 361 | 1.4.4.5.4.6.2 | Collimating Lens coating specificiation | 10d | 2011-08-19 | 2011-09-02 | 360 | 88d | 0d | Wallace [10%] | 8h | 600 |  |
| 362 | 1.4.4.5.4.6.3 | Mount detailed design | 5d | 2011-09-02 | 2011-09-09 | 361 | 88d | 0d | Bartos [40%] | 16h | 1,200 |  |
| 363 | 1.4.4.5.4.6.4 | Mount shop drawings | 2.5d | 2011-09-09 | 2011-09-13 | 362 | 88d |  | Bartos [40%] | 8h | 600 |  |
| 364 | 1.4.4.5.4.7 | **Flat Mirrors** | 35d | 2011-09-14 | 2011-11-01 | 359 | 88d | 0d |  | 76h | 5,700 |  |
| 365 | 1.4.4.5.4.7.1 | Flat Mirror specification | 10d | 2011-09-14 | 2011-09-27 |  | 88d | 0d | Wallace [10%] | 8h | 600 |  |
| 366 | 1.4.4.5.4.7.2 | Flat Mirror coating specificiation | 5d | 2011-09-28 | 2011-10-04 | 365 | 88d | 0d | Wallace [10%] | 4h | 300 |  |
| 367 | 1.4.4.5.4.7.3 | Mounts detailed design | 12.5d | 2011-10-05 | 2011-10-21 | 366 | 88d | 0d | Bartos [40%] | 40h | 3,000 |  |
| 368 | 1.4.4.5.4.7.4 | Mounts shop drawings | 7.5d | 2011-10-21 | 2011-11-01 | 367 | 88d |  | Bartos [40%] | 24h | 1,800 |  |
| 369 | 1.4.4.5.4.8 | **Reimaging Lens** | 37.5d | 2011-11-02 | 2011-12-23 | 364 | 88d |  |  | 48h | 3,600 |  |
| 370 | 1.4.4.5.4.8.1 | Reimaing Lens specification | 20d | 2011-11-02 | 2011-11-29 |  | 88d | 0d | Wallace [10%] | 16h | 1,200 |  |
| 371 | 1.4.4.5.4.8.2 | Reimaing Lens coating specificiation | 10d | 2011-11-30 | 2011-12-13 | 370 | 88d | 0d | Wallace [10%] | 8h | 600 |  |
| 372 | 1.4.4.5.4.8.3 | Mount detailed design | 5d | 2011-12-14 | 2011-12-20 | 371 | 88d | 0d | Bartos [40%] | 16h | 1,200 |  |
| 373 | 1.4.4.5.4.8.4 | Mount shop drawings | 2.5d | 2011-12-21 | 2011-12-23 | 372 | 88d |  | Bartos [40%] | 8h | 600 |  |
| 374 | 1.4.4.5.5 | **LOWFS DM & TTM** | 198.12d | 2010-10-01 | 2011-07-06 |  | 322.88d |  |  | 478h | 35,850 | 10.3 |
| 375 | 1.4.4.5.5.1 | **DM** | 121.25d | 2010-10-01 | 2011-03-21 |  | 322.88d | 0d |  | 412h | 30,900 | 10.3.1 |
| 376 | 1.4.4.5.5.1.1 | DM detailed specification | 60d | 2010-10-01 | 2010-12-23 |  | 384.12d |  | Dekany [5%] | 24h | 1,800 |  |

| ID | WBS | Task | Duration | Start | Finish | Predecessors | Total slack | Free slack | Resources | Work | Cost | Text1 |
| --- | --- | --- | --- | --- | --- | --- | --- | --- | --- | --- | --- | --- |
| 377 | 1.4.4.5.5.1.2 | **DM Mount** | 15d | 2010-10-01 | 2010-10-21 |  | 322.88d | 0d |  | 48h | 3,600 |  |
| 378 | 1.4.4.5.5.1.2.1 | DM Mount detailed design | 10d | 2010-10-01 | 2010-10-14 |  | 322.88d | 0d | Bartos [40%] | 32h | 2,400 |  |
| 379 | 1.4.4.5.5.1.2.2 | DM Mount shop drawings | 5d | 2010-10-15 | 2010-10-21 | 378 | 322.88d |  | Bartos [40%] | 16h | 1,200 |  |
| 380 | 1.4.4.5.5.1.3 | Electrical Interface definition | 6.25d | 2010-10-22 | 2010-11-01 | 377 | 322.88d | 0d | Croner [40%] | 20h | 1,500 | 10.2.3 |
| 381 | 1.4.4.5.5.1.4 | Cable detailed design | 37.5d | 2010-11-01 | 2010-12-22 | 380 | 322.88d | 0d | Croner [40%] | 120h | 9,000 |  |
| 382 | 1.4.4.5.5.1.5 | Analog drive electronics and A/D converter (high order) | 25d | 2010-12-22 | 2011-01-26 | 381 | 322.88d | 0d | Rahmer [40%] | 80h | 6,000 |  |
| 383 | 1.4.4.5.5.1.6 | Electrical Interface detailed design | 25d | 2011-01-26 | 2011-03-02 | 382 | 322.88d | 0d | Rahmer [40%] | 80h | 6,000 | 10.3.3 |
| 384 | 1.4.4.5.5.1.7 | Electrical Interface CAD drawings | 12.5d | 2011-03-02 | 2011-03-21 | 383 | 322.88d |  | Croner [40%] | 40h | 3,000 |  |
| 385 | 1.4.4.5.5.2 | **Tip-Tilt Mirror** | 76.88d | 2011-03-21 | 2011-07-06 | 375 | 322.88d |  |  | 66h | 4,950 |  |
| 386 | 1.4.4.5.5.2.1 | Tip-Tilt Mirror specification | 5d | 2011-03-21 | 2011-03-28 |  | 322.88d | 0d | Wallace [10%] | 4h | 300 |  |
| 387 | 1.4.4.5.5.2.2 | Tip-tilt Mirror Mount detailed design | 50d | 2011-03-28 | 2011-06-06 | 386 | 322.88d | 0d | Bartos [10%] | 40h | 3,000 | 10.3.2 |
| 388 | 1.4.4.5.5.2.3 | Tip-tilt Mirror Mount shop drawings | 20d | 2011-06-06 | 2011-07-04 | 387 | 322.88d | 0d | Bartos [10%] | 16h | 1,200 |  |
| 389 | 1.4.4.5.5.2.4 | Tip-tilt Mirror electrical interface detailed design | 0.62d | 2011-07-04 | 2011-07-04 | 388 | 322.88d | 0d | Croner [40%] | 2h | 150 |  |
| 390 | 1.4.4.5.5.2.5 | Tip-tilt Mirror cable routing design | 1.25d | 2011-07-04 | 2011-07-06 | 389 | 322.88d |  | Croner [40%] | 4h | 300 |  |
| 391 | 1.4.4.5.6 | **LOWFS DM Relay** | 112.5d | 2011-12-23 | 2012-05-29 | 336 | 88d |  |  | 304h | 22,800 |  |
| 392 | 1.4.4.5.6.1 | **LOWFS DM Relay Tube** | 17.5d | 2011-12-23 | 2012-01-17 |  | 88d | 0d |  | 56h | 4,200 |  |
| 393 | 1.4.4.5.6.1.1 | LOWFS DM Relay tube design | 12.5d | 2011-12-23 | 2012-01-10 |  | 88d | 0d | Bartos [40%] | 40h | 3,000 |  |
| 394 | 1.4.4.5.6.1.2 | LOWFS DM Relay tube shop drawings | 5d | 2012-01-11 | 2012-01-17 | 393 | 88d |  | Bartos [40%] | 16h | 1,200 |  |
| 395 | 1.4.4.5.6.2 | **LOWFS DM Relay Flexure Mount** | 27.5d | 2012-01-18 | 2012-02-24 | 392 | 88d | 0d |  | 88h | 6,600 |  |
| 396 | 1.4.4.5.6.2.1 | Flexure design | 15d | 2012-01-18 | 2012-02-07 |  | 88d | 0d | Bartos [40%] | 48h | 3,600 |  |
| 397 | 1.4.4.5.6.2.2 | Flexure shop drawings | 10d | 2012-02-08 | 2012-02-21 | 396 | 88d | 0d | Bartos [40%] | 32h | 2,400 |  |
| 398 | 1.4.4.5.6.2.3 | Preload design | 2.5d | 2012-02-22 | 2012-02-24 | 397 | 88d |  | Bartos [40%] | 8h | 600 |  |
| 399 | 1.4.4.5.6.3 | **LOWFS DM Relay fold mirror** | 7.5d | 2012-02-24 | 2012-03-06 | 395 | 88d | 0d |  | 24h | 1,800 |  |
| 400 | 1.4.4.5.6.3.1 | Fold mirror mount design | 5d | 2012-02-24 | 2012-03-02 |  | 88d | 0d | Bartos [40%] | 16h | 1,200 |  |
| 401 | 1.4.4.5.6.3.2 | Fold mirror mount shop drawings | 2.5d | 2012-03-02 | 2012-03-06 | 400 | 88d |  | Bartos [40%] | 8h | 600 |  |

| ID | WBS | Task | Duration | Start | Finish | Predecessors | Total slack | Free slack | Resources | Work | Cost |
| --- | --- | --- | --- | --- | --- | --- | --- | --- | --- | --- | --- |
| 402 | 1.4.4.5.6.4 | **Air-spaced Triplet** | 30d | 2012-03-07 | 2012-04-17 | 399 | 88d | 0d |  | 64h | 4,800 |
| 403 | 1.4.4.5.6.4.1 | Air-spaced Triplet specification | 30d | 2012-03-07 | 2012-04-17 |  | 88d |  | Wallace [10%] | 24h | 1,800 |
| 404 | 1.4.4.5.6.4.2 | Air-spaced Triplet coating specification | 10d | 2012-03-07 | 2012-03-20 |  | 108d |  | Wallace [10%] | 8h | 600 |
| 405 | 1.4.4.5.6.4.3 | Air-spaced Triplet mount design | 5d | 2012-03-07 | 2012-03-13 |  | 108d | 0d | Bartos [40%] | 16h | 1,200 |
| 406 | 1.4.4.5.6.4.4 | Air-spaced Triplet mount shop drawings | 5d | 2012-03-14 | 2012-03-20 | 405 | 108d |  | Bartos [40%] | 16h | 1,200 |
| 407 | 1.4.4.5.6.5 | **LOWFS DM Relay Alignment Fixturing** | 30d | 2012-04-18 | 2012-05-29 | 402 | 88d |  |  | 72h | 5,400 |
| 408 | 1.4.4.5.6.5.1 | LOWFS DM Relay Alignment Fixturing detailed design | 15d | 2012-04-18 | 2012-05-08 |  | 88d | 0d | Wallace [20%]; Bartos [20%] | 48h | 3,600 |
| 409 | 1.4.4.5.6.5.2 | LOWFS DM Relay Alignment Fixturing shop drawings | 15d | 2012-05-09 | 2012-05-29 | 408 | 88d |  | Bartos [20%] | 24h | 1,800 |
| 410 | 1.4.4.5.7 | **LOWFS Dewar Assemblies** | 336.5d | 2010-10-01 | 2012-01-16 |  | 49.75d | 0d |  | 784h | 58,800 |
| 411 | 1.4.4.5.7.1 | **Dewar Window** | 20d | 2010-10-01 | 2010-10-28 |  | 49.75d | 0d |  | 48h | 3,600 |
| 412 | 1.4.4.5.7.1.1 | Deward Window specification | 20d | 2010-10-01 | 2010-10-28 |  | 49.75d |  | Wallace [10%] | 16h | 1,200 |
| 413 | 1.4.4.5.7.1.2 | Dewar Window coating specification | 10d | 2010-10-01 | 2010-10-14 |  | 59.75d |  | Wallace [10%] | 8h | 600 |
| 414 | 1.4.4.5.7.1.3 | Dewar Window mount design | 10d | 2010-10-01 | 2010-10-14 |  | 54.75d | 0d | Bartos [20%] | 16h | 1,200 |
| 415 | 1.4.4.5.7.1.4 | Dewar Window shop drawings | 5d | 2010-10-15 | 2010-10-21 | 414 | 54.75d |  | Bartos [20%] | 8h | 600 |
| 416 | 1.4.4.5.7.2 | **K-blocking filter** | 20d | 2010-10-29 | 2010-11-25 | 411 | 49.75d | 0d |  | 48h | 3,600 |
| 417 | 1.4.4.5.7.2.1 | K-blocking filer specification | 10d | 2010-10-29 | 2010-11-11 |  | 52.25d | 0d | Wallace [10%] | 8h | 600 |
| 418 | 1.4.4.5.7.2.2 | K-blocking filter specification | 20d | 2010-10-29 | 2010-11-25 |  | 49.75d |  | Wallace [10%] | 16h | 1,200 |
| 419 | 1.4.4.5.7.2.3 | K-blocking filter mount design | 5d | 2010-11-12 | 2010-11-18 | 417 | 52.25d | 0d | Bartos [40%] | 16h | 1,200 |
| 420 | 1.4.4.5.7.2.4 | K-blocking filter mount shop drawings | 2.5d | 2010-11-19 | 2010-11-23 | 419 | 52.25d |  | Bartos [40%] | 8h | 600 |
| 421 | 1.4.4.5.7.3 | **Dewar walls and flanges** | 22.5d | 2010-11-26 | 2010-12-28 | 416 | 49.75d | 0d |  | 72h | 5,400 |
| 422 | 1.4.4.5.7.3.1 | Dewar walls detailed design | 15d | 2010-11-26 | 2010-12-16 |  | 49.75d | 0d | Bartos [40%] | 48h | 3,600 |
| 423 | 1.4.4.5.7.3.2 | Dewar wall shop drawings | 7.5d | 2010-12-17 | 2010-12-28 | 422 | 49.75d |  | Bartos [40%] | 24h | 1,800 |
| 424 | 1.4.4.5.7.4 | **Dewar shields, cold plates, and cold finger** | 65d | 2010-12-28 | 2011-03-29 | 421 | 49.75d | 0d |  | 208h | 15,600 |
| 425 | 1.4.4.5.7.4.1 | Dewar shields detailed design | 50d | 2010-12-28 | 2011-03-08 |  | 49.75d | 0d | Bartos [40%] | 160h | 12,000 |
| 426 | 1.4.4.5.7.4.2 | Dewar shields shop drawings | 15d | 2011-03-08 | 2011-03-29 | 425 | 49.75d |  | Bartos [40%] | 48h | 3,600 |

| ID | WBS | Task | Duration | Start | Finish | Predecessors | Total slack | Free slack | Resources | Work | Cost |
| --- | --- | --- | --- | --- | --- | --- | --- | --- | --- | --- | --- |
| 427 | 1.4.4.5.7.5 | **Detector** | 100d | 2011-03-29 | 2011-08-16 | 424 | 49.75d | 0d |  | 40h | 3,000 |
| 428 | 1.4.4.5.7.5.1 | Detector detailed specification | 100d | 2011-03-29 | 2011-08-16 |  | 49.75d |  | Wallace [5%] | 40h | 3,000 |
| 429 | 1.4.4.5.7.6 | **Detector mount** | 25d | 2011-08-16 | 2011-09-20 | 424, 427 | 49.75d | 0d |  | 80h | 6,000 |
| 430 | 1.4.4.5.7.6.1 | Detector mount detailed design | 17.5d | 2011-08-16 | 2011-09-08 |  | 49.75d | 0d | Bartos [40%] | 56h | 4,200 |
| 431 | 1.4.4.5.7.6.2 | Detector mount shop drawings | 7.5d | 2011-09-09 | 2011-09-20 | 430 | 49.75d |  | Bartos [40%] | 24h | 1,800 |
| 432 | 1.4.4.5.7.7 | **Internal wiring** | 20d | 2011-09-20 | 2011-10-18 | 429 | 49.75d | 0d |  | 80h | 6,000 |
| 433 | 1.4.4.5.7.7.1 | Flex cable specification | 8d | 2011-09-20 | 2011-09-30 |  | 61.75d |  | Croner [25%] | 16h | 1,200 |
| 434 | 1.4.4.5.7.7.2 | Internal wiring design | 20d | 2011-09-20 | 2011-10-18 |  | 49.75d |  | Croner [25%] | 40h | 3,000 |
| 435 | 1.4.4.5.7.7.3 | Internal wiring specification | 8d | 2011-09-20 | 2011-09-30 |  | 61.75d |  | Croner [25%] | 16h | 1,200 |
| 436 | 1.4.4.5.7.7.4 | Hermetic connector specification | 4d | 2011-09-20 | 2011-09-26 |  | 65.75d |  | Rahmer [25%] | 8h | 600 |
| 437 | 1.4.4.5.7.8 | **External wiring** | 12d | 2011-10-18 | 2011-11-03 | 432 | 49.75d | 0d |  | 40h | 3,000 |
| 438 | 1.4.4.5.7.8.1 | External wiring design | 12d | 2011-10-18 | 2011-11-03 |  | 49.75d |  | Rahmer [25%] | 24h | 1,800 |
| 439 | 1.4.4.5.7.8.2 | External wiring specification | 8d | 2011-10-18 | 2011-10-28 |  | 53.75d |  | Rahmer [25%] | 16h | 1,200 |
| 440 | 1.4.4.5.7.9 | **Ion pump manifold** | 20d | 2011-11-03 | 2011-12-01 | 429, 437 | 49.75d | 0d |  | 64h | 4,800 |
| 441 | 1.4.4.5.7.9.1 | Ion pump manifold design | 15d | 2011-11-03 | 2011-11-24 |  | 49.75d | 0d | Bartos [40%] | 48h | 3,600 |
| 442 | 1.4.4.5.7.9.2 | Ion pump manifold shop drawings | 5d | 2011-11-24 | 2011-12-01 | 441 | 49.75d |  | Bartos [40%] | 16h | 1,200 |
| 443 | 1.4.4.5.7.10 | **Temperature control** | 12d | 2011-12-01 | 2011-12-19 | 440 | 49.75d | 0d |  | 40h | 3,000 |
| 444 | 1.4.4.5.7.10.1 | Temperature sensor layout | 12d | 2011-12-01 | 2011-12-19 |  | 49.75d |  | Croner [25%] | 24h | 1,800 |
| 445 | 1.4.4.5.7.10.2 | Temperature sensor wiring design | 8d | 2011-12-01 | 2011-12-13 |  | 53.75d |  | Croner [25%] | 16h | 1,200 |
| 446 | 1.4.4.5.7.11 | **Detector Test Electronics** | 20d | 2011-12-19 | 2012-01-16 | 440, 443 | 49.75d |  |  | 64h | 4,800 |
| 447 | 1.4.4.5.7.11.1 | Detector Test Electronics box mechanical design | 5d | 2011-12-19 | 2011-12-26 |  | 49.75d | 0d | Bartos [40%] | 16h | 1,200 |
| 448 | 1.4.4.5.7.11.2 | Detector Test Electronics box shop drawings | 2.5d | 2011-12-26 | 2011-12-28 | 447 | 49.75d | 0d | Bartos [40%] | 8h | 600 |
| 449 | 1.4.4.5.7.11.3 | Detector Test Electronics electrical design | 10d | 2011-12-29 | 2012-01-11 | 448 | 49.75d | 0d | Rahmer [40%] | 32h | 2,400 |
| 450 | 1.4.4.5.7.11.4 | Detector Test Electronics wiring specification | 2.5d | 2012-01-12 | 2012-01-16 | 449 | 49.75d |  | Rahmer [40%] | 8h | 600 |

| ID | WBS | Task | Duration | Start | Finish | Predecessors | Total slack | Free slack | Resources | Work | Cost |
| --- | --- | --- | --- | --- | --- | --- | --- | --- | --- | --- | --- |
| 451 | 1.4.4.5.8 | **LOWFS TTFA Customizations** | 115d | 2012-01-16 | 2012-06-25 | 410 | 69.5d |  |  | 224h | 16,800 |
| 452 | 1.4.4.5.8.1 | **TTFA Collimating lens** | 22.5d | 2012-01-16 | 2012-02-15 |  | 69.5d | 0d |  | 36h | 2,700 |
| 453 | 1.4.4.5.8.1.1 | TTFA Collimating lens specification | 10d | 2012-01-16 | 2012-01-30 |  | 69.5d | 0d | Wallace [10%] | 8h | 600 |
| 454 | 1.4.4.5.8.1.2 | TTFA Collimating lens coating specification | 5d | 2012-01-30 | 2012-02-06 | 453 | 69.5d | 0d | Wallace [10%] | 4h | 300 |
| 455 | 1.4.4.5.8.1.3 | TTFA Collimating lens mount detailed design | 5d | 2012-02-06 | 2012-02-13 | 454 | 69.5d | 0d | Bartos [40%] | 16h | 1,200 |
| 456 | 1.4.4.5.8.1.4 | TTFA Collimating lens mount shop drawings | 2.5d | 2012-02-13 | 2012-02-15 | 455 | 69.5d |  | Bartos [40%] | 8h | 600 |
| 457 | 1.4.4.5.8.2 | **TTFA Lenslet** | 22.5d | 2012-02-16 | 2012-03-19 | 452 | 69.5d | 0d |  | 36h | 2,700 |
| 458 | 1.4.4.5.8.2.1 | TTFA Lenslet specification | 10d | 2012-02-16 | 2012-02-29 |  | 69.5d | 0d | Wallace [10%] | 8h | 600 |
| 459 | 1.4.4.5.8.2.2 | TTFA Lenslet coating specification | 5d | 2012-03-01 | 2012-03-07 | 458 | 69.5d | 0d | Wallace [10%] | 4h | 300 |
| 460 | 1.4.4.5.8.2.3 | TTFA Lenslet mount detailed design | 5d | 2012-03-08 | 2012-03-14 | 459 | 69.5d | 0d | Bartos [40%] | 16h | 1,200 |
| 461 | 1.4.4.5.8.2.4 | TTFA Lenslet mount shop drawings | 2.5d | 2012-03-15 | 2012-03-19 | 460 | 69.5d |  | Bartos [40%] | 8h | 600 |
| 462 | 1.4.4.5.8.3 | **TTFA Cold Stop** | 7.5d | 2012-03-19 | 2012-03-28 | 457 | 69.5d | 0d |  | 24h | 1,800 |
| 463 | 1.4.4.5.8.3.1 | TTFA Cold Stop detailed design | 5d | 2012-03-19 | 2012-03-26 |  | 69.5d | 0d | Bartos [40%] | 16h | 1,200 |
| 464 | 1.4.4.5.8.3.2 | TTFA Cold Stop shop drawings | 2.5d | 2012-03-26 | 2012-03-28 | 463 | 69.5d |  | Bartos [40%] | 8h | 600 |
| 465 | 1.4.4.5.8.4 | **TTFA Relay Lens 1** | 22.5d | 2012-03-29 | 2012-04-30 | 462 | 69.5d | 0d |  | 36h | 2,700 |
| 466 | 1.4.4.5.8.4.1 | TTFA Relay Lens 1 specification | 10d | 2012-03-29 | 2012-04-11 |  | 69.5d | 0d | Wallace [10%] | 8h | 600 |
| 467 | 1.4.4.5.8.4.2 | TTFA Relay Lens 1 coating specification | 5d | 2012-04-12 | 2012-04-18 | 466 | 69.5d | 0d | Wallace [10%] | 4h | 300 |
| 468 | 1.4.4.5.8.4.3 | TTFA Relay Lens 1 mount detailed design | 5d | 2012-04-19 | 2012-04-25 | 467 | 69.5d | 0d | Bartos [40%] | 16h | 1,200 |
| 469 | 1.4.4.5.8.4.4 | TTFA Relay Lens 1 mount shop drawings | 2.5d | 2012-04-26 | 2012-04-30 | 468 | 69.5d |  | Bartos [40%] | 8h | 600 |
| 470 | 1.4.4.5.8.5 | **TTFA Relay Lens 2** | 22.5d | 2012-04-30 | 2012-05-30 | 465 | 69.5d | 0d |  | 36h | 2,700 |
| 471 | 1.4.4.5.8.5.1 | TTFA Relay Lens 2 specification | 10d | 2012-04-30 | 2012-05-14 |  | 69.5d | 0d | Wallace [10%] | 8h | 600 |
| 472 | 1.4.4.5.8.5.2 | TTFA Relay Lens 2 coating specification | 5d | 2012-05-14 | 2012-05-21 | 471 | 69.5d | 0d | Wallace [10%] | 4h | 300 |
| 473 | 1.4.4.5.8.5.3 | TTFA Relay Lens 2 mount detailed design | 5d | 2012-05-21 | 2012-05-28 | 472 | 69.5d | 0d | Bartos [40%] | 16h | 1,200 |
| 474 | 1.4.4.5.8.5.4 | TTFA Relay Lens 2 mount shop drawings | 2.5d | 2012-05-28 | 2012-05-30 | 473 | 69.5d |  | Bartos [40%] | 8h | 600 |

| ID | WBS | Task | Duration | Start | Finish | Predecessors | Total slack | Free slack | Resources | Work | Cost |
| --- | --- | --- | --- | --- | --- | --- | --- | --- | --- | --- | --- |
| 475 | 1.4.4.5.8.6 | **TTFA Alignment Fixturing** | 17.5d | 2012-05-31 | 2012-06-25 | 470 | 69.5d |  |  | 56h | 4,200 |
| 476 | 1.4.4.5.8.6.1 | TTFA Alignment Fixturing detailed design | 10d | 2012-05-31 | 2012-06-13 |  | 69.5d | 0d | Bartos [40%] | 32h | 2,400 |
| 477 | 1.4.4.5.8.6.2 | TTFA Alignment Fixturing shop drawings | 7.5d | 2012-06-14 | 2012-06-25 | 476 | 69.5d |  | Bartos [40%] | 24h | 1,800 |
| 478 | 1.4.4.5.9 | **LOWFS Truth WFS** | 133.75d | 2012-01-16 | 2012-07-20 | 410 | 49.75d | 0d |  | 284h | 21,300 |
| 479 | 1.4.4.5.9.1 | **TWFS Enclosure** | 5d | 2012-01-16 | 2012-01-23 | 325 | 49.75d | 0d |  | 16h | 1,200 |
| 480 | 1.4.4.5.9.1.1 | TWFS Enclosure detailed design | 3.75d | 2012-01-16 | 2012-01-20 |  | 49.75d | 0d | Bartos [40%] | 12h | 900 |
| 481 | 1.4.4.5.9.1.2 | TWFS Enclosure shop drawings | 1.25d | 2012-01-20 | 2012-01-23 | 480 | 49.75d |  | Bartos [40%] | 4h | 300 |
| 482 | 1.4.4.5.9.2 | **TWFS Structure** | 13.75d | 2012-01-23 | 2012-02-10 | 479 | 49.75d | 0d |  | 44h | 3,300 |
| 483 | 1.4.4.5.9.2.1 | TWFS Structure detailed design | 7.5d | 2012-01-23 | 2012-02-01 |  | 49.75d | 0d | Bartos [40%] | 24h | 1,800 |
| 484 | 1.4.4.5.9.2.2 | TWFS Structure shop drawings | 2.5d | 2012-02-02 | 2012-02-06 | 483 | 49.75d | 0d | Bartos [40%] | 8h | 600 |
| 485 | 1.4.4.5.9.2.3 | TWFS cooling design | 2.5d | 2012-02-06 | 2012-02-08 | 484 | 49.75d | 0d | Bartos [40%] | 8h | 600 |
| 486 | 1.4.4.5.9.2.4 | TWFS cooling mechanical interface | 1.25d | 2012-02-09 | 2012-02-10 | 485 | 49.75d |  | Bartos [40%] | 4h | 300 |
| 487 | 1.4.4.5.9.3 | **TWFS Collimating lens** | 22.5d | 2012-02-10 | 2012-03-13 | 482 | 49.75d | 0d |  | 36h | 2,700 |
| 488 | 1.4.4.5.9.3.1 | TWFS Collimating Lens specification | 10d | 2012-02-10 | 2012-02-24 |  | 49.75d | 0d | Wallace [10%] | 8h | 600 |
| 489 | 1.4.4.5.9.3.2 | TWFS Collimating Lens coating specification | 5d | 2012-02-24 | 2012-03-02 | 488 | 49.75d | 0d | Wallace [10%] | 4h | 300 |
| 490 | 1.4.4.5.9.3.3 | TWFS Collimating lens mount detailed design | 5d | 2012-03-02 | 2012-03-09 | 489 | 49.75d | 0d | Bartos [40%] | 16h | 1,200 |
| 491 | 1.4.4.5.9.3.4 | TWFS Collimating lens mount shop drawings | 2.5d | 2012-03-09 | 2012-03-13 | 490 | 49.75d |  | Bartos [40%] | 8h | 600 |
| 492 | 1.4.4.5.9.4 | **TWFS Lenslet** | 22.5d | 2012-03-13 | 2012-04-13 | 487 | 49.75d | 0d |  | 36h | 2,700 |
| 493 | 1.4.4.5.9.4.1 | TWFS Lenslet specification | 10d | 2012-03-13 | 2012-03-27 |  | 49.75d | 0d | Wallace [10%] | 8h | 600 |
| 494 | 1.4.4.5.9.4.2 | TWFS Lenslet coating specification | 5d | 2012-03-27 | 2012-04-03 | 493 | 49.75d | 0d | Wallace [10%] | 4h | 300 |
| 495 | 1.4.4.5.9.4.3 | TWFS Lenslet mount detailed design | 5d | 2012-04-03 | 2012-04-10 | 494 | 49.75d | 0d | Bartos [40%] | 16h | 1,200 |
| 496 | 1.4.4.5.9.4.4 | TWFS Lenslet mount shop drawings | 2.5d | 2012-04-10 | 2012-04-13 | 495 | 49.75d |  | Bartos [40%] | 8h | 600 |
| 497 | 1.4.4.5.9.5 | **TWFS Cold Stop** | 7.5d | 2012-04-13 | 2012-04-24 | 492 | 49.75d | 0d |  | 24h | 1,800 |
| 498 | 1.4.4.5.9.5.1 | TWFS Cold Stop detailed design | 5d | 2012-04-13 | 2012-04-20 |  | 49.75d | 0d | Bartos [40%] | 16h | 1,200 |
| 499 | 1.4.4.5.9.5.2 | TWFS Cold Stop shop drawings | 2.5d | 2012-04-20 | 2012-04-24 | 498 | 49.75d |  | Bartos [40%] | 8h | 600 |

| ID | WBS | Task | Duration | Start | Finish | Predecessors | Total slack | Free slack | Constraint | Resources | Work | Cost |
| --- | --- | --- | --- | --- | --- | --- | --- | --- | --- | --- | --- | --- |
| 500 | 1.4.4.5.9.6 | **TWFS Relay Lens 1** | 22.5d | 2012-04-24 | 2012-05-25 | 497 | 49.75d | 0d |  |  | 36h | 2,700 |
| 501 | 1.4.4.5.9.6.1 | TWFS Relay Lens 1 specification | 10d | 2012-04-24 | 2012-05-08 |  | 49.75d | 0d |  | Wallace [10%] | 8h | 600 |
| 502 | 1.4.4.5.9.6.2 | TWFS Relay Lens 1 coating specification | 5d | 2012-05-08 | 2012-05-15 | 501 | 49.75d | 0d |  | Wallace [10%] | 4h | 300 |
| 503 | 1.4.4.5.9.6.3 | TWFS Relay Lens 1 mount detailed design | 5d | 2012-05-15 | 2012-05-22 | 502 | 49.75d | 0d |  | Bartos [40%] | 16h | 1,200 |
| 504 | 1.4.4.5.9.6.4 | TWFS Relay Lens 1 mount shop drawings | 2.5d | 2012-05-22 | 2012-05-25 | 503 | 49.75d |  |  | Bartos [40%] | 8h | 600 |
| 505 | 1.4.4.5.9.7 | **TWFS Relay Lens 2** | 22.5d | 2012-05-25 | 2012-06-26 | 500 | 49.75d | 0d |  |  | 36h | 2,700 |
| 506 | 1.4.4.5.9.7.1 | TWFS Relay Lens 2 specification | 10d | 2012-05-25 | 2012-06-08 |  | 49.75d | 0d |  | Wallace [10%] | 8h | 600 |
| 507 | 1.4.4.5.9.7.2 | TWFS Relay Lens 2 coating specification | 5d | 2012-06-08 | 2012-06-15 | 506 | 49.75d | 0d |  | Wallace [10%] | 4h | 300 |
| 508 | 1.4.4.5.9.7.3 | TWFS Relay Lens 2 mount detailed design | 5d | 2012-06-15 | 2012-06-22 | 507 | 49.75d | 0d |  | Bartos [40%] | 16h | 1,200 |
| 509 | 1.4.4.5.9.7.4 | TWFS Relay Lens 2 mount shop drawings | 2.5d | 2012-06-22 | 2012-06-26 | 508 | 49.75d |  |  | Bartos [40%] | 8h | 600 |
| 510 | 1.4.4.5.9.8 | **TWFS Alignment Fixturing** | 17.5d | 2012-06-26 | 2012-07-20 | 505 | 49.75d |  |  |  | 56h | 4,200 |
| 511 | 1.4.4.5.9.8.1 | TWFS Alignment Fixturing detailed design | 10d | 2012-06-26 | 2012-07-10 |  | 49.75d | 0d |  | Bartos [40%] | 32h | 2,400 |
| 512 | 1.4.4.5.9.8.2 | TWFS Alignment Fixturing shop drawings | 7.5d | 2012-07-10 | 2012-07-20 | 511 | 49.75d |  |  | Bartos [40%] | 24h | 1,800 |
| 513 | 1.4.4.5.10 | LOWFS Mini-Review | 1d? | 2012-07-20 | 2012-07-23 | 478 | 49.75d | 0d |  |  |  |  |
| 514 | 1.4.4.6 | **Acquisition Camera** | 123d? | 2010-12-01 | 2011-05-20 |  | 355d |  |  |  | 620h | 46,500 |
| 515 | 1.4.4.6.1 | Specification of Camera and Electronics | 20d? | 2011-01-03 | 2011-01-28 |  | 355d | 0d | start no earlier than 2011-01-03 | Cooper [25%] | 40h | 3,000 |
| 516 | 1.4.4.6.2 | Optical Design | 40d? | 2010-12-01 | 2011-01-25 |  | 358d | 3d | start no earlier than 2010-12-01 | Martin [50%] | 160h | 12,000 |
| 517 | 1.4.4.6.3 | Mechanical Design | 80d? | 2011-01-31 | 2011-05-20 | 515, 516 | 355d |  |  | Pollard [25%] | 160h | 12,000 |
| 518 | 1.4.4.6.4 | Electrical Design | 10d? | 2011-01-31 | 2011-02-11 | 515 | 392.5d | 0d |  | Cooper | 80h | 6,000 |
| 519 | 1.4.4.6.5 | Quote Acquisition | 4d? | 2011-02-14 | 2011-02-17 | 518 | 392.5d | 0d |  | Cooper [50%]; Martin [50%]; Pollard [37.5%] | 40h | 3,000 |
| 520 | 1.4.4.6.6 | Compliance Verification | 2.5d? | 2011-02-18 | 2011-02-22 | 519 | 392.5d | 0d |  | Martin [50%]; Cooper [50%] | 20h | 1,500 |
| 521 | 1.4.4.6.7 | Test Plan | 10d? | 2011-02-22 | 2011-03-08 | 520 | 392.5d | 0d |  | Cooper [25%]; Martin [25%] | 40h | 3,000 |
| 522 | 1.4.4.6.8 | Design Documention | 15d? | 2011-03-08 | 2011-03-29 | 521 | 392.5d | 0d |  | Cooper [25%]; Martin [25%]; Pollard [25%] | 80h | 6,000 |
| 523 | 1.4.4.6.9 | Acquistion Camera Mini-Review | 1d? | 2011-03-29 | 2011-03-30 | 522 | 392.5d | 0d |  |  |  |  |

| ID | WBS | Task | Duration | Start | Finish | Predecessors | Total slack | Free slack | Constraint | Resources | Work | Cost |
| --- | --- | --- | --- | --- | --- | --- | --- | --- | --- | --- | --- | --- |
| 524 | 1.4.4.7 | **Alignment, Calibration & Diagnostics** | 373.5d? | 2010-10-01 | 2012-03-07 |  | 147.5d |  |  |  | 1240h | 94,000 |
| 525 | 1.4.4.7.1 | **Alignment** | 157.5d? | 2011-08-01 | 2012-03-07 |  | 147.5d |  |  |  | 680h | 51,000 |
| 526 | 1.4.4.7.1.1 | Optical Design of Alignment Tools and Plans | 50d? | 2011-08-01 | 2011-10-07 |  | 147.5d | 0d | start no earlier than 2011-08-01 | Stalcup [50%] | 200h | 15,000 |
| 527 | 1.4.4.7.1.2 | Mechanical Design of Tools | 50d? | 2011-10-10 | 2011-12-16 | 526 | 147.5d | 0d |  | James [50%] | 200h | 15,000 |
| 528 | 1.4.4.7.1.3 | Assembly, Alignment and Test Plans | 20d? | 2011-12-19 | 2012-01-13 | 527 | 147.5d | 0d |  | Stalcup [50%] | 80h | 6,000 |
| 529 | 1.4.4.7.1.4 | Vendor Quote Acquisition | 10d? | 2012-01-16 | 2012-01-27 | 528 | 147.5d | 0d |  | Stalcup [50%] | 40h | 3,000 |
| 530 | 1.4.4.7.1.5 | Compliance Verification | 15d? | 2012-01-30 | 2012-02-17 | 529 | 147.5d | 0d |  | Stalcup [50%]; James [50%] | 80h | 6,000 |
| 531 | 1.4.4.7.1.6 | Documentation | 12.5d? | 2012-02-20 | 2012-03-07 | 530 | 147.5d |  |  | Stalcup [50%]; James [50%] | 80h | 6,000 |
| 532 | 1.4.4.7.2 | **Calibration Unit** | 195d? | 2010-10-01 | 2011-06-30 |  | 326d |  |  |  | 560h | 43,000 |
| 533 | 1.4.4.7.2.1 | Optical Design | 25d? | 2010-10-01 | 2010-11-04 |  | 326d | 0d |  | Stalcup [50%] | 100h | 7,500 |
| 534 | 1.4.4.7.2.2 | Flat Field Source Risk Reduction | 40d? | 2010-11-05 | 2010-12-30 | 533 | 326d | 0d |  | Stalcup [25%]; Flat Field Source | 80h | 7,000 |
| 535 | 1.4.4.7.2.3 | Components Selection and Compliance | 50d? | 2010-12-31 | 2011-03-10 | 534 | 326d | 0d |  | Stalcup [25%] | 100h | 7,500 |
| 536 | 1.4.4.7.2.4 | Opto-Mechanical Design | 60d? | 2011-03-11 | 2011-06-02 | 535 | 326d | 0d |  | James [25%]; Stalcup [25%]; Mogenson [25%] | 220h | 16,500 |
| 537 | 1.4.4.7.2.5 | Documentation | 20d? | 2011-06-03 | 2011-06-30 | 536 | 326d |  |  | Stalcup [25%]; James [25%] | 60h | 4,500 |
| 538 | 1.4.4.8 | **Real-Time Controller** | 514d? | 2010-09-01 | 2012-08-21 |  | 28d |  | start no earlier than 2010-09-01 |  | 7904h | 1,477,800 |
| 539 | 1.4.4.8.1 | **RTC Control processor** | 514d? | 2010-09-01 | 2012-08-21 |  | 28d |  |  |  | 7904h | 1,477,800 |
| 540 | 1.4.4.8.1.1 | **RTC Project Management** | 514d | 2010-09-01 | 2012-08-21 |  | 28d |  |  |  | 1040h | 78,000 |
| 541 | 1.4.4.8.1.1.1 | **Milestones and Reviews** | 514d | 2010-09-01 | 2012-08-21 |  | 28d |  |  |  |  |  |
| 542 | 1.4.4.8.1.1.1.1 | NGAO Detailed Design Phase | 24emo | 2010-09-01 | 2012-08-21 |  | 115.12d |  | start no earlier than 2010-09-01 |  |  |  |
| 543 | 1.4.4.8.1.1.2 | **Management Support** | 514d | 2010-09-01 | 2012-08-21 |  | 28d |  |  |  | 1040h | 78,000 |
| 544 | 1.4.4.8.1.1.2.1 | RTC subsystem project management oversight | 24emo | 2010-09-01 | 2012-08-21 |  | 115.12d |  | start no earlier than 2010-09-01 | Gavel [2.3%] | 400h | 30,000 |
| 545 | 1.4.4.8.1.1.2.2 | RTC code version control | 24emo | 2010-09-01 | 2012-08-21 |  | 115.12d |  | start no earlier than 2010-09-01 | Reinig [0.9%] | 160h | 12,000 |
| 546 | 1.4.4.8.1.1.2.3 | RTC documentation control | 24emo | 2010-09-01 | 2012-08-21 |  | 115.12d |  |  | Reinig [2.8%] | 480h | 36,000 |
| 547 | 1.4.4.8.1.2 | **Tomography Engine** | 487.5d | 2010-09-01 | 2012-07-13 |  | 53d |  |  |  | 720h | 414,000 |
| 548 | 1.4.4.8.1.2.1 | **TE Hardware custom boards** | 300d | 2010-09-01 | 2011-10-25 |  | 53d |  |  |  |  | 160,000 |
| 549 | 1.4.4.8.1.2.1.1 | Final design of custom TE boards | 15mo | 2010-09-01 | 2011-10-25 |  | 53d | 0d |  | TE Board Final Design Contract [256000%] |  | 160,000 |

Notes:
- 533: Product: Zemax
- 540: Manage all aspects of the RTC project, including generation and monitoring of outside contracts. This also includes some system-engineering tasks such as code version management and document management.
- 544: Includes project plan execution and reporting
- 546: Includes generating the final design, user, and maintenance documents
- 548: Design of custom digital logic boards for the tomography engine, based on the use of field-programmable gate array (FPGA) chips.
- 549: 2560 hours

| ID | WBS | Task | Duration | Start | Finish | Predecessors | Total slack | Free slack | Resources | Work | Cost |
| --- | --- | --- | --- | --- | --- | --- | --- | --- | --- | --- | --- |
| 550 | 1.4.4.8.1.2.2 | **TE hard-code** | 487.5d | 2010-09-01 | 2012-07-13 |  | 55.5d |  |  | 720h | 254,000 |
| 551 | 1.4.4.8.1.2.2.1 | Design and Simulate TE hard-code | 14.38mo | 2010-09-01 | 2011-10-07 |  | 55.5d | 0d | Reinig [20%]; RTC Programmer Contract [130000%] | 460h | 164,500 |
| 552 | 1.4.4.8.1.2.2.2 | Test TE hard-code on prototype unit | 10mo | 2011-10-07 | 2012-07-13 | 551 | 55.5d |  | Reinig [16.2%]; RTC Programmer Contract [70000%] | 260h | 89,500 |
| 553 | 1.4.4.8.1.3 | **Control Processor (CP)** | 120d | 2010-09-01 | 2011-02-15 |  | 423d |  |  | 360h | 91,000 |
| 554 | 1.4.4.8.1.3.1 | Final design specification of CP components | 0.25mo | 2010-09-01 | 2010-09-07 |  | 538d |  | Dillon | 40h | 3,000 |
| 555 | 1.4.4.8.1.3.2 | Design CP RTC-side hard-code | 3mo | 2010-09-01 | 2010-11-23 |  | 483d |  | RTC Programmer Contract [32000%]; Reinig [33.3%] | 160h | 44,000 |
| 556 | 1.4.4.8.1.3.3 | Design CP to supervisor interface software | 2mo | 2010-09-01 | 2011-02-15 |  | 423d |  | Reinig [50%]; RTC Programmer Contract [32000%] | 160h | 44,000 |
| 557 | 1.4.4.8.1.4 | **Tip/Tilt System** | 130d? | 2010-11-24 | 2011-05-24 | 571 | 53d | 0d |  | 1840h | 138,000 |
| 558 | 1.4.4.8.1.4.1 | **LOWFS processor** | 100d? | 2010-11-24 | 2011-04-12 |  | 83d |  |  | 960h | 72,000 |
| 559 | 1.4.4.8.1.4.1.1 | Final design and specification of LOWFS processor hardware | 2mo | 2010-11-24 | 2011-01-18 |  | 83d | 0d | Reinig [25%]; Dillon | 400h | 30,000 |
| 560 | 1.4.4.8.1.4.1.2 | Final design of LOWFS processor software | 60d? | 2011-01-19 | 2011-04-12 | 559 | 83d |  | Reinig [50%]; UCSC Programmer | 560h | 42,000 |
| 561 | 1.4.4.8.1.4.2 | **Tip/Tilt Controller** | 130d | 2010-11-24 | 2011-05-24 |  | 53d |  |  | 800h | 60,000 |
| 562 | 1.4.4.8.1.4.2.1 | Final Design of Tip/Tilt control software | 6mo | 2010-11-24 | 2011-05-10 |  | 53d | 0d | Reinig [25%]; UCSC Programmer [75%] | 720h | 54,000 |
| 563 | 1.4.4.8.1.4.2.2 | Final design and specification of TT controller hardware | 10d | 2011-05-11 | 2011-05-24 | 562 | 53d |  | Dillon | 80h | 6,000 |
| 564 | 1.4.4.8.1.4.3 | Stand-alone test of tip/tilt control system | 0.5mo | 2010-11-24 | 2010-12-07 |  | 173d |  | Reinig | 80h | 6,000 |
| 565 | 1.4.4.8.1.5 | **Point-And-Shoot AO Processor** | 120d | 2011-04-27 | 2011-10-11 | 557FS-1mo | 53d | 0d |  | 1440h | 108,000 |
| 566 | 1.4.4.8.1.5.1 | Final design and specification of Point-and-Shoot AO processor hardware | 4mo | 2011-04-27 | 2011-08-16 |  | 93d |  | Reinig [25%]; Dillon [50%] | 480h | 36,000 |
| 567 | 1.4.4.8.1.5.2 | Final design of Point and Shoot AO processor software | 120d | 2011-04-27 | 2011-10-11 |  | 53d |  | Reinig [50%]; UCSC Programmer | 960h | 72,000 |
| 568 | 1.4.4.8.1.6 | **DM Command Generator** | 178d | 2010-09-01 | 2011-05-06 |  | 365d |  |  | 24h | 145,800 |
| 569 | 1.4.4.8.1.6.1 | Final analysis and specification of DM Command Generator hardware | 12d | 2010-09-01 | 2010-09-16 |  | 531d |  | Dillon [25%] | 24h | 1,800 |
| 570 | 1.4.4.8.1.6.2 | Final design of software for DM command generator | 178d | 2010-09-01 | 2011-05-06 |  | 365d |  | RTC Programmer Contract [144000%] |  | 144,000 |
| 571 | 1.4.4.8.1.7 | **Clock and Synchronization System** | 60d | 2010-09-01 | 2010-11-23 |  | 53d | 0d |  |  | 48,000 |
| 572 | 1.4.4.8.1.7.1 | Final design of Clock and Synchronization hardware | 3mo | 2010-09-01 | 2010-11-23 |  | 53d | 0d | Timing board design-build contract [48000%] |  | 48,000 |
| 573 | 1.4.4.8.1.8 | **Telemetry Disk System** | 200d | 2011-10-12 | 2012-07-17 | 565 | 53d |  |  | 400h | 150,000 |
| 574 | 1.4.4.8.1.8.1 | Final design of Telemetry Disk System | 200d | 2011-10-12 | 2012-07-17 |  | 53d |  | RTC Programmer Contract [120000%]; Reinig [25%] | 400h | 150,000 |

Notes:
- 550: Design and test the hard-code defining the gate array logic in the TE
- 551: 1440 hours
- 553: The control processor is a dual-processor unit, consisting of a "soft" and a "hard" processor. The command-interpreter interface to the NGAO supervisory control system, a basic engineering interface, and related support tasks are taken care of on the "soft" real-time processor side, running a standard OS such as Linux. The interface to the Tomography engine and other hard real-time custom hardware is taken care of on the "hard" real-time processor running a real-time operating system with guaranteed interrupt latency such as RT-Linux. These interfaces require strict timing coordination in response to a clock.
- 554: Computer hardware, operating systems, memory, disks, and I/O cards.
- 555: Design the interrupt-driven code for TE parameter loading and setup control of other hardware units in the RTC system including Tip/Tilt controllers, Point-and-Shoot AO processors, and Camera drivers
- 556: Define the supervisory controller interface language. Program the interpreter and supporting command execution software. Program the state machine and supporting software.
- 557: The tip/tilt system takes input from 3 infrared camera controllers and produces the signals for 1) driving the tip/tilt mirrors in each LOWFS subsystem in a null-seeking control architecture and 2) driving the tip/tilt stage in the science beam.
- 568: The DM command generator is a commercial GPU card the implements the non-linear lookup tables for the open-loop controlled DMs

| ID | WBS | Task | Duration | Start | Finish | Predecessors | Total slack | Free slack | Constraint | Resources | Work | Cost | Text1 |
| --- | --- | --- | --- | --- | --- | --- | --- | --- | --- | --- | --- | --- | --- |
| 575 | 1.4.4.8.1.9 | **RTC Subsystem Hardware Support** | 20d? | 2011-10-26 | 2011-11-22 |  | 223d |  |  |  | 160h | 12,000 |  |
| 576 | 1.4.4.8.1.9.1 | Final design specification of cabinets, enclosures, cabling, cooling | 20d? | 2011-10-26 | 2011-11-22 | 549 | 223d |  |  | Lockwood | 160h | 12,000 |  |
| 577 | 1.4.4.8.1.10 | **Subsystem integration and testing** | 100d? | 2011-12-21 | 2012-05-08 |  | 103d |  |  |  | 1440h | 209,000 |  |
| 578 | 1.4.4.8.1.10.1 | Lab facilities preparation, general supplies and equipment | 100d? | 2011-12-21 | 2012-05-08 | 580 | 103d |  |  | Dillon; Reinig [33%]; UCSC Programmer; RTC Timing signal genrator; RTC Data capture unit; RTC Misc. test equipment; RTC Cable breakouts; RTC OS development license | 1440h | 209,000 |  |
| 579 | 1.4.4.8.1.11 | **Risk Mitigation Activities** | 430d | 2010-11-24 | 2012-07-17 |  | 53d |  |  |  | 480h | 84,000 |  |
| 580 | 1.4.4.8.1.11.1 | Fabricate one Engineering TE board | 2mo | 2011-10-26 | 2011-12-20 | 549 | 53d | 0d |  |  |  |  |  |
| 581 | 1.4.4.8.1.11.2 | Test and debug Engineering TE board | 3mo | 2011-12-21 | 2012-03-13 | 580 | 53d | 0d |  | Reinig [50%]; RTC Programmer Contract [24000%] | 240h | 42,000 |  |
| 582 | 1.4.4.8.1.11.3 | TE board rework (design) | 1mo | 2012-03-14 | 2012-04-10 | 581 | 53d | 0d |  |  |  |  |  |
| 583 | 1.4.4.8.1.11.4 | Fabricate Second Engineering TE board | 2mo | 2012-04-11 | 2012-06-05 | 582 | 53d | 0d |  |  |  |  |  |
| 584 | 1.4.4.8.1.11.5 | Test second engineering TE board | 1.5mo | 2012-06-06 | 2012-07-17 | 583 | 53d |  |  |  |  |  |  |
| 585 | 1.4.4.8.1.11.6 | Fabricate one clock and timing system | 2mo | 2010-11-24 | 2011-01-18 | 572 | 263d | 0d |  |  |  |  |  |
| 586 | 1.4.4.8.1.11.7 | Test and debug clock and timing system | 6mo | 2011-01-19 | 2011-07-05 | 585 | 263d | 0d |  | RTC Programmer Contract [24000%]; Reinig [25%] | 240h | 42,000 |  |
| 587 | 1.4.4.8.1.11.8 | Clock and timing system rework | 3mo | 2011-07-06 | 2011-09-27 | 586 | 263d |  |  |  |  |  |  |
| 588 | 1.4.4.8.2 | DM's and Tip/Tilt Stages | 1d? | 2010-09-01 | 2010-09-01 |  | 542d |  |  |  |  |  |  |
| 589 | 1.4.4.9 | **AO System Lab I&T** | 26d? | 2012-02-06 | 2012-03-12 |  | 144d |  |  |  | 100h | 7,500 |  |
| 590 | 1.4.4.9.1 | Detailed Plan for I&T | 25d? | 2012-02-06 | 2012-03-09 |  | 144d | 0d | finish no earlier than 2012-03-09 | Wizinowich [16%]; Stalcup [16%]; Tsubota [50%]; Gavel; Velur [62.5%] | 100h | 7,500 |  |
| 591 | 1.4.4.9.2 | AO System Lab I&T Mini-Review | 1d? | 2012-03-12 | 2012-03-12 | 590 | 144d |  |  |  |  |  |  |
| 592 | 1.4.5 | **Laser Guide Star Facility** | 391d? | 2010-09-01 | 2012-02-29 |  | 3.96d |  | start no earlier than 2010-09-01 |  | 5151.01h | 215,850 |  |
| 593 | 1.4.5.1 | **Laser Enclosure** | 100.5d? | 2011-06-10 | 2011-10-28 |  | 239.5d | 0d |  |  | 528h | 9,000 | DD |
| 594 | 1.4.5.1.1 | LE Management and Reporting | 90d | 2011-06-10 | 2011-10-13 | 972 | 250d |  | start no earlier than 2010-09-01 | MRI Chin [4.2%]; Chin [2.8%] | 50h | 1,500 | DD |
| 595 | 1.4.5.1.2 | **LE Engineering Tasks** | 85d? | 2011-06-10 | 2011-10-06 |  | 239.5d | 0d |  |  | 320h | 6,000 | DD |
| 596 | 1.4.5.1.2.1 | **LE Opto-Mechanical** | 63d? | 2011-06-10 | 2011-09-06 |  | 239.5d |  |  |  | 200h | 3,000 | DD |
| 597 | 1.4.5.1.2.1.1 | LE Mounting Frame | 20d | 2011-06-10 | 2011-07-07 | 972 | 239.5d | 0d |  | MRI Medeiros [25%]; MRI Mogenson [50%] | 80h |  | DD |
| 598 | 1.4.5.1.2.1.2 | LE Mods for Install and Servicing | 20d | 2011-07-08 | 2011-08-04 | 597 | 239.5d | 0d |  | MRI Medeiros [12.5%]; MRI Mogenson [12.5%] | 40h |  | DD |
| 599 | 1.4.5.1.2.1.3 | LE for BTO Interface | 19d | 2011-08-05 | 2011-08-31 | 598 | 239.5d | 0d |  | MRI Stalcup [15.8%]; MRI Mogenson | 40h |  | DD |
| 600 | 1.4.5.1.2.1.4 | LE for SYD Interface | 4d? | 2011-09-01 | 2011-09-06 | 599 | 239.5d | 0d |  | Stalcup; Mogenson [50%] | 40h | 3,000 | DD |

| ID | WBS | Task | Duration | Start | Finish | Predecessors | Total slack | Free slack | Constraint | Resources | Work | Cost | Text1 |
| --- | --- | --- | --- | --- | --- | --- | --- | --- | --- | --- | --- | --- | --- |
| 601 | 1.4.5.1.2.2 | **LE Infrastructure Support** | 22d | 2011-09-07 | 2011-10-06 |  | 239.5d |  |  |  | 40h |  | DD |
| 602 | 1.4.5.1.2.2.1 | LE Electrical Power | 10d | 2011-09-07 | 2011-09-20 | 600 | 239.5d | 0d |  | MRI Nance [20%] | 16h |  | DD |
| 603 | 1.4.5.1.2.2.2 | LE Glycol Cooling Manifold | 12d | 2011-09-21 | 2011-10-06 | 602 | 239.5d |  |  | MRI Nance [25%] | 24h |  | DD |
| 604 | 1.4.5.1.2.3 | **LE Electronics** | 25d | 2011-06-10 | 2011-07-14 |  | 299.5d |  |  |  | 80h | 3,000 | DD |
| 605 | 1.4.5.1.2.3.1 | LE Environmental Layout: Temperature, Humidity, HEPA | 5d | 2011-06-10 | 2011-06-16 | 972 | 299.5d | 0d |  | Nance | 40h | 3,000 | DD |
| 606 | 1.4.5.1.2.3.2 | LE Electronics Interface | 20d | 2011-06-17 | 2011-07-14 | 605 | 299.5d |  |  | MRI Wetherell [25%] | 40h |  | DD |
| 607 | 1.4.5.1.3 | **LE System Engineering Tasks** | 15.5d | 2011-10-06 | 2011-10-28 |  | 239.5d |  |  |  | 158h | 1,500 | DD |
| 608 | 1.4.5.1.3.1 | LE Integration and Test Plans | 7d | 2011-10-06 | 2011-10-17 | 595 | 239.5d | 0d |  | MRI Stalcup; MRI Medeiros [50%]; MRI Wetherell; MRI LaVen; MRI Nance [75%] | 70h |  | DD |
| 609 | 1.4.5.1.3.2 | LE Documentation Preparation | 8.5d | 2011-10-18 | 2011-10-28 | 608 | 239.5d |  |  | MRI Chin; Chin | 88h | 1,500 | DD |
| 610 | 1.4.5.2 | **Lasers** | 327.33d? | 2010-09-01 | 2011-12-02 |  | 21d |  |  |  | 1265.01h | 3,000 | DD |
| 611 | 1.4.5.2.1 | Laser Reporting and Planning | 326.65d | 2010-09-01 | 2011-12-01 |  | 21d | 0d |  | MRI Chin [6.1%] | 160h |  | DD |
| 612 | 1.4.5.2.2 | **Laser Procurement** | 327.33d? | 2010-09-01 | 2011-12-02 |  | 215.67d |  |  |  | 693h |  | DD |
| 613 | 1.4.5.2.2.1 | Laser Contracting | 13.33d | 2010-09-01 | 2010-09-20 | 611SS | 215.67d | 0d | finish no earlier than 2010-02-15 | MRI Chin [37.5%]; MRI Wizinowich [37.5%]; MRI Laser#1 Down Payment | 80h |  | DD |
| 614 | 1.4.5.2.2.2 | **Laser Phase 1 FDR** | 174.5d? | 2010-09-20 | 2011-05-20 |  | 215.67d |  |  |  | 392h |  | DD |
| 615 | 1.4.5.2.2.2.1 | Laser Detailed Design | 8emo | 2010-09-20 | 2011-05-18 | 613 | 903.79d | 0d | start no earlier than 2010-02-02 | MRI Adkins [0.7%]; MRI Chin [1.7%]; MRI Grace [0.7%]; MRI Wizinowich [0.7%] | 220h |  | DD |
| 616 | 1.4.5.2.2.2.2 | Laser Detailed Design Review | 7.5d? | 2011-05-11 | 2011-05-20 | 615FS-5d | 215.67d | 0d |  | MRI Adkins; MRI Chin; MRI LaVen; MRI Wizinowich; MRI Grace; MRI Laser Travel [200%] | 172h |  | DD |
| 617 | 1.4.5.2.2.3 | **Laser Phase 2 PPU** | 139.5d | 2011-05-20 | 2011-12-02 |  | 215.67d |  |  |  | 221h |  | DD |
| 618 | 1.4.5.2.2.3.1 | PPU Fabrication | 6.88mo | 2011-05-20 | 2011-11-30 | 616 | 215.67d | 0d |  | MRI Adkins [1%]; MRI Chin [2%]; MRI Wizinowich [2%]; MRI LaVen [4%]; MRI Grace [1%]; MRI Laser Travel [200%] | 77h |  | DD |
| 619 | 1.4.5.2.2.3.2 | PPU Review | 7d | 2011-11-23 | 2011-12-02 | 618FS-5d | 215.67d |  |  | MRI Adkins; MRI Chin; MRI LaVen; MRI Wizinowich; MRI Grace [35.3%]; MRI Laser Travel [200%] | 144h |  | DD |
| 620 | 1.4.5.2.3 | **Laser Engineering Tasks** | 75.83d? | 2011-03-03 | 2011-06-17 |  | 21d |  |  |  | 336h | 1,500 |  |
| 621 | 1.4.5.2.3.1 | **Laser Control Software Design** | 26d | 2011-03-04 | 2011-04-08 |  | 21d |  |  |  | 120h |  | DD |
| 622 | 1.4.5.2.3.1.1 | **Laser Interface Software** | 15d | 2011-03-04 | 2011-03-24 |  | 21d |  |  |  | 96h |  | DD |
| 623 | 1.4.5.2.3.1.1.1 | LICS Requirements and Interfaces (ICD) | 7d | 2011-03-04 | 2011-03-14 | 611SS+6.6mo | 21d | 0d |  | MRI Chin [33.3%]; MRI LaVen | 56h |  | DD |
| 624 | 1.4.5.2.3.1.1.2 | LICS Detailed Design, XML library, State Machines | 8d | 2011-03-14 | 2011-03-24 | 623 | 21d | 0d | finish no later than 2011-04-22 | MRI Chin [50%]; MRI LaVen; MRI Grace | 40h |  | DD |

| ID | WBS | Task | Type | Duration | Start | Finish | Predecessors | Total slack | Free slack | Constraint | Resources | Work | Cost | Text1 |
| --- | --- | --- | --- | --- | --- | --- | --- | --- | --- | --- | --- | --- | --- | --- |
| 625 | 1.4.5.2.3.1.2 | **Laser Operational Software** |  | 11d | 2011-03-24 | 2011-04-08 |  | 358.83d |  |  |  | 24h |  | DD |
| 626 | 1.4.5.2.3.1.2.1 | LOS Requirements and Interfaces (ICD) |  | 3d | 2011-03-24 | 2011-03-29 | 624 | 358.83d | 0d |  | MRI Chin [33.3%]; MRI LaVen | 8h |  | DD |
| 627 | 1.4.5.2.3.1.2.2 | LOS Detailed Design, GUI design |  | 8d | 2011-03-29 | 2011-04-08 | 626 | 358.83d |  |  | MRI Chin [25%]; MRI LaVen [25%] | 16h |  | DD |
| 628 | 1.4.5.2.3.2 | **Laser Controller H/W Design** |  | 19d | 2011-03-03 | 2011-03-30 |  | 365.83d | 36.83d |  |  | 76h |  | DD |
| 629 | 1.4.5.2.3.2.1 | **Laser Interface Controller** |  | 19d | 2011-03-03 | 2011-03-30 |  | 365.83d |  |  |  | 76h |  | DD |
| 630 | 1.4.5.2.3.2.1.1 | LIC Requirements and Interfaces Review (ICD) |  | 4d | 2011-03-03 | 2011-03-09 | 611SS+6.6mo | 365.83d | 0d | finish no earlier than 2010-10-01 | MRI Chin [25%]; MRI LaVen [50%]; MRI Wetherell [50%]; MRI ChockJ [50%]; MRI Grace [50%] | 28h |  | DD |
| 631 | 1.4.5.2.3.2.1.2 | LIC Design and Hardware Selection |  | 13d | 2011-03-10 | 2011-03-30 | 630 | 365.83d |  |  | MRI Chin [41.7%]; MRI LaVen [25%]; MRI Wetherell [25%]; MRI ChockJ [25%] | 48h |  | DD |
| 632 | 1.4.5.2.3.3 | Laser I&T Test Plans |  | 20d? | 2011-05-20 | 2011-06-17 | 616, 621, 628 | 329d | 0d |  | MRI Grace [25%]; MRI LaVen [45.9%]; MRI Chin [25%]; Chin | 140h | 1,500 | DD |
| 633 | 1.4.5.2.4 | Laser Design Documents |  | 6.17d | 2011-06-17 | 2011-06-27 | 632 | 329d |  |  | MRI Chin; MRI LaVen; Chin | 76h | 1,500 | DD |
| 634 | 1.4.5.3 | **Laser Launch Facility** |  | 335d? | 2010-09-01 | 2011-12-13 |  | 3.96d |  |  |  | 2268h | 125,100 |  |
| 635 | 1.4.5.3.1 | LLF Management and Reporting |  | 250d | 2010-09-01 | 2011-08-16 |  | 3.96d | 0d | start no earlier than 2010-09-01 | Chin [12%] | 240h | 18,000 | DD |
| 636 | 1.4.5.3.2 | **LLF Engineering Tasks** |  | 320d? | 2010-09-01 | 2011-11-22 |  | 3.96d |  |  |  | 1808h | 98,100 |  |
| 637 | 1.4.5.3.2.1 | **LLF Beam Transfer Optics** |  | 90d? | 2010-09-01 | 2011-01-04 |  | 3.96d |  |  |  | 420h |  |  |
| 638 | 1.4.5.3.2.1.1 | LLF BTO Optical Design |  | 10d? | 2010-09-01 | 2010-09-14 | 635SS | 3.96d | 0d |  | MRI Stalcup [50%] | 40h |  |  |
| 639 | 1.4.5.3.2.1.2 | LLF BTO Opto-Mechanical Design |  | 60d? | 2010-09-15 | 2010-12-07 | 638 | 3.96d | 0d |  | MRI Stalcup [50%]; MRI Medeiros [50%]; MRI Mogenson [25%] | 280h |  |  |
| 640 | 1.4.5.3.2.1.3 | LLF BTO Electronics Design |  | 10d? | 2010-12-08 | 2010-12-21 | 639 | 3.96d | 0d |  | MRI Wetherell [50%] | 40h |  |  |
| 641 | 1.4.5.3.2.1.4 | LLF BTO Test and Integration Plan |  | 10d? | 2010-12-22 | 2011-01-04 | 640 | 3.96d | 0d |  | MRI Stalcup [50%]; MRI Medeiros [50%] | 60h |  |  |
| 642 | 1.4.5.3.2.2 | **LLF Beam Generation System** |  | 160d? | 2011-01-05 | 2011-08-16 |  | 3.96d |  |  |  | 832h | 62,400 |  |
| 643 | 1.4.5.3.2.2.1 | LLF BGS Optical Design |  | 70d? | 2011-01-05 | 2011-04-12 | 641 | 3.96d | 0d |  | Stalcup [50%] | 280h | 21,000 |  |
| 644 | 1.4.5.3.2.2.2 | LLF BGS Opto-Mechanical Design |  | 80d? | 2011-04-13 | 2011-08-02 | 643 | 3.96d | 0d |  | Stalcup [50%]; Medeiros [50%]; Mogenson [25%] | 480h | 36,000 |  |
| 645 | 1.4.5.3.2.2.3 | LLF BGS Electronics Design | milestone | 0d? | 2011-08-02 | 2011-08-02 | 644 | 3.96d | 0d |  | Wetherell [50%] |  |  |  |
| 646 | 1.4.5.3.2.2.4 | LLF BGS Test and Integration Plan |  | 10d? | 2011-08-03 | 2011-08-16 | 645 | 3.96d | 0d |  | Stalcup [50%]; Medeiros [50%]; Chin | 72h | 5,400 |  |
| 647 | 1.4.5.3.2.3 | **LLF Switchyard** |  | 70d? | 2011-08-17 | 2011-11-22 |  | 3.96d |  |  |  | 396h | 29,700 |  |
| 648 | 1.4.5.3.2.3.1 | LLF SYD Optical Design |  | 20d? | 2011-08-17 | 2011-09-13 | 646 | 3.96d | 0d |  | Stalcup [50%] | 80h | 6,000 |  |
| 649 | 1.4.5.3.2.3.2 | LLF SYD Opto-Mechanical Design |  | 40d? | 2011-09-14 | 2011-11-08 | 648 | 3.96d | 0d |  | Stalcup [50%]; Medeiros [50%]; Mogenson [25%] | 240h | 18,000 |  |
| 650 | 1.4.5.3.2.3.3 | LLF SYD Electronics Design | milestone | 0d? | 2011-11-08 | 2011-11-08 | 649 | 3.96d | 0d |  | Wetherell [50%] |  |  |  |
| 651 | 1.4.5.3.2.3.4 | LLF SYD Test and Integration Plan |  | 10d? | 2011-11-09 | 2011-11-22 | 650 | 223d |  |  | Stalcup [50%]; Medeiros [50%]; Chin | 76h | 5,700 |  |
| 652 | 1.4.5.3.2.4 | LLF Safety Functionality |  | 10d? | 2011-11-09 | 2011-11-22 | 650 | 3.96d | 0d |  | MRI Wetherell [50%]; MRI Chin [50%]; Wetherell [50%]; Chin [50%]; MRI Stalcup [50%]; Stalcup [50%] | 160h | 6,000 |  |
| 653 | 1.4.5.3.3 | LLF Documentation |  | 15d? | 2011-11-23 | 2011-12-13 | 652 | 3.96d | 0d |  | Stalcup [50%]; Medeiros [50%]; Wetherell [50%]; MRI Medeiros [50%]; MRI Wetherell [50%]; MRI Stalcup [50%]; Chin [50%]; MRI Chin [50%] | 220h | 9,000 |  |

| ID | WBS | Task | Duration | Start | Finish | Predecessors | Total slack | Free slack | Constraint | Resources | Work | Cost | Text1 |
| --- | --- | --- | --- | --- | --- | --- | --- | --- | --- | --- | --- | --- | --- |
| 654 | 1.4.5.4 | **Laser Safety Systems** | 133d? | 2010-09-01 | 2011-03-04 |  | 410d |  |  |  | 574h | 43,050 |  |
| 655 | 1.4.5.4.1 | SS Planning and Reporting | 130d | 2010-09-01 | 2011-03-01 |  | 413d |  |  | Chin [6.2%] | 64h | 4,800 |  |
| 656 | 1.4.5.4.2 | **Safety System Controller** | 55d? | 2010-09-01 | 2010-11-16 |  | 410d |  |  |  | 384h | 28,800 |  |
| 657 | 1.4.5.4.2.1 | **SS Engineering Tasks** | 47.5d? | 2010-09-01 | 2010-11-05 |  | 410d | 0d |  |  | 320h | 24,000 |  |
| 658 | 1.4.5.4.2.1.1 | **SS PLC Assembly** | 42.5d? | 2010-09-01 | 2010-10-29 |  | 410d |  |  |  | 280h | 21,000 |  |
| 659 | 1.4.5.4.2.1.1.1 | SS Layout and Infrastructure | 10d | 2010-09-01 | 2010-09-14 |  | 410d | 0d |  | Cooper [50%]; Doyle | 80h | 6,000 |  |
| 660 | 1.4.5.4.2.1.1.2 | SS Electronics Drawings | 10d | 2010-09-15 | 2010-09-28 | 659 | 410d | 0d |  | Cooper [50%]; Doyle | 80h | 6,000 |  |
| 661 | 1.4.5.4.2.1.1.3 | SS Interface Design | 12.5d | 2010-09-29 | 2010-10-15 | 660 | 410d | 0d |  | Cooper [40%] | 40h | 3,000 |  |
| 662 | 1.4.5.4.2.1.1.4 | SS Interlocks | 5d? | 2010-10-15 | 2010-10-22 | 661 | 410d | 0d |  | Chin | 40h | 3,000 |  |
| 663 | 1.4.5.4.2.1.1.5 | SS Firmware | 5d? | 2010-10-22 | 2010-10-29 | 662 | 410d | 0d |  | Chin | 40h | 3,000 |  |
| 664 | 1.4.5.4.2.1.2 | SS Integration and Test Plans | 5d | 2010-10-29 | 2010-11-05 | 663 | 410d |  |  | Chin | 40h | 3,000 |  |
| 665 | 1.4.5.4.2.2 | **System Engineering Tasks** | 7.5d | 2010-11-05 | 2010-11-16 |  | 410d |  |  |  | 64h | 4,800 |  |
| 666 | 1.4.5.4.2.2.1 | SS Documentation | 7.5d | 2010-11-05 | 2010-11-16 | 657 | 410d | 0d |  | Chin; Shimko | 64h | 4,800 |  |
| 667 | 1.4.5.4.3 | **LTCS** | 3d | 2010-11-16 | 2010-11-19 |  | 410d |  |  |  | 24h | 1,800 |  |
| 668 | 1.4.5.4.3.1 | **LTCS System Engineering Tasks** | 3d | 2010-11-16 | 2010-11-19 |  | 410d |  |  |  | 24h | 1,800 |  |
| 669 | 1.4.5.4.3.1.1 | LTCS Integration and Test Plans | 2d | 2010-11-16 | 2010-11-18 | 666 | 410d | 0d |  | Chin; LaVen | 16h | 1,200 |  |
| 670 | 1.4.5.4.3.1.2 | LTCS Documentation Preparation | 1d | 2010-11-19 | 2010-11-19 | 669 | 410d | 0d |  | Chin | 8h | 600 |  |
| 671 | 1.4.5.4.4 | **Aircraft Detection and Safety** | 25d? | 2010-11-22 | 2010-12-24 |  | 410d |  |  |  | 62h | 4,650 | DD |
| 672 | 1.4.5.4.4.1 | **ACDS Electronics** | 17d? | 2010-11-22 | 2010-12-14 |  | 410d |  |  |  | 34h | 2,550 | DD |
| 673 | 1.4.5.4.4.1.1 | ACDS Support Plan for relocation of devices | 5d? | 2010-11-22 | 2010-11-26 | 670 | 410d | 0d |  | Chin [25%] | 10h | 750 | DD |
| 674 | 1.4.5.4.4.1.2 | ACDS Telescope Interface Unit | 12d? | 2010-11-29 | 2010-12-14 | 673 | 410d | 0d |  | Cooper [25%] | 24h | 1,800 | DD |
| 675 | 1.4.5.4.4.2 | ACDS Confirm Plans with FAA and update design document | 4d? | 2010-12-15 | 2010-12-20 | 674 | 410d | 0d | start no earlier than 2010-10-26 | Chin [25%]; Shimko [25%] | 12h | 900 | DD |
| 676 | 1.4.5.4.4.3 | ACDS Integration and Test Plans | 4d? | 2010-12-21 | 2010-12-24 | 675 | 410d | 0d |  | Chin [25%]; Cooper [25%] | 16h | 1,200 | DD |
| 677 | 1.4.5.4.5 | **Satellite Safety (LCH)** | 50d | 2010-12-27 | 2011-03-04 |  | 410d |  |  |  | 40h | 3,000 | DD |
| 678 | 1.4.5.4.5.1 | LCH Confirm Plans with LCH and update design document | 50d | 2010-12-27 | 2011-03-04 | 676 | 410d |  |  | Chin [10%] | 40h | 3,000 | DD |

| ID | WBS | Task | Type | Duration | Start | Finish | Predecessors | Total slack | Free slack | Constraint | Resources | Work | Cost | Text1 |
| --- | --- | --- | --- | --- | --- | --- | --- | --- | --- | --- | --- | --- | --- | --- |
| 679 | 1.4.5.5 | **HQ LGSF I&T** |  | 189d? | 2011-06-10 | 2012-02-29 |  | 3.96d | 0d |  |  | 516h | 35,700 | DD |
| 680 | 1.4.5.5.1 | HQ LGSF I&T Planning and Reporting |  | 68.57d | 2011-06-10 | 2011-09-14 | 972 | 124.39d |  | start no earlier than 2010-10-01 | Chin [7.3%] | 40h | 3,000 | DD |
| 681 | 1.4.5.5.2 | **HQ Lab Infrastructure Design** |  | 20d | 2011-06-10 | 2011-07-07 |  | 146.96d |  |  |  | 56h | 4,200 | DD |
| 682 | 1.4.5.5.2.1 | HQ Lab Infrastructure Design |  | 20d | 2011-06-10 | 2011-07-07 | 972 | 146.96d | 0d |  | Chin [25%]; Nance [25%] | 56h | 4,200 | DD |
| 683 | 1.4.5.5.3 | HQ Laser Installation Plan |  | 20d | 2011-07-08 | 2011-08-12 | 682 | 146.96d |  |  | MRI Medeiros [25%]; MRI Chin [25%]; Medeiros [30%]; Chin | 80h | 3,000 | DD |
| 684 | 1.4.5.5.4 | **LGSF Lab I&T Test Plans** |  | 45d? | 2011-12-14 | 2012-02-14 |  | 3.96d |  |  |  | 180h | 13,500 | DD |
| 685 | 1.4.5.5.4.1 | LGSF Optical Alignment Procedure and Planning |  | 8d? | 2011-12-14 | 2011-12-23 | 653 | 3.96d | 0d |  | Stalcup [50%] | 32h | 2,400 | DD |
| 686 | 1.4.5.5.4.2 | **Laser Steering Interface Test Plans** |  | 13d? | 2011-12-26 | 2012-01-11 |  | 3.96d |  |  |  | 52h | 3,900 | DD |
| 687 | 1.4.5.5.4.2.1 | Laser Interface to BTO Modifications |  | 5d | 2011-12-26 | 2011-12-30 | 685 | 3.96d | 0d |  | Stalcup [50%] | 20h | 1,500 | DD |
| 688 | 1.4.5.5.4.2.2 | Laser Interface with BGS |  | 4d | 2012-01-02 | 2012-01-05 | 687 | 3.96d | 0d |  | Stalcup [50%] | 16h | 1,200 | DD |
| 689 | 1.4.5.5.4.2.3 | Laser Interface with Switchyard |  | 4d? | 2012-01-06 | 2012-01-11 | 688 | 3.96d | 0d |  | Stalcup [50%] | 16h | 1,200 | DD |
| 690 | 1.4.5.5.4.3 | **Safety System interface** |  | 8d | 2012-01-12 | 2012-01-23 |  | 3.96d |  |  |  | 32h | 2,400 | DD |
| 691 | 1.4.5.5.4.3.1 | Laser Interface Testing to Safety System |  | 8d | 2012-01-12 | 2012-01-23 | 972, 689 | 3.96d | 0d |  | Cooper [50%] | 32h | 2,400 | DD |
| 692 | 1.4.5.5.4.4 | **Laser Controller Interface Test Plans** |  | 8d | 2012-01-24 | 2012-02-02 |  | 3.96d |  |  |  | 32h | 2,400 | DD |
| 693 | 1.4.5.5.4.4.1 | Laser Interface Testing to Laser Controller |  | 4d | 2012-01-24 | 2012-01-27 | 691 | 3.96d | 0d |  | Cooper [50%] | 16h | 1,200 | DD |
| 694 | 1.4.5.5.4.4.2 | Laser Operational Software Testing |  | 4d | 2012-01-30 | 2012-02-02 | 693 | 3.96d | 0d |  | Cooper [50%] | 16h | 1,200 | DD |
| 695 | 1.4.5.5.4.5 | **LGSF Lab I&T Multi-Command Sequencer Test Plans Support** |  | 8d? | 2012-02-03 | 2012-02-14 |  | 3.96d | 0d |  |  | 32h | 2,400 | DD |
| 696 | 1.4.5.5.4.5.1 | Safety System Interface Testing with MCS |  | 2d? | 2012-02-03 | 2012-02-06 | 694 | 3.96d | 0d |  | Cooper [50%] | 8h | 600 | DD |
| 697 | 1.4.5.5.4.5.2 | BGS Interface with MCS |  | 2d? | 2012-02-07 | 2012-02-08 | 696 | 3.96d | 0d |  | Stalcup [50%] | 8h | 600 | DD |
| 698 | 1.4.5.5.4.5.3 | Switchyard Interface with MCS |  | 2d? | 2012-02-09 | 2012-02-10 | 697 | 3.96d | 0d |  | Stalcup [50%] | 8h | 600 | DD |
| 699 | 1.4.5.5.4.5.4 | Laser Interface with MCS |  | 2d? | 2012-02-13 | 2012-02-14 | 698 | 3.96d |  |  | Chin [50%] | 8h | 600 | DD |
| 700 | 1.4.5.5.5 | LGSF E2E Testing |  | 6d | 2012-02-15 | 2012-02-22 | 695 | 3.96d | 0d |  | Stalcup [50%] | 24h | 1,800 | DD |
| 701 | 1.4.5.5.6 | LGSF Mini-Review (Place underLab I&T) |  | 5d? | 2012-02-23 | 2012-02-29 | 653, 700 | 3.96d | 0d |  | Chin; Cooper [50%]; Wetherell [50%]; Stalcup; Medeiros [50%]; Shimko [50%]; Nance [50%] | 136h | 10,200 |  |
| 702 | 1.4.6 | **Control System** |  | 517.25d? | 2010-10-01 | 2012-09-25 |  | 3.75d |  | start no earlier than 2010-10-01 |  | 12416h | 919,200 |  |
| 703 | 1.4.6.1 | **AO Control System** |  | 514d? | 2010-10-01 | 2012-09-20 |  | 3.75d | 0d |  |  | 5088h | 381,600 |  |
| 704 | 1.4.6.1.1 | AO External Subsystem Design Inputs (80% confidence) | milestone | 0d? | 2011-06-07 | 2011-06-07 |  | 92.5d | 0d | start no earlier than 2011-06-07 |  |  |  |  |
| 705 | 1.4.6.1.2 | AO Control System Management and Reporting |  | 24emo | 2010-10-01 | 2012-09-20 |  | 15.88d |  |  | Tsubota [1.1%] | 196h | 14,700 |  |

Notes:
- 704: To design our architecture we need inputs from the subsystems for things like number of devices, accuracy, range of motion, speeds, etc... to at least an 80% confidence level early on during the DD phase.

| ID | WBS | Task | Duration | Start | Finish | Predecessors | Total slack | Free slack | Constraint | Resources | Work | Cost | Text1 |
| --- | --- | --- | --- | --- | --- | --- | --- | --- | --- | --- | --- | --- | --- |
| 706 | 1.4.6.1.3 | **AO Calibration / Simulation** | 176d? | 2011-06-07 | 2012-02-07 |  | 92.5d |  |  |  | 600h | 45,000 | CALSIM |
| 707 | 1.4.6.1.3.1 | CALSIM Electronics Design | 6w | 2011-06-07 | 2011-07-18 | 704, 778 | 92.5d | 0d | start no earlier than 2010-12-26 | Wetherell | 240h | 18,000 |  |
| 708 | 1.4.6.1.3.2 | CALSIM Motion Control Software Design | 8w | 2011-11-09 | 2012-01-03 | 707, 791, 809 | 164.75d | 0d |  | LaVen [50%] | 160h | 12,000 |  |
| 709 | 1.4.6.1.3.3 | CALSIM Control Sequencer | 25d? | 2012-01-04 | 2012-02-07 | 708 | 164.75d |  |  | LaVen | 200h | 15,000 |  |
| 710 | 1.4.6.1.4 | **Wide Field Relay (Low Order)** | 91d? | 2011-07-19 | 2011-11-22 |  | 59.75d |  |  |  | 280h | 21,000 | WFR |
| 711 | 1.4.6.1.4.1 | WFR Electronics Design | 3w | 2011-07-19 | 2011-08-08 | 704, 707 | 92.5d | 0d |  | Wetherell | 120h | 9,000 |  |
| 712 | 1.4.6.1.4.2 | WFR Motion Control Software Design | 2w | 2011-11-09 | 2011-11-22 | 711, 791 | 59.75d | 0d |  | Tsubota [50%] | 40h | 3,000 |  |
| 713 | 1.4.6.1.4.3 | WFR Control Sequencer | 15d? | 2011-08-03 | 2011-08-23 | 749 | 114.75d | 0d |  | Morrison | 120h | 9,000 |  |
| 714 | 1.4.6.1.5 | **LGS Wavefront Sensors** | 116d? | 2011-08-09 | 2012-01-17 |  | 59.75d |  |  |  | 640h | 48,000 | LGSWFS |
| 715 | 1.4.6.1.5.1 | LGSWFS Electronics Design | 6w | 2011-08-09 | 2011-09-19 | 704, 711 | 92.5d | 0d |  | Wetherell | 240h | 18,000 |  |
| 716 | 1.4.6.1.5.2 | LGSWFS Motion Control Software Design | 8w | 2011-11-23 | 2012-01-17 | 712, 715 | 59.75d | 0d |  | Tsubota [50%] | 160h | 12,000 |  |
| 717 | 1.4.6.1.5.3 | LGSWFS Control Sequencer | 30d? | 2011-08-24 | 2011-10-04 | 713 | 114.75d | 0d |  | Morrison | 240h | 18,000 |  |
| 718 | 1.4.6.1.6 | **Acquisition Camera** | 106d? | 2011-09-20 | 2012-02-14 |  | 59.75d |  |  |  | 280h | 21,000 | ACQ |
| 719 | 1.4.6.1.6.1 | ACQ Electronics Design | 2w | 2011-09-20 | 2011-10-03 | 704, 715 | 92.5d | 0d |  | Wetherell | 80h | 6,000 |  |
| 720 | 1.4.6.1.6.2 | ACQ Motion Control Software Design | 4w | 2012-01-18 | 2012-02-14 | 716, 719 | 59.75d | 0d |  | Tsubota [50%] | 80h | 6,000 |  |
| 721 | 1.4.6.1.6.3 | ACQ Control Sequencer | 15d? | 2011-10-05 | 2011-10-25 | 717 | 114.75d | 0d |  | Morrison | 120h | 9,000 |  |
| 722 | 1.4.6.1.7 | **Low Order Wavefront Sensors** | 116d? | 2011-10-04 | 2012-03-13 |  | 59.75d |  |  |  | 360h | 27,000 | LOWFS |
| 723 | 1.4.6.1.7.1 | LOWFS Electronics Design | 3w | 2011-10-04 | 2011-10-24 | 704, 719 | 92.5d | 0d |  | Wetherell | 120h | 9,000 |  |
| 724 | 1.4.6.1.7.2 | LOWFS Motion Control Software Design | 4w | 2012-02-15 | 2012-03-13 | 720, 723 | 59.75d | 0d |  | Tsubota [50%] | 80h | 6,000 |  |
| 725 | 1.4.6.1.7.3 | LOWFS Control Sequencer | 20d? | 2011-10-26 | 2011-11-22 | 721 | 114.75d | 0d |  | Morrison | 160h | 12,000 |  |
| 726 | 1.4.6.1.8 | **Narrow Field Relay (High Order)** | 111d? | 2011-10-25 | 2012-03-27 |  | 59.75d |  |  |  | 200h | 15,000 | NFR |
| 727 | 1.4.6.1.8.1 | NFR Electronics Design | 2w | 2011-10-25 | 2011-11-07 | 704, 723 | 92.5d | 0d |  | Wetherell | 80h | 6,000 |  |
| 728 | 1.4.6.1.8.2 | NFR Motion Control Software Design | 2w | 2012-03-14 | 2012-03-27 | 724, 727 | 59.75d | 0d |  | Tsubota [50%] | 40h | 3,000 |  |
| 729 | 1.4.6.1.8.3 | NFR Control Sequencer | 10d? | 2011-11-23 | 2011-12-06 | 725 | 114.75d | 0d |  | Morrison | 80h | 6,000 |  |

Notes:
- 706: Hardware: / ·injection fold (linear) / ·field selector (linear) / ·source grid (4dof: 3xlinear,1xrotator) / ·source positioner (rotator) / ·laser source (linear) / ·turbulence generator (3dof: 2xrotator, 1xlinear) / Software: / ·single dof device controllers for: fold, selector, positioner, laser / ·special device controller for source grid / ·special device controller for turbulence generator / ·non-motion device controls for laser source and / ·non-motion device controls for turblence generator / ·supervisory control sequencer (~14 calibration sequences)
- 710: First optical relay of the NGAO AO system as the light leaves the telescope tertiary mirror. It contains the Low Order Deformable Mirror (LODM), various pickoff optics and optics for reimage the main telescope Nasmyth focus. This term is preferred to Low Order Relay or Woofer Relay. / PBS refers to this as: "Low Order DM & Tip-Tilt Platform" but we're going to use "Wide Field Relay" (per Chris' definition) even though we prefer "Low Order Relay". / Hardware: / ·image rotator* / ·lodm t/t (non-realtime) / ·lodm (non-realtime) / Software: / ·image rotator device control / ·lodm non-realtime controls: on/off / ·image rotator high level controller
- 714: Hardware: / ·3x object select (2dof) / ·7x tip/tilt (non-realtime) / ·3x patrolling beacon (2dof) / ·focus stage / ·details for handling pickoff arms / Software: / ·device controllers for 6x2dof devices / ·device controller for linear focus stage / ·non-realtime control for 7 t/t devices (on/off) / ·supervisory controller: moving more of the intelligence for the pickoffs to the NGAO Controls level to get the best control of positioning. also need some extra time to investigate and design spiral searches and the numerous control loops
- 718: Hardware: / ·filter wheel (rotary) / ·focus stage (linear) / Software: / ·device controller for filter wheel / ·device controller for focus stage / ·supervisory conrol sequencer
- 722: Detailed design and documentation for: / Hardware: / ·3x object select arm (2dof: rotatary) / ·3x tip/tilt non-realtime control / ·lowfs dm non-realtime control / ·3x focus stage (linear) / Software: / ·customized device controller for object select arms / ·non-motion device control (on/off) for 3x tip/tilt and 1x dm stages / ·3x device controller for linear focus stage / ·supervisory sequencer
- 726: Second optical relay of the NGAO AO system as the light leaves the telescope tertiary mirror. It follows directly after the Wide Field Relay. It contains the High Order Deformable Mirror (HODM) pickoff optics and optics for reimage the main telescope Nasmyth focus. This term is preferred to High Order Relay or Tweeter Relay. / PBS refers to this as: "High Order DM & Tip-Tilt Platform" but we're going to use "Narrow Field Relay" (per Chris' definition) even though we prefer "High Order Relay". / Hardware: / ·hodm slow tip/tilt (2dof) / ·hodm non-realtime control / Software: / ·hodm non-realtime control / ·device controller for tip/tilt / ·tip/tilt sequencer controller

| ID | WBS | Task | Type | Duration | Start | Finish | Predecessors | Total slack | Free slack | Constraint | Resources | Work | Cost | Text1 |
| --- | --- | --- | --- | --- | --- | --- | --- | --- | --- | --- | --- | --- | --- | --- |
| 730 | 1.4.6.1.9 | **Optical Switchyard** |  | 111d | 2011-11-08 | 2012-04-10 |  | 59.75d |  |  |  | 120h | 9,000 | AOSY |
| 731 | 1.4.6.1.9.1 | AOSY Electronics Design |  | 2w | 2011-11-08 | 2011-11-21 | 704, 727 | 92.5d | 0d |  | Wetherell | 80h | 6,000 |  |
| 732 | 1.4.6.1.9.2 | AOSY Motion Control Software Design |  | 2w | 2012-03-28 | 2012-04-10 | 728, 731 | 59.75d | 0d |  | Tsubota [50%] | 40h | 3,000 |  |
| 733 | 1.4.6.1.10 | **NGS Wavefront Sensor** |  | 141d? | 2011-11-22 | 2012-06-05 |  | 59.75d |  |  |  | 440h | 33,000 | NGSWFS |
| 734 | 1.4.6.1.10.1 | NGSWFS Electronics Design |  | 3w | 2011-11-22 | 2011-12-12 | 704, 731 | 92.5d | 0d |  | Wetherell | 120h | 9,000 |  |
| 735 | 1.4.6.1.10.2 | NGSWFS Moiton Control Software Design |  | 8w | 2012-04-11 | 2012-06-05 | 732, 734 | 59.75d | 0d |  | Tsubota [50%] | 160h | 12,000 |  |
| 736 | 1.4.6.1.10.3 | NGWFS Control Sequencer Desgin |  | 20d? | 2011-12-07 | 2012-01-03 | 729 | 114.75d | 0d |  | Morrison | 160h | 12,000 |  |
| 737 | 1.4.6.1.11 | **Atmospheric Dispersion Corrector** |  | 146d? | 2011-12-13 | 2012-07-03 |  | 59.75d |  |  |  | 280h | 21,000 | ADC |
| 738 | 1.4.6.1.11.1 | ADC Electronics Design |  | 2w | 2011-12-13 | 2011-12-26 | 704, 734 | 92.5d | 0d |  | Wetherell | 80h | 6,000 |  |
| 739 | 1.4.6.1.11.2 | ADC Motion Control Software Design |  | 4w | 2012-06-06 | 2012-07-03 | 735, 738 | 59.75d |  |  | Tsubota [50%] | 80h | 6,000 |  |
| 740 | 1.4.6.1.11.3 | ADC Control Sequencer Design |  | 15d? | 2012-01-04 | 2012-01-24 | 736 | 114.75d | 0d |  | Morrison | 120h | 9,000 |  |
| 741 | 1.4.6.1.12 | **AO Enclosures** |  | 100d | 2011-12-27 | 2012-05-14 |  | 92.5d |  |  |  | 1040h | 78,000 | ENC |
| 742 | 1.4.6.1.12.1 | **ENC Electronics Design** |  | 100d | 2011-12-27 | 2012-05-14 | 704, 738 | 92.5d |  |  |  | 800h | 60,000 |  |
| 743 | 1.4.6.1.12.1.1 | ENC AO Room (inc: input and output hatches) |  | 5w | 2011-12-27 | 2012-01-30 |  | 92.5d | 0d |  | Wetherell | 200h | 15,000 |  |
| 744 | 1.4.6.1.12.1.2 | ENC AO Electronics Vault |  | 8w | 2012-01-31 | 2012-03-26 | 743 | 92.5d | 0d |  | Wetherell | 320h | 24,000 |  |
| 745 | 1.4.6.1.12.1.3 | ENC AO Cold Enclosure (Bench) |  | 7w | 2012-03-27 | 2012-05-14 | 744 | 92.5d | 0d |  | Wetherell | 280h | 21,000 |  |
| 746 | 1.4.6.1.12.2 | ENC Control Software Design |  | 12w | 2012-01-25 | 2012-04-17 | 740 | 114.75d |  |  | Morrison [50%] | 240h | 18,000 |  |
| 747 | 1.4.6.1.13 | AO Control Sequencer |  | 12w | 2011-04-20 | 2011-07-12 | 808 | 114.75d | 0d |  | Morrison | 480h | 36,000 | AOSEQ |
| 748 | 1.4.6.1.14 | RTC Interface |  | 10d? | 2011-07-13 | 2011-07-26 | 747 | 114.75d | 0d |  | Morrison | 80h | 6,000 |  |
| 749 | 1.4.6.1.15 | Atmospheric Profiler Interface |  | 5d? | 2011-07-27 | 2011-08-02 | 748 | 114.75d | 0d |  | Morrison | 40h | 3,000 |  |
| 750 | 1.4.6.1.16 | AO Control System Mini-Review Support |  | 3.25d? | 2012-05-15 | 2012-05-18 | 745 | 92.5d |  |  | Tsubota [50%]; LaVen; Morrison; Wetherell | 52h | 3,900 |  |
| 751 | 1.4.6.2 | **LGSF Control System** |  | 514d? | 2010-10-01 | 2012-09-20 |  | 3.75d | 0d |  |  | 2488h | 174,600 |  |
| 752 | 1.4.6.2.1 | LGSF External Subsystem Design Inputs (80% confidence) | milestone | 0d? | 2011-06-07 | 2011-06-07 |  | 340.75d |  | start no earlier than 2011-06-07 |  |  |  |  |
| 753 | 1.4.6.2.2 | **LGSF Controls Subsystem Mini-Reviews** |  | 66d? | 2011-04-15 | 2011-07-15 |  | 311.75d |  |  |  |  |  |  |
| 754 | 1.4.6.2.2.1 | LIF | milestone | 1d? | 2011-04-15 | 2011-04-15 | 762 | 376.75d |  |  |  |  |  |  |
| 755 | 1.4.6.2.2.2 | LSY | milestone | 1d? | 2011-04-29 | 2011-04-29 | 765 | 366.75d |  |  |  |  |  |  |
| 756 | 1.4.6.2.2.3 | BGS | milestone | 1d? | 2011-05-27 | 2011-05-27 | 769 | 346.75d |  |  |  |  |  |  |
| 757 | 1.4.6.2.2.4 | LSS | milestone | 1d? | 2011-06-17 | 2011-06-17 | 774 | 331.75d |  |  |  |  |  |  |
| 758 | 1.4.6.2.2.5 | LSE | milestone | 1d? | 2011-07-15 | 2011-07-15 | 779 | 311.75d |  |  |  |  |  |  |
| 759 | 1.4.6.2.3 | Laser Control System Management and Reporting |  | 24emo | 2010-10-01 | 2012-09-20 |  | 15.88d |  |  | Tsubota [1.1%] | 196h | 14,700 |  |

Notes:
- 730: Detailed design and documentation: / Hardware: / ·interferometer dichroic (linear) / ·acquisition fold (linear) [part of ACQ] / ·ngs wfs dichroic (linear) [part of NGSWFS] / ·instrument select (rotary) / Software: / ·3x linear device controllers / ·1x rotary device controller
- 733: Hardware: / ·2x wfs fsm (2dof: tip/tilt) / ·wfs lenslet (2dof: linear) / ·focus stage (linear) / ·collision avoidance mechanism between lenslet and focus stage / Software: / ·2dof device controllers for fsms and lenslet / ·device controller for focus stage / ·supervisory controller: there will have to be some serious thought about how to coordinate offloading / tip-tilt correction between TTM2 and FSMs. Based on Eds comment about focus and lenslet stage collision it seems like the supervisory controller will have to be more intelligent than I originally assumed.
- 737: Detailed design and documenation base on assumptions of what it is / Hardware: / ·adc (2dof: either rotary or linear) / ·linear stage / Software: / ·2dof device controller (custom?) / ·linear stage device controller / ·high level controller (actively controlling positions)
- 743: Large room on the Keck Telescope Nasmyth platform containing the AO system, for NGAO it will be climate controlled. Temperature will be ~dome ambient, nominally 0 degrees Celsius +/- 10 degrees. / ·room temperature / ·humidity / ·dust / ·rack/equipment temperatures / ·camera / ·A/C controls / ·HEPA controls / ·lights controls / ·input hatch* / ·interferometer output hatch*
- 744: Large room containing electronics that support operation of the AO system. Room is keep at a warmer temperature than the AO Room, ~17 degrees Celsius (63 degrees Fahrenheit). Waste heat is removed by a cooling system. The Electronics Vault must be thermally isolated to some degree from adjoining AO Room. Frequently abbreviated e-vault. / ·glycol flow / ·temperature / ·ca/sim source output / ·cal/sim source power / ·cal/sim source intensity readback / ·motion control local/remote / ·motion control status / ·ac controls / ·racks / ·cabling
- 745: Smaller enclosure that surrounds the AO system bench and is cooled to approximately -15 degree Celsius to reduce emissivity (background) for infrared wavelength observations. (Note that the exact temperature of the AO Cold Enclosure is subject to change as design progresses). Previously referred to as the cold box. / ·temperature / ·humidity / ·dust / ·video camera / ·accels / ·IF IBM-T source / ·lights control / ·racks / ·cabling
- 746: Software: / ·readback for: / ·temperature/ ·humidity/ ·dust/ ·cal/sim source intensity / ·control and readback for: / ·accels/ ·AC/ ·HEPA/ ·lights/ ·motion control/ ·cal/sim source / ·surveillance camera controls
- 747: High level AO control sequencer. / Interfaces to higher level operations level controllers and coordinates and controls lower level AO device controllers accordingly. Lots of sequences need to be understood and developed.
- 752: To design our architecture we need inputs from the subsystems for things like number of devices, accuracy, range of motion, speeds, etc... to at least an 80% confidence level early on during the DD phase.

| ID | WBS | Task | Type | Duration | Start | Finish | Predecessors | Total slack | Free slack | Constraint | Resources | Work | Cost | Text1 |
| --- | --- | --- | --- | --- | --- | --- | --- | --- | --- | --- | --- | --- | --- | --- |
| 760 | 1.4.6.2.4 | **Laser Controller Interface** |  | 75d? | 2010-12-31 | 2011-04-14 |  | 134.5d |  |  |  | 200h | 3,000 | LIF |
| 761 | 1.4.6.2.4.1 | LIF Communication Cabling |  | 5d? | 2010-12-31 | 2011-01-06 | 787SS+65d | 134.5d | 0d | start no earlier than 2010-09-19 | MRI Wetherell | 40h |  |  |
| 762 | 1.4.6.2.4.2 | LIF Control / Status Interface |  | 15d? | 2011-03-25 | 2011-04-14 | 776 | 187.75d | 0d |  | MRI LaVen; LaVen | 160h | 3,000 |  |
| 763 | 1.4.6.2.5 | **Laser Switchyard** |  | 90d? | 2010-12-24 | 2011-04-28 |  | 144.5d |  |  |  | 360h | 27,000 | LSY |
| 764 | 1.4.6.2.5.1 | LSY Electronics Design |  | 20d? | 2011-01-07 | 2011-02-03 | 761 | 134.5d | 0d |  | Wetherell | 160h | 12,000 |  |
| 765 | 1.4.6.2.5.2 | LSY Motion Control Software Design |  | 10d? | 2011-04-15 | 2011-04-28 | 762, 764 | 187.75d | 0d |  | LaVen | 80h | 6,000 |  |
| 766 | 1.4.6.2.5.3 | LSY Control Sequencer Design |  | 15d? | 2010-12-24 | 2011-01-13 | 781 | 187.75d | 0d |  | LaVen | 120h | 9,000 |  |
| 767 | 1.4.6.2.6 | **Laser Beam Generation System** |  | 95d? | 2011-01-14 | 2011-05-26 |  | 149.5d |  |  |  | 680h | 51,000 | BGS |
| 768 | 1.4.6.2.6.1 | BGS Electronics Design |  | 30d? | 2011-02-04 | 2011-03-17 | 764 | 134.5d | 0d |  | Wetherell | 240h | 18,000 |  |
| 769 | 1.4.6.2.6.2 | BGS Software Design |  | 20d? | 2011-04-29 | 2011-05-26 | 765 | 187.75d | 0d |  | LaVen | 160h | 12,000 |  |
| 770 | 1.4.6.2.6.3 | BGS Control Sequencer Design |  | 35d? | 2011-01-14 | 2011-03-03 | 766 | 187.75d | 0d |  | LaVen | 280h | 21,000 |  |
| 771 | 1.4.6.2.7 | **Laser Safety System** |  | 185d? | 2010-10-01 | 2011-06-16 |  | 297.75d |  | start no earlier than 2010-10-01 |  | 240h | 18,000 | LSS |
| 772 | 1.4.6.2.7.1 | LSS Electronics Design |  | 1d? | 2010-10-01 | 2010-10-01 |  | 516.75d |  |  |  |  |  |  |
| 773 | 1.4.6.2.7.2 | **LSS Software Design** |  | 75d? | 2011-03-04 | 2011-06-16 |  | 187.75d |  |  |  | 240h | 18,000 |  |
| 774 | 1.4.6.2.7.2.1 | LSS Safety System Interface |  | 15d? | 2011-05-27 | 2011-06-16 | 769 | 187.75d | 0d |  | LaVen | 120h | 9,000 |  |
| 775 | 1.4.6.2.7.2.2 | LSS LTCS |  | 10d? | 2011-03-04 | 2011-03-17 | 770 | 187.75d | 0d |  | LaVen | 80h | 6,000 |  |
| 776 | 1.4.6.2.7.2.3 | LSS Laser Clearinghouse |  | 5d? | 2011-03-18 | 2011-03-24 | 775 | 187.75d | 0d |  | LaVen | 40h | 3,000 |  |
| 777 | 1.4.6.2.8 | **Laser Service Enclosure** |  | 85d? | 2011-03-18 | 2011-07-14 |  | 134.5d |  |  |  | 280h | 21,000 | LSE |
| 778 | 1.4.6.2.8.1 | LSE Electronics Design |  | 15d? | 2011-03-18 | 2011-04-07 | 768 | 134.5d | 42d |  | Wetherell | 120h | 9,000 |  |
| 779 | 1.4.6.2.8.2 | LSE Software Design |  | 20d? | 2011-06-17 | 2011-07-14 | 774 | 187.75d | 0d |  | LaVen | 160h | 12,000 |  |
| 780 | 1.4.6.2.9 | Laser Beam Transport Optics |  | 1d? | 2010-10-01 | 2010-10-01 |  | 516.75d |  |  |  |  |  |  |
| 781 | 1.4.6.2.10 | LGSF Sequencer |  | 60d? | 2010-10-01 | 2010-12-23 |  | 187.75d | 0d | start no earlier than 2010-10-01 | LaVen | 480h | 36,000 |  |
| 782 | 1.4.6.2.11 | LGSF Control System Mini-Review |  | 3.25d? | 2010-10-01 | 2010-10-06 |  | 514.5d |  |  | Tsubota [50%]; LaVen; Morrison; Wetherell | 52h | 3,900 |  |
| 783 | 1.4.6.3 | **Control System Infrastructure** |  | 517.25d? | 2010-10-01 | 2012-09-25 |  | 3.75d |  |  |  | 4840h | 363,000 |  |
| 784 | 1.4.6.3.1 | Motion and Device Subsystem Design Inputs (80% confidence) | milestone | 0d? | 2011-06-07 | 2011-06-07 |  | 344d |  | start no earlier than 2011-06-07 |  |  |  |  |
| 785 | 1.4.6.3.2 | Control System infrastructure Management and Reporting |  | 24emo | 2010-10-01 | 2012-09-20 |  | 25.12d |  |  | Tsubota [1.1%] | 196h | 14,700 |  |

Notes:
- 760: Detailed design and documentation for interfacing to the vendor supplied laser controller. / Will be reading statuses and sending commands to laser controller. No automated control loops are envisioned at this time.
- 763: Hardware: / ·3x polarizing 1/4 waveplate (1dof: rotary) / ·3x polarizing 1/2 waveplate (1dof: rotary) / ·3x pointing/steering mirrors (2dof: tip/tilt) / ·alignment beamsplitter (1dof: linear) / Software: / ·6x device controllers for rotary devices / ·3x 2dof device controllers for pointing/steering mirrors / ·linear device controller / ·supervisory sequencer
- 767: Hardware: / ·2x beam splitter (1dof: linear) / ·imager pickoff (1dof: linear) / ·3x patrolling lgs steering (2dof: linear) / ·asterism rotator (1dof: rotary) / ·asterism tip/tilt (2dof: tipt/tilt) / ·fast shutter / ·focus stage (1dof: linear) / ·lto polarization sensor (2dof: rotary) / ·lto cover (1dof: ?) / ·beam wfs / ·power / ·polarization sensor / ·beam position sensor / ·AC controls / ·temperature / ·humidity / Software: / ·5x 1dof linear device controllers / ·3x 2dof linear device controllers / ·1dof rotary device controller / ·2dof rotary device controller / ·2dof tip/tilt device controller / ·shutter type device control / ·non-motion device status and control / ·high level control sequencer (5wks)
- 772: Don't think there's anything here for Ed to do... I'm assuming Jason will be responsible for installing and making this work under his WBS.
- 774: Detailed design and documenation for interfacing to laser safety system.
- 775: per JC: Need to make existing code work with 7beams and transfer to new system, see: / http://www.oir.caltech.edu/twiki_oir/pub/Keck/NGAO/LaserPDRPhase/NGAO_LTCS_Modification_Preliiminary_Design_DS.doc / DSummers estimate: DD 32hrs, FSD 100hrs / reference documents: / http://keckshare.keck.hawaii.edu/dsweb/Get/Document-35985/KAON713.doc/ http://keckshare.keck.hawaii.edu/dsweb/Get/Document-7474/SDF_KECK_LTCS_URLs.doc/ http://keckshare.keck.hawaii.edu/dsweb/Get/Document-7472/SDF_revised_draft.doc
- 776: per JC: Transfer existing tool to new system, see: http://www.oir.caltech.edu/twiki_oir/pub/Keck/NGAO/LaserPDRPhase/NGAO_Laser_Clearing_House_Planning.doc
- 777: Hardware: / ·beam dump / ·temperature / ·humidity / ·dust / ·video camera / ·AC controls / Software: / ·non-motion device status and controls
- 780: This is being handled by the MRI proposal and JC has it covered.
- 781: Detailed design and documentation for high level laser control sequencer. / Interfaces to higher level operations level controllers and coordinates and controls lower level laser device controllers accordingly.
- 784: To design our architecture we need inputs from the subsystems for things like number of devices, accuracy, range of motion, speeds, etc... to at least an 80% confidence level early on during the DD phase.

| ID | WBS | Task | Type | Duration | Start | Finish | Predecessors | Total slack | Free slack | Resources | Work | Cost | Text1 |
| --- | --- | --- | --- | --- | --- | --- | --- | --- | --- | --- | --- | --- | --- |
| 786 | 1.4.6.3.3 | **Motion Control** |  | 435d? | 2010-10-01 | 2012-05-31 |  | 41d | 0d |  | 960h | 72,000 |  |
| 787 | 1.4.6.3.3.1 | MC Electronics |  | 120d? | 2010-10-01 | 2012-05-31 |  | 41d | 0d | Wetherell [50%] | 480h | 36,000 |  |
| 788 | 1.4.6.3.3.2 | MC Software |  | 120d? | 2010-12-08 | 2011-05-24 | 801 | 59.75d | 0d | Tsubota [50%] | 480h | 36,000 |  |
| 789 | 1.4.6.3.4 | **Device Control** |  | 435d? | 2010-10-01 | 2012-05-31 |  | 41d | 0d |  | 960h | 72,000 |  |
| 790 | 1.4.6.3.4.1 | DC Electronics |  | 120d? | 2010-10-01 | 2012-05-31 |  | 41d |  | Wetherell [50%] | 480h | 36,000 |  |
| 791 | 1.4.6.3.4.2 | DC Software |  | 120d? | 2011-05-25 | 2011-11-08 | 788 | 59.75d | 0d | Tsubota [50%] | 480h | 36,000 |  |
| 792 | 1.4.6.3.5 | **Electronics** |  | 45d? | 2012-06-01 | 2012-08-02 | 786, 789 | 41d |  |  | 360h | 27,000 |  |
| 793 | 1.4.6.3.5.1 | Instrument Interface |  | 5d? | 2012-06-01 | 2012-06-07 |  | 41d | 0d | Wetherell | 40h | 3,000 |  |
| 794 | 1.4.6.3.5.2 | Interferometer Interface |  | 5d? | 2012-06-08 | 2012-06-14 | 793 | 41d | 0d | Wetherell | 40h | 3,000 |  |
| 795 | 1.4.6.3.5.3 | Control Computers |  | 5d? | 2012-06-15 | 2012-06-21 | 794 | 41d | 0d | Wetherell | 40h | 3,000 |  |
| 796 | 1.4.6.3.5.4 | Realtime Control Computers |  | 10d? | 2012-06-22 | 2012-07-05 | 795 | 41d | 0d | Wetherell | 80h | 6,000 |  |
| 797 | 1.4.6.3.5.5 | Time Infrastructure (Sync) |  | 15d? | 2012-07-06 | 2012-07-26 | 796 | 41d | 0d | Wetherell | 120h | 9,000 |  |
| 798 | 1.4.6.3.5.6 | Communication Infrastructure |  | 5d? | 2012-07-27 | 2012-08-02 | 797 | 41d |  | Wetherell | 40h | 3,000 |  |
| 799 | 1.4.6.3.6 | **Software** |  | 265d? | 2010-10-01 | 2011-10-06 |  | 59.75d |  |  | 1752h | 131,400 | INFR |
| 800 | 1.4.6.3.6.1 | Common Services Mini-Review | milestone | 1d? | 2011-04-20 | 2011-04-20 | 808 | 377d |  |  |  |  |  |
| 801 | 1.4.6.3.6.2 | Revisit KCSF vs EPICS decision |  | 48d? | 2010-10-01 | 2010-12-07 |  | 59.75d | 0d | Morrison; Tsubota [50%] | 512h | 38,400 |  |
| 802 | 1.4.6.3.6.3 | Health Monitoring |  | 10d? | 2010-12-08 | 2010-12-21 | 801 | 114.75d | 0d | Morrison | 80h | 6,000 |  |
| 803 | 1.4.6.3.6.4 | Logging |  | 10d? | 2010-12-22 | 2011-01-04 | 802 | 114.75d | 0d | Morrison | 80h | 6,000 |  |
| 804 | 1.4.6.3.6.5 | Archiving |  | 10d? | 2011-01-05 | 2011-01-18 | 803 | 114.75d | 0d | Morrison | 80h | 6,000 |  |
| 805 | 1.4.6.3.6.6 | Alarming |  | 15d? | 2011-01-19 | 2011-02-08 | 804 | 114.75d | 0d | Morrison | 120h | 9,000 |  |
| 806 | 1.4.6.3.6.7 | Configuration |  | 30d? | 2011-02-09 | 2011-03-22 | 805 | 114.75d | 0d | Morrison | 240h | 18,000 |  |
| 807 | 1.4.6.3.6.8 | Keyword Interface |  | 10d? | 2011-03-23 | 2011-04-05 | 806 | 114.75d | 0d | Morrison | 80h | 6,000 |  |
| 808 | 1.4.6.3.6.9 | EPICS Channel Access Interface |  | 10d? | 2011-04-06 | 2011-04-19 | 807 | 114.75d | 0d | Morrison | 80h | 6,000 |  |
| 809 | 1.4.6.3.6.10 | Utility Scripts |  | 60d? | 2011-07-15 | 2011-10-06 | 747, 779, 781 | 187.75d | 23d | LaVen | 480h | 36,000 |  |

Notes:
- 786: Motion device control. / Hardware: / ·platform selection / ·motion controller selection / ·motion controller locations / ·amplifiers / ·wiring / ·etc... / Software: / ·software interface / · low level device controller / ·device control state machine / · low level engineering gui interface
- 789: Non-motion device control. / Hardware: / ·controller selection / ·temperature / ·humidity / ·dust/ ·wiring / ·video camera / ·power / ·etc... / Software: / ·device drivers for each type / ·interface definition / ·attribute definitions / ·method definition / ·etc...
- 806: ·config Server / ·database design / ·config snapshot / ·gui
- 809: Library of common functions / tasks for observers, SA, developers, etc... / Still needs to be defined but I stuck a number in for now.

| ID | WBS | Task | Duration | Start | Finish | Predecessors | Total slack | Free slack | Constraint | Resources | Work | Cost | Text1 |
| --- | --- | --- | --- | --- | --- | --- | --- | --- | --- | --- | --- | --- | --- |
| 810 | 1.4.6.3.7 | **Data Server** | 350d? | 2010-10-01 | 2012-02-02 |  | 171d |  |  |  | 560h | 42,000 | DS |
| 811 | 1.4.6.3.7.1 | DS Software Design | 300d? | 2010-10-01 | 2012-02-02 |  | 171d | 0d |  | Johnson [20%] | 480h | 36,000 |  |
| 812 | 1.4.6.3.7.2 | DS Hardware Selection | 50d? | 2011-02-25 | 2011-05-05 | 811SS+105d | 366d |  | start no earlier than 2010-11-14 | Johnson [20%] | 80h | 6,000 |  |
| 813 | 1.4.6.3.8 | Control System Infrastructure Mini-Review Support | 3.25d? | 2012-09-20 | 2012-09-25 | 703, 751 | 3.75d | 0d |  | Tsubota [50%]; LaVen; Morrison; Wetherell | 52h | 3,900 |  |
| 814 | 1.4.7 | **Science Operations Tools** | 487d? | 2010-10-01 | 2012-08-13 |  | 34d |  |  |  | 2180h | 163,500 |  |
| 815 | 1.4.7.1 | **Multi-System Command Sequencer** | 191d? | 2010-10-01 | 2011-06-24 |  | 34d |  |  |  | 720h | 54,000 |  |
| 816 | 1.4.7.1.1 | Multi-Systems Command Sequencer Infrastructure | 60d? | 2010-10-01 | 2010-12-23 |  | 34d | 0d |  | Lyke [25%]; Morrison [75%] | 240h | 18,000 |  |
| 817 | 1.4.7.1.2 | Setup Sequences: configuration and calibrations | 47d? | 2010-12-24 | 2011-02-28 | 816 | 34d | 0d |  | Lyke [21.3%]; Morrison [75%] | 160h | 12,000 |  |
| 818 | 1.4.7.1.3 | Observing Sequences | 84d? | 2011-03-01 | 2011-06-24 | 817 | 34d | 0d |  | Lyke [11.9%]; Morrison [75%]; PostD-OpsTools | 320h | 24,000 |  |
| 819 | 1.4.7.2 | **User Interfaces** | 111d? | 2011-06-27 | 2011-11-28 |  | 34d |  |  |  | 660h | 49,500 |  |
| 820 | 1.4.7.2.1 | User interfaces Infrastructure | 31d? | 2011-06-27 | 2011-08-08 | 818 | 34d | 0d | finish no earlier than 2011-05-27 | Lyke [28.2%]; Morrison [75%] | 140h | 10,500 |  |
| 821 | 1.4.7.2.2 | Setup Operations: configuration and calibrations | 30d? | 2011-08-09 | 2011-09-19 | 820 | 34d | 0d |  | Lyke [25%]; Morrison [75%] | 120h | 9,000 |  |
| 822 | 1.4.7.2.3 | Observations User Interfaces for Operator, Observers, Specialists | 50d? | 2011-09-20 | 2011-11-28 | 821 | 34d | 0d | finish no earlier than 2011-11-18 | Lyke [50%]; Morrison [75%] | 400h | 30,000 |  |
| 823 | 1.4.7.3 | **Pre- & Post-Observing Science Support Tools** | 184d? | 2011-11-29 | 2012-08-10 |  | 34d | 0d |  |  | 800h | 60,000 |  |
| 824 | 1.4.7.3.1 | Users' Documentation | 144d? | 2011-11-29 | 2012-06-15 | 822 | 34d | 0d |  | Lyke [20.8%]; Morrison [75%] | 480h | 36,000 |  |
| 825 | 1.4.7.3.2 | Planning Tools | 40d? | 2012-06-18 | 2012-08-10 | 824 | 34d |  | finish no earlier than 2012-07-29 | Lyke [50%]; Morrison | 320h | 24,000 |  |
| 826 | 1.4.7.4 | Science Operations Tools Mini-Review | 1d? | 2012-08-13 | 2012-08-13 | 815, 819, 823 | 34d | 0d |  |  |  |  |  |
| 827 | 1.4.8 | **Telescope & Summit Engineering** | 498.5d? | 2010-10-01 | 2012-08-29 |  | 22.5d |  |  |  | 3844h | 227,175 |  |
| 828 | 1.4.8.1 | **Infrastructure Modifications for AO - part I** | 367.5d? | 2011-04-01 | 2012-08-28 |  | 22.5d | 0d | start no earlier than 2010-10-01 |  | 1550h | 116,250 |  |
| 829 | 1.4.8.1.1 | **Engineering Tasks** | 240d? | 2011-04-01 | 2012-03-01 |  | 22.5d | 0d |  |  | 1020h | 76,500 |  |
| 830 | 1.4.8.1.1.1 | **Mechanical Tasks** | 240d? | 2011-04-01 | 2012-03-01 |  | 22.5d |  |  |  | 560h | 42,000 |  |
| 831 | 1.4.8.1.1.1.1 | Mechanical modifications to Nasmyth deck and support structure | 100d? | 2011-04-01 | 2011-08-18 |  | 22.5d | 0d | start no earlier than 2011-04-01 | James [25%]; Mogenson [10%]; Hyatt [25%] | 180h | 13,500 |  |
| 832 | 1.4.8.1.1.1.2 | Final design for mount for AO Cold Enclosure heat exchanger (likely mounted below Nasymth platform). | 100d? | 2011-08-19 | 2012-01-05 | 831 | 22.5d | 0d |  | James [25%]; Mogenson [10%]; Hyatt [25%] | 180h | 13,500 |  |
| 833 | 1.4.8.1.1.1.3 | Final design for cables, trays, conduits, etc. run from AO to other areas of observatory | 40d? | 2012-01-06 | 2012-03-01 | 832 | 22.5d |  |  | James [25%]; Mogenson [50%]; Hyatt [25%] | 200h | 15,000 |  |

Notes:
- 810: Detailed design and documentation including recommended computer/disk hardware selection. / Computers: 1wk / Software: 12wks / ·database definition and design / ·log files definition and design / ·interface tool specs and design / ·inter-process comm spec and design

| ID | WBS | Task | Duration | Start | Finish | Predecessors | Total slack | Free slack | Constraint | Resources | Work | Cost | Text1 |
| --- | --- | --- | --- | --- | --- | --- | --- | --- | --- | --- | --- | --- | --- |
| 834 | 1.4.8.1.1.2 | **Electrical and Cooling** | 200d? | 2011-04-01 | 2012-01-05 |  | 62.5d | 40d |  |  | 460h | 34,500 |  |
| 835 | 1.4.8.1.1.2.1 | Final design for electrical power modifications for AO Room, AO Cold Enclosure and AO Electronics Vault. (WBS 8.5 ) | 80d? | 2011-04-01 | 2011-07-21 |  | 62.5d | 0d | start no earlier than 2011-04-01 | Nance [25%]; Reed [25%] | 180h | 13,500 |  |
| 836 | 1.4.8.1.1.2.2 | Final design for AO Room glycol system (most covered already under common infrastructure WBS 8.5) | 80d? | 2011-07-22 | 2011-11-10 | 835 | 62.5d | 0d |  | Nance [25%]; Agliam [25%] | 180h | 13,500 |  |
| 837 | 1.4.8.1.1.2.3 | Final design of modification to system for cooling LOWFS IR detectors may have special needs (Cryo Tiger or other CCR) and mount LOWFS CryoTiger CCR head (below nasymth or in mech room, TBD). | 40d? | 2011-11-11 | 2012-01-05 | 836 | 62.5d |  |  | Nance [25%]; Agliam [25%] | 100h | 7,500 |  |
| 838 | 1.4.8.1.2 | **System Engineering** | 127.5d? | 2012-03-02 | 2012-08-28 | 829, 834 | 22.5d |  |  |  | 530h | 39,750 |  |
| 839 | 1.4.8.1.2.1 | Plan relocation of NIRC2 to Keck I | 20d? | 2012-03-02 | 2012-03-29 |  | 22.5d | 0d |  | Pollard [25%]; Mogenson [25%] | 80h | 6,000 |  |
| 840 | 1.4.8.1.2.2 | Vendor quotes | 12.5d? | 2012-03-30 | 2012-04-17 | 839 | 22.5d | 0d |  | Pollard [25%]; Nance [25%] | 50h | 3,750 |  |
| 841 | 1.4.8.1.2.3 | Engineering change requests (ECR) approved | 15d? | 2012-04-17 | 2012-05-08 | 840 | 22.5d | 0d |  | Pollard [25%]; Nance [25%]; Mogenson | 80h | 6,000 |  |
| 842 | 1.4.8.1.2.4 | Installation/work plan and test plan | 20d? | 2012-05-08 | 2012-06-05 | 841 | 22.5d | 0d |  | Pollard [25%]; Nance [25%] | 80h | 6,000 |  |
| 843 | 1.4.8.1.2.5 | Verify compliance, compliance matrices and final specifications (requirements) | 20d? | 2012-06-05 | 2012-07-03 | 842 | 22.5d | 0d |  | Pollard [25%]; Nance [25%] | 80h | 6,000 |  |
| 844 | 1.4.8.1.2.6 | Document design | 40d? | 2012-07-03 | 2012-08-28 | 843 | 22.5d |  |  | Pollard [25%]; Nance [25%]; Mogenson | 160h | 12,000 |  |
| 845 | 1.4.8.2 | **Infastructure Modifications for LGSF - part I** | 106d? | 2011-06-10 | 2011-11-04 |  | 234d | 211.5d |  |  | 764h | 15,075 | DD |
| 846 | 1.4.8.2.1 | LGSF IM Planning and Reporting | 106d | 2011-06-10 | 2011-11-04 | 972 | 234d |  | start no earlier than 2010-09-01 | Chin [5.8%]; MRI Chin [5.8%] | 98h | 3,675 | DD |
| 847 | 1.4.8.2.2 | **LGSF IM Engineering Tasks** | 102d? | 2011-06-10 | 2011-10-31 |  | 234d |  |  |  | 570h | 7,800 | DD |
| 848 | 1.4.8.2.2.1 | **LGSF IM Electrical** | 20d | 2011-06-10 | 2011-07-07 | 972 | 316d | 82d |  |  | 56h |  | DD |
| 849 | 1.4.8.2.2.1.1 | **LGSF IM Adaptive Optics Area** | 20d | 2011-06-10 | 2011-07-07 |  | 316d |  |  |  | 56h |  | DD |
| 850 | 1.4.8.2.2.1.1.1 | LGSF IM Feeds to Electronics Room for Laser | 8d | 2011-06-10 | 2011-06-21 |  | 316d | 0d |  | MRI Nance [25%]; MRI Reed [50%] | 24h |  | DD |
| 851 | 1.4.8.2.2.1.1.2 | LGSF IM Feeds to Laser Heat Exchanger | 12d | 2011-06-22 | 2011-07-07 | 850 | 316d |  |  | MRI Nance [25%]; MRI Reed [50%] | 32h |  | DD |
| 852 | 1.4.8.2.2.2 | **LGSF IM Cooling Modifications** | 40d? | 2011-06-10 | 2011-08-04 | 972 | 296d | 62d |  |  | 100h |  | DD |
| 853 | 1.4.8.2.2.2.1 | **LGSF IM On Telescope Glycol Modifications** | 30d | 2011-06-10 | 2011-07-21 |  | 296d |  |  |  | 80h |  | DD |
| 854 | 1.4.8.2.2.2.1.1 | LGSF IM Glycol lines between AO and LE for Laser Heads | 30d | 2011-06-10 | 2011-07-21 |  | 296d | 0d |  | MRI Nance [25%]; MRI Agliam [50%] | 80h |  | DD |
| 855 | 1.4.8.2.2.2.2 | **LGSF IM AO Enclosure** | 10d? | 2011-07-22 | 2011-08-04 |  | 296d |  |  |  | 20h |  | DD |
| 856 | 1.4.8.2.2.2.2.1 | LGSF IM Glycol Lines and Manifolds to the Laser/Controller/Heat Exchanger | 10d? | 2011-07-22 | 2011-08-04 | 854 | 296d |  |  | MRI Reed [25%] | 20h |  | DD |
| 857 | 1.4.8.2.2.3 | **LGSF IM Mechanical Modifications** | 102d? | 2011-06-10 | 2011-10-31 |  | 234d | 0d |  |  | 414h | 7,800 | DD |
| 858 | 1.4.8.2.2.3.1 | **LGSF IM Secondary Modifications** | 19d | 2011-09-01 | 2011-09-27 |  | 234d |  |  |  | 62h | 1,200 | DD |
| 859 | 1.4.8.2.2.3.1.1 | LGSF IM Secondary Module Counter Weight Modifications | 12.5d | 2011-09-01 | 2011-09-19 |  | 234d | 0d | start no earlier than 2011-09-01 | MRI Medeiros [25%] | 25h |  | DD |
| 860 | 1.4.8.2.2.3.1.2 | LGSF IM Secondary Mirror Controller Modification | 2.5d | 2011-09-19 | 2011-09-21 | 859 | 234d | 0d |  | MRI Medeiros [25%] | 5h |  | DD |
| 861 | 1.4.8.2.2.3.1.3 | LGSF IM BGS Beam Steering Modification | 4d | 2011-09-22 | 2011-09-27 | 860 | 234d | 0d |  | Chin [50%]; MRI Medeiros [25%]; MRI Mogenson [50%] | 32h | 1,200 | DD |

| ID | WBS | Task | Duration | Start | Finish | Predecessors | Total slack | Free slack | Resources | Work | Cost | Text1 |
| --- | --- | --- | --- | --- | --- | --- | --- | --- | --- | --- | --- | --- |
| 862 | 1.4.8.2.2.3.2 | **LGSF IM Telescope Modifications** | 102d? | 2011-06-10 | 2011-10-31 |  | 234d |  |  | 136h | 3,600 | DD |
| 863 | 1.4.8.2.2.3.2.1 | LGSF IM Modifications to Secondary Module Ring | 12d? | 2011-09-28 | 2011-10-13 | 861 | 234d | 0d | MRI Nance [25%]; MRI Wetherell [25%] | 40h |  | DD |
| 864 | 1.4.8.2.2.3.2.2 | LGSF IM Cable Trays to Secondary Module | 8d | 2011-10-14 | 2011-10-25 | 863 | 234d | 0d | Medeiros [25%]; Mogenson [50%]; Wetherell [25%] | 40h | 3,000 | DD |
| 865 | 1.4.8.2.2.3.2.3 | LGSF IM Cable Trays to Laser Enclosure | 8d | 2011-06-10 | 2011-06-21 | 972 | 324d | 90d | MRI Medeiros [25%]; MRI Nance [25%]; MRI Mogenson [50%] | 40h |  | DD |
| 866 | 1.4.8.2.2.3.2.4 | LGSF IM Telescope Rebalance Plan | 4d | 2011-10-26 | 2011-10-31 | 865, 864 | 234d |  | Medeiros [25%]; MRI Medeiros [25%] | 16h | 600 | DD |
| 867 | 1.4.8.2.2.3.3 | **LGSF IM Laser Enclosure Modifications** | 12d | 2011-06-10 | 2011-06-27 |  | 324d |  |  | 40h | 3,000 | DD |
| 868 | 1.4.8.2.2.3.3.1 | LGSF IM Switchyard Beam Steering Modifications | 12d | 2011-06-10 | 2011-06-27 | 972 | 324d |  | Medeiros [25%]; Mogenson [50%] | 40h | 3,000 | DD |
| 869 | 1.4.8.2.2.3.4 | **LGSF IM AO Enclosure Modifications** | 48d? | 2011-06-10 | 2011-08-16 |  | 288d |  |  | 176h |  | DD |
| 870 | 1.4.8.2.2.3.4.1 | LGSF IM AO Platform for Heat Exchanger | 28d? | 2011-06-10 | 2011-07-19 | 972 | 288d | 0d | MRI Medeiros [25%]; MRI Mogenson [50%] | 80h |  | DD |
| 871 | 1.4.8.2.2.3.4.2 | LGSF IM Heat Exchanger Enclosure | 20d | 2011-07-20 | 2011-08-16 | 870 | 288d |  | MRI Medeiros [25%]; MRI Mogenson [50%]; MRI Nance [25%]; MRI Wetherell [25%] | 96h |  | DD |
| 872 | 1.4.8.2.3 | LGSF IM Design Review and Document Support | 4d | 2011-11-01 | 2011-11-04 | 848, 852, 857 | 234d |  | Nance [50%]; Medeiros [50%]; Chin [50%]; MRI Nance [50%]; MRI Medeiros [50%]; MRI Chin [50%] | 96h | 3,600 | DD |
| 873 | 1.4.8.3 | **Infrastructure Modifications for Instruments - part I** | 116d? | 2010-10-01 | 2011-03-11 |  | 404d | 381.5d |  | 340h | 25,500 |  |
| 874 | 1.4.8.3.1 | **Engineering Tasks** | 60d? | 2010-10-01 | 2010-12-23 |  | 404d | 0d |  | 160h | 12,000 |  |
| 875 | 1.4.8.3.1.1 | **Mechanical Tasks** | 10d? | 2010-10-01 | 2010-10-14 |  | 454d |  |  | 20h | 1,500 |  |
| 876 | 1.4.8.3.1.1.1 | Final mechanical design for modifications to Nasmyth deck and support structure (costed under AO Infrastructure 8.1) | 10d? | 2010-10-01 | 2010-10-14 |  | 454d |  | Hyatt [25%] | 20h | 1,500 |  |
| 877 | 1.4.8.3.1.2 | **Electrical and Cooling** | 60d? | 2010-10-01 | 2010-12-23 |  | 404d | 0d |  | 140h | 10,500 |  |
| 878 | 1.4.8.3.1.2.1 | Final design of modification to system for cooling DaVinici, assume that OSIRIS/NIRSPEC lines are reused. Move lines to other sider of deck needed (currently on wrong side for DAVINCI) | 60d? | 2010-10-01 | 2010-12-23 |  | 404d |  | Nance [25%]; Agliam [25%] | 140h | 10,500 |  |
| 879 | 1.4.8.3.2 | **System Engineering** | 56d? | 2010-12-24 | 2011-03-11 | 874, 877 | 404d |  |  | 180h | 13,500 |  |
| 880 | 1.4.8.3.2.1 | Vendor quotes | 5d? | 2010-12-24 | 2010-12-30 |  | 404d | 0d | Pollard [25%]; Nance [25%] | 20h | 1,500 |  |
| 881 | 1.4.8.3.2.2 | Engineering change requests (ECR) approved | 12.5d? | 2010-12-31 | 2011-01-21 | 880 | 404d | 0d | Pollard [25%]; Mogenson [20%]; Nance | 40h | 3,000 |  |
| 882 | 1.4.8.3.2.3 | Installation/work plan and test plan | 10d? | 2011-01-24 | 2011-02-04 | 881 | 404d | 0d | Pollard [25%] | 20h | 1,500 |  |
| 883 | 1.4.8.3.2.4 | Verify compliance, compliance matrices and final specifications (requirements) | 15d? | 2011-02-07 | 2011-02-25 | 882 | 404d | 0d | Pollard [25%]; Nance [25%] | 60h | 4,500 |  |
| 884 | 1.4.8.3.2.5 | Document design | 10d? | 2011-02-28 | 2011-03-11 | 883 | 404d |  | Mogenson [25%]; Nance [25%] | 40h | 3,000 |  |
| 885 | 1.4.8.4 | **Interferometer Modifications** | 165d? | 2010-10-01 | 2011-05-19 |  | 355d | 332.5d |  | 520h | 39,000 |  |
| 886 | 1.4.8.4.1 | **Engineering Tasks** | 120d? | 2010-10-01 | 2011-03-17 |  | 355d | 0d |  | 320h | 24,000 |  |
| 887 | 1.4.8.4.1.1 | **Opto-Mechanical** | 120d? | 2010-10-01 | 2011-03-17 |  | 355d |  |  | 320h | 24,000 |  |
| 888 | 1.4.8.4.1.1.1 | Final optical design of interferometer interface including a ray trace design, design tolerances, and alignment plan | 40d? | 2010-10-01 | 2010-11-25 |  | 355d | 0d | Martin [25%] | 80h | 6,000 |  |
| 889 | 1.4.8.4.1.1.2 | Final mechanical design of interferometer interface (fabrication drawings, structural analysis, mechanisms designs, motion control | 40d? | 2010-11-26 | 2011-01-20 | 888 | 355d | 0d | Pollard [25%]; Mogenson [25%] | 160h | 12,000 |  |
| 890 | 1.4.8.4.1.1.3 | Design modifcation needed on Keck I AO system to "match" NGAO interferometer mode. Examples include design of Keck I windows for AO. | 40d? | 2011-01-21 | 2011-03-17 | 889 | 355d |  | Martin [25%] | 80h | 6,000 |  |

| ID | WBS | Task | Duration | Start | Finish | Predecessors | Total slack | Free slack | Constraint | Resources | Work | Cost | Text1 |
| --- | --- | --- | --- | --- | --- | --- | --- | --- | --- | --- | --- | --- | --- |
| 891 | 1.4.8.4.2 | **System Engineering** | 45d? | 2011-03-18 | 2011-05-19 | 886 | 355d |  |  |  | 200h | 15,000 |  |
| 892 | 1.4.8.4.2.1 | Vendor quotes | 10d? | 2011-03-18 | 2011-03-31 |  | 355d | 0d |  | Martin [25%] | 20h | 1,500 |  |
| 893 | 1.4.8.4.2.2 | Engineering change requests (ECR) approved | 10d? | 2011-04-01 | 2011-04-14 | 892 | 355d | 0d |  | Martin [25%]; Mogenson [50%] | 40h | 3,000 |  |
| 894 | 1.4.8.4.2.3 | Installation/work plan and test plan | 10d? | 2011-04-15 | 2011-04-28 | 893 | 355d | 0d |  | Pollard [25%]; Martin [25%] | 40h | 3,000 |  |
| 895 | 1.4.8.4.2.4 | Verify compliance, compliance matrices and final specifications (requirements) | 10d? | 2011-04-29 | 2011-05-12 | 894 | 355d | 0d |  | Pollard [25%]; Martin [25%]; Mogenson [25%] | 60h | 4,500 |  |
| 896 | 1.4.8.4.2.5 | Document design | 5d? | 2011-05-13 | 2011-05-19 | 895 | 355d |  |  | Pollard [25%]; Martin [25%]; Mogenson [50%] | 40h | 3,000 |  |
| 897 | 1.4.8.4.3 | Install Interferometer Hatch Covers | 1d? | 2010-10-01 | 2010-10-01 |  | 519d |  |  |  |  |  |  |
| 898 | 1.4.8.5 | **Common Infrastructure** | 170d? | 2010-10-01 | 2011-05-26 |  | 350d | 327.5d |  |  | 670h | 31,350 | DD |
| 899 | 1.4.8.5.1 | CI Planning and Management | 166d | 2010-10-01 | 2011-05-20 |  | 350d | 0d | start no earlier than 2010-10-01 | Chin [3%]; MRI Chin [3%] | 80h | 3,000 | DD |
| 900 | 1.4.8.5.2 | **CI Engineering Tasks** | 162d? | 2010-10-01 | 2011-05-16 |  | 350d |  |  |  | 526h | 25,950 |  |
| 901 | 1.4.8.5.2.1 | **CI Electrical** | 40d | 2010-10-01 | 2010-11-25 | 899SS | 472d | 122d |  |  | 122h | 9,150 | DD |
| 902 | 1.4.8.5.2.1.1 | **CI Mechanical Room** | 40d | 2010-10-01 | 2010-11-25 |  | 472d |  |  |  | 122h | 9,150 | DD |
| 903 | 1.4.8.5.2.1.1.1 | 80KW UPS Systems | 12d | 2010-10-01 | 2010-10-18 |  | 472d | 0d |  | Nance [25%]; Reed [50%] | 32h | 2,400 | DD |
| 904 | 1.4.8.5.2.1.1.2 | Electrical Distribution Panels in Mechanical Room | 8d | 2010-10-19 | 2010-10-28 | 903 | 472d | 0d |  | Nance [25%]; Reed [50%] | 24h | 1,800 | DD |
| 905 | 1.4.8.5.2.1.1.3 | Electrical Feeds from Mechanical Room to Computer Room (21KW) | 8d | 2010-10-29 | 2010-11-09 | 904 | 472d | 0d |  | Nance [25%]; Reed [50%] | 24h | 1,800 | DD |
| 906 | 1.4.8.5.2.1.1.4 | Electrical Feeds to Instrument Power Panel to Telescope (22 KW for AO) | 8d | 2010-11-10 | 2010-11-19 | 905 | 472d | 0d |  | Nance [25%]; Reed [50%] | 24h | 1,800 | DD |
| 907 | 1.4.8.5.2.1.1.5 | Electrical Feeds to Instrument CCR (5.5KW) | 4d | 2010-11-22 | 2010-11-25 | 906 | 472d |  |  | Nance [25%]; Reed [50%] | 18h | 1,350 | FSD |
| 908 | 1.4.8.5.2.2 | **CI Cooling Modifications** | 162d? | 2010-10-01 | 2011-05-16 | 899SS | 350d | 0d |  |  | 404h | 16,800 | DD |
| 909 | 1.4.8.5.2.2.1 | **Mechanical Room / Off Telescope Modifications** | 60d | 2010-10-01 | 2010-12-23 |  | 350d |  |  |  | 180h |  | DD |
| 910 | 1.4.8.5.2.2.1.1 | Glycol Modifications between Keck 1 and Keck II | 40d | 2010-10-01 | 2010-11-25 |  | 350d | 0d |  | MRI Nance [25%]; MRI Agliam [50%] | 120h |  | DD |
| 911 | 1.4.8.5.2.2.1.2 | Glycol Modications in Mechanical Room | 20d | 2010-11-26 | 2010-12-23 | 910 | 350d | 0d |  | MRI Nance [25%]; MRI Agliam [50%] | 60h |  | DD |
| 912 | 1.4.8.5.2.2.2 | **On Telescope Glycol Modifications** | 40d | 2010-12-24 | 2011-02-17 | 911 | 350d |  |  |  | 100h | 7,500 | DD |
| 913 | 1.4.8.5.2.2.2.1 | New 2" Lines in the from Mechanical Room To AO Enclosure via Az Wrap | 40d | 2010-12-24 | 2011-02-17 |  | 350d | 0d |  | Nance [25%]; Agliam [50%] | 100h | 7,500 | DD |
| 914 | 1.4.8.5.2.2.3 | **AO Enclosure** | 62d? | 2011-02-18 | 2011-05-16 |  | 350d |  |  |  | 124h | 9,300 | DD |
| 915 | 1.4.8.5.2.2.3.1 | Glycol Lines to Low Temperature Chiller (AOB) | 12d? | 2011-02-18 | 2011-03-07 | 913 | 350d | 0d |  | Nance [25%] | 24h | 1,800 | DD |
| 916 | 1.4.8.5.2.2.3.2 | Glycol Lines to Instrument | 20d? | 2011-03-08 | 2011-04-04 | 915 | 350d | 0d |  | Nance [25%] | 40h | 3,000 | DD |
| 917 | 1.4.8.5.2.2.3.3 | Glycol Lines to AO Room and AO Vault Heat Exchanger | 20d | 2011-04-05 | 2011-05-02 | 916 | 350d | 0d |  | Nance [25%] | 40h | 3,000 | DD |
| 918 | 1.4.8.5.2.2.3.4 | Glycol Lines to Laser Heat Exchanger | 10d? | 2011-05-03 | 2011-05-16 | 917 | 350d |  |  | Nance [25%] | 20h | 1,500 | DD |
| 919 | 1.4.8.5.3 | CI Design Review and Documents Support | 4d | 2011-05-17 | 2011-05-26 | 901, 908 | 350d |  |  | Nance [50%]; Medeiros [50%]; Chin [50%]; MRI Nance [50%]; MRI Medeiros [50%]; MRI Chin [50%] | 64h | 2,400 | DD |
| 920 | 1.4.8.6 | Telescope & Summit Engineering Mini-Review Ready | 1d? | 2012-08-28 | 2012-08-29 | 828, 845, 873, 885, 898 | 22.5d | 0d |  |  |  |  |  |

| ID | WBS | Task | Duration | Start | Finish | Predecessors | Total slack | Free slack | Constraint | Resources | Work | Cost | Text1 |
| --- | --- | --- | --- | --- | --- | --- | --- | --- | --- | --- | --- | --- | --- |
| 921 | 1.4.9 | **Telescope Integration & Test** | 466d? | 2010-10-01 | 2012-07-16 |  | 55d |  |  |  | 1468h | 105,600 |  |
| 922 | 1.4.9.1 | **Old AO/Laser System Removal** | 340d? | 2010-10-01 | 2012-01-19 |  | 181d |  |  |  | 534h | 29,550 |  |
| 923 | 1.4.9.1.1 | **Remove Old AO System** | 46d? | 2010-10-01 | 2010-12-03 |  | 475d |  |  |  | 240h | 18,000 |  |
| 924 | 1.4.9.1.1.1 | Generate AO Inventory | 16d? | 2010-10-01 | 2010-10-22 |  | 475d | 0d |  | Doyle [25%]; Martin [25%] | 40h | 3,000 |  |
| 925 | 1.4.9.1.1.2 | Detailed AO Removal Plan | 30d? | 2010-10-25 | 2010-12-03 | 924 | 475d |  |  | Martin [25%]; Cooper [25%]; Doyle [25%]; ChockJ [25%] | 200h | 15,000 |  |
| 926 | 1.4.9.1.2 | **Remove Old Laser System** | 340d | 2010-10-01 | 2012-01-19 |  | 181d |  |  |  | 294h | 11,550 | DD |
| 927 | 1.4.9.1.2.1 | Generate Old Laser Inventory | 10d | 2011-12-30 | 2012-01-19 | 973 | 181d |  |  | MRI Cooper [25%]; MRI Grace [25%]; MRI Doyle [25%] | 40h |  | DD |
| 928 | 1.4.9.1.2.2 | Generate Old Laser Removal Plan Phase A | 10d | 2010-10-01 | 2010-10-14 |  | 495.6d | 0d | start no earlier than 2010-10-01 | MRI Grace [25%]; MRI Chin [25%]; MRI Nance [25%]; MRI Doyle [25%]; MRI Medeiros [25%] | 100h |  | DD |
| 929 | 1.4.9.1.2.3 | Generate Old Laser Removal Plan Phase B/C | 10d | 2010-10-15 | 2010-10-28 | 928 | 495.6d | 0d |  | Grace [25%]; Chin [25%]; Nance [25%]; Cooper [25%]; Medeiros [25%] | 100h | 7,500 | DD |
| 930 | 1.4.9.1.2.4 | Old Laser Removal Review Planning A | 2.7d | 2010-10-29 | 2010-11-02 | 929 | 495.6d | 0d | start no earlier than 2010-10-01 | Chin [25%]; Medeiros [25%]; Nance [25%]; Grace [25%]; ChockE [25%] | 27h | 2,025 | DD |
| 931 | 1.4.9.1.2.5 | Old Laser Removal Review Planning B/C | 2.7d | 2010-11-02 | 2010-11-05 | 930 | 495.6d |  | start no earlier than 2010-10-01 | Chin [25%]; Medeiros [25%]; Nance [25%]; Grace [25%]; ChockE [25%] | 27h | 2,025 | DD |
| 932 | 1.4.9.2 | Laser Enclosure Integration | 1d | 2011-10-28 | 2011-10-31 | 593 | 239.5d |  |  |  |  |  |  |
| 933 | 1.4.9.3 | AO Enclosure Integration Plan | 10d? | 2011-10-03 | 2011-10-14 | 139 | 250d |  |  | Pollard [50%] | 40h | 3,000 |  |
| 934 | 1.4.9.4 | **AO System Install + I&T** | 25d? | 2011-10-03 | 2011-11-04 | 139 | 157.96d | 0d |  |  | 120h | 9,000 |  |
| 935 | 1.4.9.4.1 | Infrastructure Mods for AO - part II | 1d? | 2011-10-03 | 2011-10-03 |  | 181.96d |  |  |  |  |  |  |
| 936 | 1.4.9.4.2 | **AO System Support Structures Installation** | 1d? | 2011-10-03 | 2011-10-03 |  | 181.96d |  |  |  |  |  |  |
| 937 | 1.4.9.4.2.1 | Install AO Bench & Cold Enclosure Support | 1d? | 2011-10-03 | 2011-10-03 |  | 181.96d |  |  |  |  |  |  |
| 938 | 1.4.9.4.2.2 | Install Electronics Supports | 1d? | 2011-10-03 | 2011-10-03 |  | 181.96d |  |  |  |  |  |  |
| 939 | 1.4.9.4.2.3 | Install Science Instrument Support | 1d? | 2011-10-03 | 2011-10-03 |  | 181.96d |  |  |  |  |  |  |
| 940 | 1.4.9.4.2.4 | Install LGS WFS Support | 1d? | 2011-10-03 | 2011-10-03 |  | 181.96d |  |  |  |  |  |  |
| 941 | 1.4.9.4.2.5 | Install Interferometer Module Support | 1d? | 2011-10-03 | 2011-10-03 |  | 181.96d |  |  |  |  |  |  |
| 942 | 1.4.9.4.3 | Install AO Electronics | 10d? | 2011-10-03 | 2011-10-14 |  | 157.96d | 0d |  | Wetherell [50%]; ChockJ | 50h | 3,750 |  |
| 943 | 1.4.9.4.4 | Install AO Bench & Align | 2.5d? | 2011-10-17 | 2011-10-19 | 942 | 157.96d | 0d |  | Martin [50%] | 10h | 750 |  |
| 944 | 1.4.9.4.5 | Install AO Bench Cold Enclosure | 2.5d? | 2011-10-19 | 2011-10-21 | 943 | 157.96d | 0d |  | Martin [50%] | 10h | 750 |  |
| 945 | 1.4.9.4.6 | Install Science Instrument, Align to AO & Cool | 2.5d? | 2011-10-24 | 2011-10-26 | 944 | 157.96d | 0d |  | Martin [50%] | 10h | 750 |  |
| 946 | 1.4.9.4.7 | Install LGS WFS & Align | 2.5d? | 2011-10-26 | 2011-10-28 | 945 | 157.96d | 0d |  | Martin [50%] | 10h | 750 |  |
| 947 | 1.4.9.4.8 | Install Interferometer Module & Align | 5d? | 2011-10-31 | 2011-11-04 | 946 | 157.96d |  |  | Martin [50%]; SmithB [50%] | 30h | 2,250 |  |

Notes:
- 932: Planning completed under other areas as there is no new enclosure.

| ID | WBS | Task | Type | Duration | Start | Finish | Predecessors | Total slack | Free slack | Constraint | Resources | Work | Cost | Text1 |
| --- | --- | --- | --- | --- | --- | --- | --- | --- | --- | --- | --- | --- | --- | --- |
| 948 | 1.4.9.5 | **LGSF System Install + I&T** |  | 71d? | 2012-03-01 | 2012-06-07 |  | 3.96d | 0d |  |  | 290h | 21,750 | DD |
| 949 | 1.4.9.5.1 | LGSF System Install Planning and Reporting |  | 70d | 2012-03-01 | 2012-06-06 | 679 | 3.96d | 0d | start no earlier than 2010-10-01 | Chin [10.7%] | 60h | 4,500 | DD |
| 950 | 1.4.9.5.2 | LGSF Installation Plans |  | 20d? | 2012-03-01 | 2012-03-28 | 949SS | 3.96d | 0d |  | Chin [25%]; Medeiros [25%]; Wetherell [25%] | 90h | 6,750 | DD |
| 951 | 1.4.9.5.3 | LGSF Integration Plans |  | 10d? | 2012-03-29 | 2012-04-11 | 950 | 3.96d | 0d |  | Wetherell [25%]; Chin [25%]; LaVen [25%] | 60h | 4,500 | DD |
| 952 | 1.4.9.5.4 | LGSF Alignment Plans |  | 20d? | 2012-04-12 | 2012-05-09 | 951 | 3.96d | 0d |  | Stalcup [25%] | 40h | 3,000 | DD |
| 953 | 1.4.9.5.5 | LGSF Night Time Observing Plans |  | 20d? | 2012-05-10 | 2012-06-06 | 952 | 3.96d | 0d |  | Stalcup [25%] | 40h | 3,000 | DD |
| 954 | 1.4.9.5.6 | LGSF Lab & Tel I&T Mini Review |  | 1d? | 2012-06-07 | 2012-06-07 | 953 | 3.96d | 0d |  |  |  |  |  |
| 955 | 1.4.9.6 | LGS AO System On-sky I&T |  | 10d? | 2012-06-08 | 2012-06-21 | 934, 948 | 71d | 0d |  | Neyman; Dekany; Stalcup | 200h | 15,000 |  |
| 956 | 1.4.9.7 | Performance Characterization |  | 20d? | 2012-03-01 | 2012-03-28 | 949SS | 52d | 0d |  | Stalcup [25%] | 40h | 3,000 |  |
| 957 | 1.4.9.8 | Science Verification |  | 3.65emo | 2012-03-28 | 2012-07-16 | 956 | 223.5d | 0d |  | McGrath Postdoc [7.6%]; Lyke [10%]; Conrad [25%]; Wizinowich [10%]; Travel-HI [200%] | 244h | 24,300 |  |
| 958 | 1.4.10 | **Operations Transition** |  | 63.5d? | 2012-06-28 | 2012-09-25 |  | 3.5d |  |  |  | 238h | 17,850 |  |
| 959 | 1.4.10.1 | Operations Plans |  | 27d? | 2012-06-28 | 2012-08-03 | 934, 948 | 3.5d | 0d | start no earlier than 2012-01-03 | Chin [25%]; Lyke [25%] | 108h | 8,100 |  |
| 960 | 1.4.10.2 | **Operations Handover** |  | 36.5d? | 2012-08-06 | 2012-09-25 |  | 3.5d |  |  |  | 130h | 9,750 |  |
| 961 | 1.4.10.2.1 | Operations Personnel Training |  | 31.5d? | 2012-08-06 | 2012-09-18 | 959 | 3.5d | 0d |  | Chin [17.9%]; Lyke [50%] | 90h | 6,750 |  |
| 962 | 1.4.10.2.2 | Operations Documentation & Spares; Transition |  | 5d? | 2012-09-18 | 2012-09-25 | 961 | 3.5d |  |  | Chin | 40h | 3,000 |  |
| 963 | 2 | **Related Activities** |  | 535d? | 2010-06-11 | 2012-06-29 |  | 66d |  |  |  |  |  |  |
| 964 | 2.1 | **K2 Launch Telescope (MRI-funded)** |  | 296d? | 2010-07-21 | 2011-09-07 |  | 277d |  |  |  |  |  |  |
| 965 | 2.1.1 | LT Preliminary Design Review | milestone | 0d | 2010-07-21 | 2010-07-21 |  | 573d |  | start no earlier than 2010-07-21 |  |  |  |  |
| 966 | 2.1.2 | LT Detailed Design | milestone | 0d | 2010-10-29 | 2010-10-29 |  | 501d |  | start no earlier than 2010-10-29 |  |  |  |  |
| 967 | 2.1.3 | LT Delivery | milestone | 0d | 2011-01-07 | 2011-01-07 |  | 451d |  | start no earlier than 2011-01-07 |  |  |  |  |
| 968 | 2.1.4 | LT Telescope I&T |  | 68d? | 2011-04-04 | 2011-07-06 |  | 277d | 0d | finish no earlier than 2011-07-06 |  |  |  |  |
| 969 | 2.1.5 | LT Commissioning |  | 45d? | 2011-07-07 | 2011-09-07 | 968 | 277d |  | finish no earlier than 2011-09-07 |  |  |  |  |
| 970 | 2.2 | **TOPTICA Laser (ESO-funded)** |  | 535d | 2010-06-11 | 2012-06-29 |  | 66d |  |  |  |  |  |  |
| 971 | 2.2.1 | M1: Kick-off Meeting | milestone | 0d | 2010-06-11 | 2010-06-11 |  | 384.39d | 260d | start no earlier than 2010-06-11 |  |  |  |  |
| 972 | 2.2.2 | M2: Laser Final Design Review | milestone | 0d | 2011-06-10 | 2011-06-10 | 971 | 124.39d | 0d | start no earlier than 2011-06-10 |  |  |  |  |
| 973 | 2.2.3 | M3: Pre-Production Unit Completion | milestone | 0d | 2011-12-30 | 2011-12-30 | 972 | 181d | 0d | start no earlier than 2011-12-30 |  |  |  |  |
| 974 | 2.2.4 | M4: Laser Unit 1 Factory Readiness Test | milestone | 0d | 2012-06-29 | 2012-06-29 | 973 | 66d |  | start no earlier than 2012-06-29 |  |  |  |  |

| ID | WBS | Task | Type | Duration | Start | Finish | Predecessors | Total slack | Free slack | Constraint |
| --- | --- | --- | --- | --- | --- | --- | --- | --- | --- | --- |
| 975 | 2.3 | **New K2 Laser (MRI proposal)** |  | 180d? | 2010-10-01 | 2011-06-10 |  | 341d |  |  |
| 976 | 2.3.1 | K2 Laser Project Start | milestone | 0d | 2010-10-01 | 2010-10-01 |  | 521d | 180d | start no earlier than 2010-10-01 |
| 977 | 2.3.2 | K2 Laser Detailed Design Review | milestone | 0d | 2011-06-10 | 2011-06-10 | 976 | 341d |  | start no earlier than 2011-06-10 |
