# NGAO Development

Schedule from MS Project, 2005-10-03 to 2015-10-30.
CARA

## Calendars

- Standard: Mon-Fri 08:00-12:00, 13:00-17:00; Sat-Sun off.

## Schedule

| ID | WBS | Task | Type | Duration | Start | Finish | Predecessors | Total slack | Free slack | Constraint |
| --- | --- | --- | --- | --- | --- | --- | --- | --- | --- | --- |
| 1 | 1 | **NGAO Design** |  | 1825d? | 2005-10-03 | 2012-09-28 |  | 538d |  |  |
| 2 | 1.1 | Proposal |  | 195d? | 2005-10-03 | 2006-06-30 |  | 538d | 65d | start no earlier than 2005-10-03 |
| 3 | 1.2 | System Design |  | 413d? | 2006-10-02 | 2008-04-30 | 2 | 473d | 0d | start no earlier than 2006-10-02 |
| 4 | 1.3 | **Preliminary Design +** |  | 631d? | 2008-05-01 | 2010-09-30 |  | 473d |  |  |
| 5 | 1.3.1 | Preliminary Design |  | 565d? | 2008-05-01 | 2010-06-30 | 3 | 473d | 0d | start no earlier than 2008-05-01 |
| 6 | 1.3.2 | **Preliminary Design Revisions** |  | 66d? | 2010-07-01 | 2010-09-30 | 5 | 473d |  |  |
| 7 | 1.3.2.1 | Response to PDR Reviewer Report |  | 22d? | 2010-07-01 | 2010-07-30 |  | 1370d |  | start no earlier than 2010-07-01 |
| 8 | 1.3.2.2 | Plan Revisions |  | 54d? | 2010-07-19 | 2010-09-30 |  | 461d | 0d | finish no earlier than 2010-09-30 |
| 9 | 1.4 | Detailed Design |  | 521d? | 2010-10-01 | 2012-09-28 | 8 | 461d | 0d | finish no earlier than 2012-09-28 |
| 10 | 2 | **Project Management** |  | 805d? | 2012-10-01 | 2015-10-30 | 9 | 0d |  |  |
| 11 | 2.1 | **Planning** |  | 680d? | 2012-10-01 | 2015-05-08 |  | 125d |  |  |
| 12 | 2.1.1 | Post-DDR Replan |  | 25d? | 2012-10-01 | 2012-11-02 |  | 780d |  | start no earlier than 2012-10-01 |
| 13 | 2.1.2 | Support WMKO FY14 Planning |  | 70d? | 2013-02-04 | 2013-05-10 |  | 645d |  | finish no earlier than 2013-05-10 |
| 14 | 2.1.3 | Replan 1 |  | 25d? | 2013-09-30 | 2013-11-01 |  | 520d |  | start no earlier than 2013-09-30 |
| 15 | 2.1.4 | Support WMKO FY15 Planning |  | 70d? | 2014-02-03 | 2014-05-09 |  | 385d |  | start no earlier than 2014-02-03 |
| 16 | 2.1.5 | Replan 2 |  | 20d? | 2014-10-06 | 2014-10-31 |  | 260d |  | start no earlier than 2014-10-06 |
| 17 | 2.1.6 | Support WMKO FY16 Planning |  | 70d? | 2015-02-02 | 2015-05-08 |  | 125d |  | start no earlier than 2015-02-02 |
| 18 | 2.2 | Project Management & Meetings |  | 1d? | 2012-10-01 | 2012-10-01 |  | 804d |  |  |
| 19 | 2.3 | Tracking & Reporting |  | 1d? | 2012-10-01 | 2012-10-01 |  | 804d |  |  |
| 20 | 2.4 | Proposals & Fundraising |  | 1d? | 2012-10-01 | 2012-10-01 |  | 804d |  |  |
| 21 | 2.5 | Programmatic Risk Assessment & Mitigation |  | 1d? | 2012-10-01 | 2012-10-01 |  | 804d |  |  |
| 22 | 2.6 | **Project Reviews** |  | 805d? | 2012-10-01 | 2015-10-30 |  | 0d |  |  |
| 23 | 2.6.1 | Subsystem Acceptance Reviews |  | 1d? | 2012-10-01 | 2012-10-01 |  | 804d |  |  |
| 24 | 2.6.2 | AO System Pre-Lab I&T Readiness Review | milestone | 0d | 2013-09-24 | 2013-09-24 | 167FS+2d | 548d |  | start no earlier than 2013-03-22 |
| 25 | 2.6.3 | Science Instrument Pre-Lab I&T Readiness Review | milestone | 0d | 2014-03-31 | 2014-03-31 |  | 375d | 0d | start no earlier than 2014-03-31 |
| 26 | 2.6.4 | AO System Pre-Telescope I&T Readiness Review | milestone | 0d | 2014-11-26 | 2014-11-26 | 199FS+3d | 0d |  | start no earlier than 2014-09-22 |
| 27 | 2.6.5 | Laser System Pre-Telescope I&T Readiness Review | milestone | 0d | 2013-05-31 | 2013-05-31 | 209FS-11d | 514d | 11d |  |
| 28 | 2.6.6 | NGAO Operability Review | milestone | 0d | 2015-09-25 | 2015-09-25 | 402 | 25d |  |  |
| 29 | 2.6.7 | NGAO Operations Readiness Review | milestone | 0d | 2015-10-30 | 2015-10-30 | 404, 410 | 0d |  |  |
| 30 | 2.7 | Project Support |  | 1d? | 2012-10-01 | 2012-10-01 |  | 804d |  |  |

| ID | WBS | Task | Duration | Start | Finish | Predecessors | Total slack | Free slack | Constraint |
| --- | --- | --- | --- | --- | --- | --- | --- | --- | --- |
| 31 | 3 | **Systems Engineering** | 1d? | 2012-10-01 | 2012-10-01 | 9 | 804d |  |  |
| 32 | 3.1 | Science Case Requirements | 1d? | 2012-10-01 | 2012-10-01 |  | 804d |  |  |
| 33 | 3.2 | Requirements | 1d? | 2012-10-01 | 2012-10-01 |  | 804d |  |  |
| 34 | 3.3 | Systems Engineering Analysis | 1d? | 2012-10-01 | 2012-10-01 |  | 804d |  |  |
| 35 | 3.4 | Interface Control | 1d? | 2012-10-01 | 2012-10-01 |  | 804d |  |  |
| 36 | 3.5 | Configuration Control | 1d? | 2012-10-01 | 2012-10-01 |  | 804d |  |  |
| 37 | 3.6 | Technical Risk Assessment & Mitigation | 1d? | 2012-10-01 | 2012-10-01 |  | 804d |  |  |
| 38 | 3.7 | Design Manual | 1d? | 2012-10-01 | 2012-10-01 |  | 804d |  |  |
| 39 | 4 | **AO System** | 560d? | 2012-10-01 | 2014-11-21 | 9 | 245d |  |  |
| 40 | 4.1 | **AO Enclosure** | 240d? | 2012-10-01 | 2013-08-30 |  | 565d |  |  |
| 41 | 4.1.1 | **AO Room** | 130d? | 2013-03-04 | 2013-08-30 |  | 565d |  |  |
| 42 | 4.1.1.1 | AO Room Modifications Procurements/Fabrication | 130d? | 2013-03-04 | 2013-08-30 |  | 565d |  | finish no earlier than 2013-08-30 |
| 43 | 4.1.2 | **Electronics Vault** | 130d? | 2013-03-04 | 2013-08-30 |  | 565d |  |  |
| 44 | 4.1.2.1 | Electronics Vault Modifications Procurements/Fabrication | 130d? | 2013-03-04 | 2013-08-30 |  | 565d |  | finish no earlier than 2013-08-30 |
| 45 | 4.1.3 | **AO Bench Cold Enclosure** | 230d? | 2012-10-01 | 2013-08-16 |  | 568d | 0d |  |
| 46 | 4.1.3.1 | Cold Enclosure Procurements/Fabrication | 175d? | 2012-10-01 | 2013-05-31 |  | 623d |  | start no earlier than 2012-10-01 |
| 47 | 4.1.3.2 | Cold Enclosure Assembly (in lab) | 10d? | 2013-07-01 | 2013-07-12 |  | 568d | 0d | finish no earlier than 2013-07-12 |
| 48 | 4.1.3.3 | Cold Enclosure Testing & Characterization | 25d? | 2013-07-15 | 2013-08-16 | 47 | 568d |  | finish no earlier than 2013-08-16 |
| 49 | 4.2 | **AO Bench** | 261d? | 2012-10-01 | 2013-09-30 |  | 544d |  |  |
| 50 | 4.2.1 | **AO Bench (AOB) Support Structure (SS)** | 195d? | 2012-10-01 | 2013-06-28 |  | 610d | 0d |  |
| 51 | 4.2.1.1 | **AOB SS Procurements/Fabrication** | 175d? | 2012-10-01 | 2013-05-31 |  | 620d |  |  |
| 52 | 4.2.1.1.1 | Optical Bench Procurement | 175d? | 2012-10-01 | 2013-05-31 |  | 620d | 10d | start no earlier than 2012-10-01 |
| 53 | 4.2.1.1.2 | Lab Support Legs | 175d? | 2012-10-01 | 2013-05-31 |  | 630d |  | finish no earlier than 2013-05-31 |
| 54 | 4.2.1.1.3 | Telescope Support Legs | 175d? | 2012-10-01 | 2013-05-31 |  | 630d |  | finish no earlier than 2013-05-31 |
| 55 | 4.2.1.2 | AOB SS Assembly | 5d? | 2013-06-17 | 2013-06-21 | 52 | 610d | 0d | finish no earlier than 2013-06-21 |
| 56 | 4.2.1.3 | AOB SS Test & Acceptance | 5d? | 2013-06-24 | 2013-06-28 | 55 | 610d |  | finish no earlier than 2013-06-28 |

| ID | WBS | Task | Duration | Start | Finish | Predecessors | Total slack | Free slack | Constraint |
| --- | --- | --- | --- | --- | --- | --- | --- | --- | --- |
| 57 | 4.2.2 | **Entrance & Exit Windows** | 125d? | 2012-11-05 | 2013-04-26 |  | 655d |  |  |
| 58 | 4.2.2.1 | **Windows Procurements/Fabrication** | 85d? | 2012-11-05 | 2013-03-01 |  | 695d |  |  |
| 59 | 4.2.2.1.1 | Entrance Window | 85d? | 2012-11-05 | 2013-03-01 |  | 695d |  | finish no earlier than 2013-03-01 |
| 60 | 4.2.2.1.2 | LGS WFS Exit Window | 85d? | 2012-11-05 | 2013-03-01 |  | 695d |  | start no earlier than 2012-11-05 |
| 61 | 4.2.2.1.3 | Interferometer Exit Windows | 85d? | 2012-11-05 | 2013-03-01 |  | 695d |  | start no earlier than 2012-11-05 |
| 62 | 4.2.2.1.4 | Window Cells | 85d? | 2012-11-05 | 2013-03-01 |  | 695d |  | start no earlier than 2012-11-05 |
| 63 | 4.2.2.2 | Windows Testing & Characterization | 20d? | 2013-03-04 | 2013-03-29 |  | 675d |  | finish no earlier than 2013-03-29 |
| 64 | 4.2.2.3 | Windows Assembly & Alignment | 20d? | 2013-04-01 | 2013-04-26 |  | 655d |  | finish no earlier than 2013-04-26 |
| 65 | 4.2.3 | **Rotator** | 175d? | 2012-10-01 | 2013-05-31 |  | 630d |  |  |
| 66 | 4.2.3.1 | Rotator Procurements/Fabrication | 130d? | 2012-10-01 | 2013-03-29 |  | 675d |  | start no earlier than 2012-10-01 |
| 67 | 4.2.3.2 | Rotator Assembly & Alignment | 50d? | 2013-02-25 | 2013-05-03 |  | 630d | 0d | finish no earlier than 2013-05-03 |
| 68 | 4.2.3.3 | Rotator Testing & Characterization | 20d? | 2013-05-06 | 2013-05-31 | 67 | 630d |  | start no earlier than 2013-05-06 |
| 69 | 4.2.4 | **Wide Field Relay** | 220d? | 2012-10-01 | 2013-08-02 |  | 585d |  |  |
| 70 | 4.2.4.1 | Wide Field Relay Procurements/Fabrication | 175d? | 2012-10-01 | 2013-05-31 |  | 590d | 5d | start no earlier than 2012-10-01 |
| 71 | 4.2.4.2 | Wide Field Relay Assembly & Alignment | 20d? | 2013-06-10 | 2013-07-05 | 70, 145 | 585d | 0d | finish no earlier than 2013-06-28 |
| 72 | 4.2.4.3 | Wide Field Relay Testing & Characterization | 20d? | 2013-07-08 | 2013-08-02 | 71 | 585d |  | start no earlier than 2013-07-01 |
| 73 | 4.2.5 | **LGS WFS Feed** | 185d? | 2012-10-01 | 2013-06-14 |  | 620d |  |  |
| 74 | 4.2.5.1 | **LGS WFS Feed Procurements/Fabrication** | 150d? | 2012-10-01 | 2013-04-26 |  | 655d |  |  |
| 75 | 4.2.5.1.1 | LGS Dichroic | 150d? | 2012-10-01 | 2013-04-26 |  | 655d |  | start no earlier than 2012-10-01 |
| 76 | 4.2.5.1.2 | Fold Mirror | 75d? | 2013-01-07 | 2013-04-19 |  | 660d |  | finish no earlier than 2013-04-19 |
| 77 | 4.2.5.1.3 | Reimaging Lens | 120d? | 2012-11-05 | 2013-04-19 |  | 660d |  | finish no earlier than 2013-04-19 |
| 78 | 4.2.5.1.4 | Mounting Hardware | 70d? | 2013-01-07 | 2013-04-12 |  | 665d |  | finish no earlier than 2013-04-12 |
| 79 | 4.2.5.2 | LGS WFS Feed Assembly & Alignment | 20d? | 2013-05-06 | 2013-05-31 |  | 620d | 0d | finish no earlier than 2013-05-31 |
| 80 | 4.2.5.3 | LGS WFS Feed Testing & Characterization | 10d? | 2013-06-03 | 2013-06-14 | 79 | 620d |  | finish no earlier than 2013-06-14 |

| ID | WBS | Task | Duration | Start | Finish | Predecessors | Total slack | Free slack | Constraint |
| --- | --- | --- | --- | --- | --- | --- | --- | --- | --- |
| 81 | 4.2.6 | **Narrow Field Relay** | 230d? | 2012-10-01 | 2013-08-16 |  | 575d |  |  |
| 82 | 4.2.6.1 | Narrow Field Relay Procurements/Fabrication | 175d? | 2012-10-01 | 2013-05-31 |  | 585d | 10d | start no earlier than 2012-10-01 |
| 83 | 4.2.6.2 | Narrow Field Relay Assembly & Alignment | 25d? | 2013-06-17 | 2013-07-19 | 82, 146 | 575d | 0d | finish no earlier than 2013-07-19 |
| 84 | 4.2.6.3 | Narrow Field Relay Testing & Characterization | 20d? | 2013-07-22 | 2013-08-16 | 83 | 575d |  | finish no earlier than 2013-08-16 |
| 85 | 4.2.7 | **Optical Switchyard (OS)** | 150d? | 2012-12-03 | 2013-06-28 |  | 610d |  |  |
| 86 | 4.2.7.1 | **OS Procurements/Fabrication** | 105d? | 2012-12-03 | 2013-04-26 |  | 655d |  |  |
| 87 | 4.2.7.1.1 | Interferometer Dichroic | 105d? | 2012-12-03 | 2013-04-26 |  | 655d |  | finish no earlier than 2013-04-26 |
| 88 | 4.2.7.1.2 | Acquisition Mirror | 105d? | 2012-12-03 | 2013-04-26 |  | 655d |  | start no earlier than 2012-12-03 |
| 89 | 4.2.7.1.3 | NGS WFS Dichroic | 105d? | 2012-12-03 | 2013-04-26 |  | 655d |  | start no earlier than 2012-12-03 |
| 90 | 4.2.7.1.4 | Mounting Hardware | 105d? | 2012-12-03 | 2013-04-26 |  | 655d |  | start no earlier than 2012-12-03 |
| 91 | 4.2.7.1.5 | Translation Stages | 105d? | 2012-12-03 | 2013-04-26 |  | 655d |  | start no earlier than 2012-12-03 |
| 92 | 4.2.7.2 | OS Assembly & Alignment | 25d? | 2013-04-29 | 2013-05-31 |  | 630d |  | finish no earlier than 2013-05-31 |
| 93 | 4.2.7.3 | OS Testing & Characterization | 20d? | 2013-06-03 | 2013-06-28 |  | 610d |  | finish no earlier than 2013-06-28 |
| 94 | 4.2.8 | **Atmospheric Dispersion Corrector (ADC)** | 165d? | 2012-11-12 | 2013-06-28 |  | 610d |  |  |
| 95 | 4.2.8.1 | ADC Procurements/Fabrication | 120d? | 2012-11-12 | 2013-04-26 |  | 610d | 0d | finish no earlier than 2013-04-26 |
| 96 | 4.2.8.2 | ADC Assembly & Alignment | 20d? | 2013-04-29 | 2013-05-24 | 95 | 610d | 0d | start no earlier than 2013-04-29 |
| 97 | 4.2.8.3 | ADC Testing & Characterization | 25d? | 2013-05-27 | 2013-06-28 | 96 | 610d |  | start no earlier than 2013-05-27 |
| 98 | 4.2.9 | AO Bench Component Acceptance Review | 5d? | 2013-09-09 | 2013-09-13 |  | 487d | 0d | finish no earlier than 2013-09-13 |
| 99 | 4.2.10 | **AO Bench Component Packing & Shipping** | 11d? | 2013-09-16 | 2013-09-30 | 98 | 487d |  |  |
| 100 | 4.2.10.1 | AO Bench Component Packing | 5d? | 2013-09-16 | 2013-09-20 |  | 487d | 0d | start no earlier than 2013-09-16 |
| 101 | 4.2.10.2 | AO Bench Component Shipping to WMKO | 6d? | 2013-09-23 | 2013-09-30 | 100 | 487d | 0d | start no earlier than 2013-09-23 |
| 102 | 4.3 | **LGS WFS Assembly** | 281d? | 2012-10-01 | 2013-10-28 |  | 524d |  |  |
| 103 | 4.3.1 | LGS WFS Procurements/Fabrication | 130d? | 2012-10-01 | 2013-03-29 |  | 675d |  | start no earlier than 2012-10-01 |
| 104 | 4.3.2 | LGS WFS Assembly & Align | 150d? | 2012-12-03 | 2013-06-28 |  | 511d | 0d | finish no earlier than 2013-06-28 |
| 105 | 4.3.3 | LGS WFS Testing & Characterization | 65d? | 2013-07-01 | 2013-09-27 | 104 | 511d | 0d | start no earlier than 2013-07-01 |
| 106 | 4.3.4 | LGS WFS Acceptance Review | 1d? | 2013-10-07 | 2013-10-07 | 105FS+5d | 511d | 0d |  |

| ID | WBS | Task | Duration | Start | Finish | Predecessors | Total slack | Free slack | Constraint |
| --- | --- | --- | --- | --- | --- | --- | --- | --- | --- |
| 107 | 4.3.5 | **LGS WFS Shipping to WMKO** | 10d? | 2013-10-15 | 2013-10-28 |  | 511d | 14d |  |
| 108 | 4.3.5.1 | LGS WFS Packing | 5d? | 2013-10-15 | 2013-10-21 | 106FS+5d | 511d | 0d | start no earlier than 2013-10-15 |
| 109 | 4.3.5.2 | LGS WFS Shipping to WMKO | 5d? | 2013-10-22 | 2013-10-28 | 108 | 511d |  | start no earlier than 2012-10-01 |
| 110 | 4.4 | **NGS WFS Assembly** | 170d? | 2012-10-01 | 2013-05-24 |  | 635d |  |  |
| 111 | 4.4.1 | NGS WFS Procurements/Fabrication | 90d? | 2012-10-01 | 2013-02-01 |  | 715d |  | start no earlier than 2012-10-01 |
| 112 | 4.4.2 | NGS WFS Assembly & Align | 65d? | 2012-12-03 | 2013-03-01 |  | 602d | 0d | start no earlier than 2012-12-03 |
| 113 | 4.4.3 | NGS WFS Testing & Characterization | 45d? | 2013-03-04 | 2013-05-03 | 112 | 602d | 0d | start no earlier than 2013-03-04 |
| 114 | 4.4.4 | NGS WFS Acceptance Review | 1d? | 2013-05-13 | 2013-05-13 | 113FS+5d | 602d | 0d |  |
| 115 | 4.4.5 | **NGS WFS Packing & Shipping** | 9d? | 2013-05-14 | 2013-05-24 |  | 602d |  |  |
| 116 | 4.4.5.1 | NGS WFS Packing | 4d? | 2013-05-14 | 2013-05-17 | 114 | 602d | 0d | start no earlier than 2013-05-14 |
| 117 | 4.4.5.2 | NGS WFS Shipping to WMKO | 5d? | 2013-05-20 | 2013-05-24 | 116 | 602d | 115d | finish no earlier than 2013-05-24 |
| 118 | 4.5 | **LOWFS Assembly** | 270d? | 2012-10-01 | 2013-10-11 |  | 535d |  |  |
| 119 | 4.5.1 | LOWFS Procurements/Fabrication | 130d? | 2012-10-01 | 2013-03-29 |  | 675d |  | start no earlier than 2012-10-01 |
| 120 | 4.5.2 | LOWFS Assembly & Align | 130d? | 2012-12-03 | 2013-05-31 |  | 516d | 0d | finish no earlier than 2013-05-31 |
| 121 | 4.5.3 | LOWFS Testing & Characterization | 75d? | 2013-06-03 | 2013-09-13 | 120 | 516d | 0d | start no earlier than 2013-06-03 |
| 122 | 4.5.4 | LOWFS Acceptance Review | 1d? | 2013-09-23 | 2013-09-23 | 121FS+5d | 516d | 0d |  |
| 123 | 4.5.5 | **LOWFS Shipping to WMKO** | 10d? | 2013-09-30 | 2013-10-11 |  | 516d | 18d |  |
| 124 | 4.5.5.1 | LOWFS Packing | 5d? | 2013-09-30 | 2013-10-04 | 122FS+4d | 516d | 0d | start no earlier than 2013-09-30 |
| 125 | 4.5.5.2 | LOWFS Packing & Shipping | 5d? | 2013-10-07 | 2013-10-11 | 124 | 516d |  | start no earlier than 2013-10-07 |
| 126 | 4.6 | **Acquisition Camera** | 136d? | 2012-10-29 | 2013-05-06 |  | 649d |  |  |
| 127 | 4.6.1 | Acquisition Camera Procurements/Fabrication | 90d? | 2012-10-29 | 2013-03-01 |  | 695d |  | start no earlier than 2012-10-29 |
| 128 | 4.6.2 | Acquisition Camera Assembly & Align | 35d? | 2013-02-11 | 2013-03-29 |  | 649d | 0d | finish no earlier than 2013-03-29 |
| 129 | 4.6.3 | Acquisition Camera Testing & Characterization | 20d? | 2013-04-01 | 2013-04-26 | 128 | 649d | 0d | start no earlier than 2013-04-01 |
| 130 | 4.6.4 | Acquisition Camera Acceptance Review | 1d? | 2013-05-06 | 2013-05-06 | 129FS+5d | 649d |  |  |

| ID | WBS | Task | Duration | Start | Finish | Predecessors | Total slack | Free slack | Constraint |
| --- | --- | --- | --- | --- | --- | --- | --- | --- | --- |
| 131 | 4.7 | **Alignment, Calibration & Diagnostics** | 191d? | 2012-10-15 | 2013-07-08 |  | 604d |  |  |
| 132 | 4.7.1 | Calibration Unit Procurements/Fabrication | 130d? | 2012-10-15 | 2013-04-12 |  | 665d |  | finish no earlier than 2013-04-12 |
| 133 | 4.7.2 | Calibration Unit Assembly & Align | 35d? | 2013-03-11 | 2013-04-26 |  | 567d | 0d | finish no earlier than 2013-04-26 |
| 134 | 4.7.3 | Calibration Unit Testing & Characterization | 45d? | 2013-04-29 | 2013-06-28 | 133 | 567d | 0d | start no earlier than 2013-04-29 |
| 135 | 4.7.4 | Calibration Unit Acceptance Review | 1d? | 2013-07-08 | 2013-07-08 | 134FS+5d | 567d | 80d |  |
| 136 | 4.8 | **Real-Time Control (RTC)** | 370d? | 2012-10-01 | 2014-02-28 |  | 435d |  |  |
| 137 | 4.8.1 | **RTC Hardware** | 135d? | 2012-10-01 | 2013-04-05 |  | 670d |  |  |
| 138 | 4.8.1.1 | RTC Hardware Procurements | 110d? | 2012-10-01 | 2013-03-01 |  | 695d |  | start no earlier than 2012-10-01 |
| 139 | 4.8.1.2 | RTC Racks Assembly | 45d? | 2013-02-04 | 2013-04-05 |  | 670d |  | finish no earlier than 2013-04-05 |
| 140 | 4.8.2 | **DM & Driver Procurements** | 150d? | 2012-10-01 | 2013-04-26 |  | 580d |  |  |
| 141 | 4.8.2.1 | LODM/TT Procurement | 150d? | 2012-10-01 | 2013-04-26 |  | 585d | 0d | finish no earlier than 2013-04-26 |
| 142 | 4.8.2.2 | HODM Procurement | 150d? | 2012-10-01 | 2013-04-26 |  | 580d | 0d | finish no earlier than 2013-04-26 |
| 143 | 4.8.2.3 | LOWFS DM Procurement | 110d? | 2012-10-01 | 2013-03-01 |  | 657d | 0d | finish no earlier than 2013-03-01 |
| 144 | 4.8.3 | **DM & Driver Testing & Acceptance** | 70d? | 2013-03-04 | 2013-06-07 |  | 620d |  |  |
| 145 | 4.8.3.1 | LODM/TT Testing & Acceptance | 30d? | 2013-04-29 | 2013-06-07 | 141 | 585d | 0d | finish no earlier than 2013-06-07 |
| 146 | 4.8.3.2 | HODM Testing & Acceptance | 30d? | 2013-04-29 | 2013-06-07 | 142 | 580d | 5d | finish no earlier than 2013-06-07 |
| 147 | 4.8.3.3 | LOWFS DM Testing & Acceptance | 30d? | 2013-03-04 | 2013-04-12 | 143 | 657d | 0d | finish no earlier than 2013-04-12 |
| 148 | 4.8.3.4 | LOWFS DM Packing & Shipping to CIT | 8d? | 2013-04-15 | 2013-04-24 | 147 | 657d |  | finish no earlier than 2013-04-24 |
| 149 | 4.8.4 | RTC Software Development | 135d? | 2012-10-01 | 2013-04-05 |  | 670d |  | start no earlier than 2012-10-01 |
| 150 | 4.8.5 | RTC Hardware & Software Development | 150d? | 2013-04-08 | 2013-11-01 |  | 455d | 0d | finish no earlier than 2013-11-01 |
| 151 | 4.8.6 | RTC Testing & Characterization | 65d? | 2013-11-04 | 2014-01-31 | 150 | 455d |  | finish no earlier than 2014-01-31 |
| 152 | 4.8.7 | RTC Documentation | 90d? | 2013-09-30 | 2014-01-31 |  | 336d | 0d | finish no earlier than 2014-01-31 |
| 153 | 4.8.8 | RTC Acceptance Review | 5d? | 2014-02-03 | 2014-02-07 | 152 | 336d | 0d | finish no earlier than 2013-12-13 |
| 154 | 4.8.9 | **RTC Packing & Shipping** | 15d? | 2014-02-10 | 2014-02-28 | 153 | 336d |  |  |
| 155 | 4.8.9.1 | RTC Packing | 4d? | 2014-02-10 | 2014-02-13 |  | 336d | 0d | finish no earlier than 2013-12-19 |
| 156 | 4.8.9.2 | RTC Shipping to WMKO | 11d? | 2014-02-14 | 2014-02-28 | 155 | 336d | 0d | finish no earlier than 2014-01-03 |

| ID | WBS | Task | Type | Duration | Start | Finish | Predecessors | Total slack | Free slack | Constraint |
| --- | --- | --- | --- | --- | --- | --- | --- | --- | --- | --- |
| 157 | 4.9 | **AO System Lab I&T** |  | 530d? | 2012-11-12 | 2014-11-21 |  | 245d |  |  |
| 158 | 4.9.1 | **AO Setup** |  | 200d? | 2012-11-12 | 2013-08-16 |  | 575d |  |  |
| 159 | 4.9.1.1 | AO Clean Room Procurements |  | 65d? | 2012-11-12 | 2013-02-08 |  | 710d |  | finish no earlier than 2013-02-08 |
| 160 | 4.9.1.2 | AO Clean Room Setup |  | 40d? | 2013-03-04 | 2013-04-26 |  | 655d |  | finish no earlier than 2013-04-26 |
| 161 | 4.9.1.3 | AO Bench Assembly & Acceptance Complete | milestone | 0d | 2013-06-28 | 2013-06-28 | 50 | 610d |  |  |
| 162 | 4.9.1.4 | AO Bench Cold Enclosure Assembly & Acceptance Complete | milestone | 0d | 2013-08-16 | 2013-08-16 | 45 | 568d | 20d |  |
| 163 | 4.9.2 | **Control System Install** |  | 150d? | 2013-05-06 | 2013-11-29 |  | 500d |  |  |
| 164 | 4.9.2.1 | Control System Rack Installation |  | 95d? | 2013-05-06 | 2013-09-13 |  | 515d | 0d | finish no earlier than 2013-09-13 |
| 165 | 4.9.2.2 | Install AO Bench Environmental Monitors & Test |  | 5d? | 2013-09-16 | 2013-09-20 | 164 | 550d |  | finish no earlier than 2013-09-20 |
| 166 | 4.9.2.3 | Control System Cabling |  | 40d? | 2013-10-07 | 2013-11-29 | 169, 164 | 500d |  | finish no earlier than 2013-11-29 |
| 167 | 4.9.3 | AO System Pre-Lab I&T Readiness Review Preparation |  | 5d? | 2013-09-16 | 2013-09-20 | 164, 162 | 548d | 0d | start no earlier than 2013-09-16 |
| 168 | 4.9.4 | **AO Opto-Mechanics Install & Align** |  | 49d? | 2013-10-01 | 2013-12-06 |  | 487d |  |  |
| 169 | 4.9.4.1 | AO Bench Component Unpacking & Checking |  | 4d? | 2013-10-01 | 2013-10-04 | 101 | 487d | 0d | start no earlier than 2013-10-01 |
| 170 | 4.9.4.2 | Rotator Install & Align |  | 4d? | 2013-10-07 | 2013-10-10 | 169 | 487d | 0d | finish no earlier than 2013-10-10 |
| 171 | 4.9.4.3 | Low Order Relay Install & Align |  | 4d? | 2013-10-11 | 2013-10-16 | 170 | 487d | 0d | start no earlier than 2013-10-11 |
| 172 | 4.9.4.4 | High Order Relay Install & Align |  | 4d? | 2013-10-17 | 2013-10-22 | 171 | 487d | 0d | start no earlier than 2013-10-17 |
| 173 | 4.9.4.5 | LGS WFS Feed Install & Align |  | 2d? | 2013-10-23 | 2013-10-24 | 172 | 487d | 0d | start no earlier than 2013-10-23 |
| 174 | 4.9.4.6 | Acquisition Camera Install & Align |  | 2d? | 2013-10-25 | 2013-10-28 | 173 | 487d | 0d | start no earlier than 2013-10-25 |
| 175 | 4.9.4.7 | Calibration Unit Install & Align |  | 4d? | 2013-10-29 | 2013-11-01 | 135, 174 | 487d | 0d | finish no earlier than 2013-11-01 |
| 176 | 4.9.4.8 | NGS WFS Install & Align |  | 3d? | 2013-11-04 | 2013-11-06 | 175, 117 | 487d | 0d | finish no earlier than 2013-11-06 |
| 177 | 4.9.4.9 | LOWFS Install & Align |  | 5d? | 2013-11-07 | 2013-11-13 | 123, 176 | 498d | 0d | finish no earlier than 2013-11-13 |
| 178 | 4.9.4.10 | LGS WFS Window Install & Align |  | 1d? | 2013-11-14 | 2013-11-14 | 177 | 498d | 1d |  |
| 179 | 4.9.4.11 | LGS WFS Install & Align |  | 8d? | 2013-11-18 | 2013-11-27 | 107, 178 | 497d | 2d | finish no earlier than 2013-11-27 |
| 180 | 4.9.4.12 | Entrance & Interferometer Window Install & Align |  | 2d? | 2013-12-02 | 2013-12-03 | 179 | 495d | 0d | finish no earlier than 2013-12-03 |
| 181 | 4.9.4.13 | AO Bench Fiducial Install & Align |  | 3d? | 2013-12-04 | 2013-12-06 | 180 | 495d |  | finish no earlier than 2013-12-06 |
| 182 | 4.9.5 | RTC Install & Cabling |  | 15d? | 2014-03-03 | 2014-03-21 | 156 | 336d | 6d | start no earlier than 2014-01-06 |
| 183 | 4.9.6 | Science Instrument Install & Align |  | 25d? | 2014-04-21 | 2014-05-23 | 25FS+15d | 375d |  | finish no earlier than 2014-04-25 |

| ID | WBS | Task | Duration | Start | Finish | Predecessors | Total slack | Free slack | Constraint |
| --- | --- | --- | --- | --- | --- | --- | --- | --- | --- |
| 184 | 4.9.7 | **Testing & Characterization - Warm** | 210d? | 2013-11-11 | 2014-08-29 |  | 171d |  |  |
| 185 | 4.9.7.1 | Motion Control Testing & Characterization | 30d? | 2013-11-11 | 2013-12-20 | 176 | 485d |  | finish no earlier than 2013-12-20 |
| 186 | 4.9.7.2 | Device Control Testing & Characterization | 30d? | 2013-11-11 | 2013-12-20 | 176 | 485d |  | finish no earlier than 2013-12-20 |
| 187 | 4.9.7.3 | RTC Testing & Characterization | 84d? | 2014-04-01 | 2014-07-25 | 182 | 330d |  | finish no earlier than 2014-07-25 |
| 188 | 4.9.7.4 | Calibration Testing & Characterization | 45d? | 2014-04-28 | 2014-06-27 | 182 | 350d |  | finish no earlier than 2014-06-27 |
| 189 | 4.9.7.5 | Performance Budget Testing & Characterization | 44d? | 2014-07-01 | 2014-08-29 |  | 305d |  | finish no earlier than 2014-08-29 |
| 190 | 4.9.7.6 | Science Operations Tools Testing | 44d? | 2014-07-01 | 2014-08-29 |  | 5d | 0d | start no earlier than 2014-07-01 |
| 191 | 4.9.8 | **Testing & Characterization - Cold** | 45d? | 2014-09-01 | 2014-10-31 |  | 5d |  |  |
| 192 | 4.9.8.1 | AO System Lab I&T Cooldown | 5d? | 2014-09-01 | 2014-09-05 | 190 | 5d | 0d | start no earlier than 2014-09-01 |
| 193 | 4.9.8.2 | Controls Testing & Characterization - Cold | 15d? | 2014-09-08 | 2014-09-26 | 192 | 5d | 0d | finish no earlier than 2014-09-26 |
| 194 | 4.9.8.3 | Alignment Testing & Characterization - Cold | 10d? | 2014-09-15 | 2014-09-26 | 192FS+5d | 285d |  | finish no earlier than 2014-09-26 |
| 195 | 4.9.8.4 | RTC Testing & Characterization - Cold | 20d? | 2014-09-29 | 2014-10-24 | 193 | 265d |  | finish no earlier than 2014-10-24 |
| 196 | 4.9.8.5 | Calibration Testing & Characterization - Cold | 20d? | 2014-09-29 | 2014-10-24 | 193 | 5d | 0d | finish no earlier than 2014-10-24 |
| 197 | 4.9.8.6 | Performance Budget Testing & Characterization - Cold | 5d? | 2014-10-27 | 2014-10-31 | 196 | 260d |  | start no earlier than 2014-10-20 |
| 198 | 4.9.8.7 | Science Operations Tools Testing - Cold | 5d? | 2014-10-27 | 2014-10-31 | 196 | 5d |  | start no earlier than 2014-10-20 |
| 199 | 4.9.9 | AO System Pre-Telescope Readiness Review Preparation | 10d? | 2014-11-10 | 2014-11-21 | 198 | 0d |  | finish no earlier than 2014-11-21 |
| 200 | 5 | **Laser Guide Star Facility** | 305d? | 2012-10-01 | 2013-11-29 | 9 | 484d |  |  |
| 201 | 5.1 | Laser Enclosure | 1d? | 2012-10-01 | 2012-10-01 |  | 804d |  |  |
| 202 | 5.2 | **Laser** | 174d? | 2012-10-01 | 2013-05-30 |  | 484d |  |  |
| 203 | 5.2.1 | Laser Unit 1 Fabrication | 61d? | 2012-10-01 | 2012-12-24 | 426 | 484d | 14d | finish no earlier than 2012-12-24 |
| 204 | 5.2.2 | Laser Unit 2 Fabrication | 174d? | 2012-10-01 | 2013-05-30 | 426 | 631d |  | finish no earlier than 2013-05-30 |
| 205 | 5.2.3 | Laser Unit 3 Fabrication | 174d? | 2012-10-01 | 2013-05-30 | 426 | 631d |  | finish no earlier than 2013-05-30 |
| 206 | 5.3 | Laser Launch Facility | 1d? | 2012-10-01 | 2012-10-01 |  | 804d |  |  |
| 207 | 5.4 | Laser Safety Systems | 1d? | 2012-10-01 | 2012-10-01 |  | 804d |  |  |

| ID | WBS | Task | Duration | Start | Finish | Predecessors | Total slack | Free slack | Constraint |
| --- | --- | --- | --- | --- | --- | --- | --- | --- | --- |
| 208 | 5.5 | **Laser Lab I&T** | 230d? | 2013-01-14 | 2013-11-29 |  | 470d |  |  |
| 209 | 5.5.1 | Laser Unit 1 Lab I&T | 110d? | 2013-01-14 | 2013-06-14 | 203 | 470d | 0d | finish no earlier than 2013-06-14 |
| 210 | 5.5.2 | Laser Unit 2 Lab I&T | 60d? | 2013-06-17 | 2013-09-06 | 209 | 470d | 0d | finish no earlier than 2013-09-06 |
| 211 | 5.5.3 | Laser Unit 3 Lab I&T | 60d? | 2013-09-09 | 2013-11-29 | 210 | 470d | 0d | finish no earlier than 2013-11-29 |
| 212 | 6 | **Control System** | 1d? | 2012-10-01 | 2012-10-01 | 9 | 804d |  |  |
| 213 | 6.1 | **AO Control System** | 1d? | 2012-10-01 | 2012-10-01 |  | 804d |  |  |
| 214 | 6.1.1 | **Calibration / Simulation** | 1d? | 2012-10-01 | 2012-10-01 |  | 804d |  |  |
| 215 | 6.1.1.1 | Electronics | 1d? | 2012-10-01 | 2012-10-01 |  | 804d |  |  |
| 216 | 6.1.1.2 | Software | 1d? | 2012-10-01 | 2012-10-01 |  | 804d |  |  |
| 217 | 6.1.2 | **Low Order Relay** | 1d? | 2012-10-01 | 2012-10-01 |  | 804d |  |  |
| 218 | 6.1.2.1 | Electronics | 1d? | 2012-10-01 | 2012-10-01 |  | 804d |  |  |
| 219 | 6.1.2.2 | Software | 1d? | 2012-10-01 | 2012-10-01 |  | 804d |  |  |
| 220 | 6.1.3 | **LGS Wavefront Sensors** | 1d? | 2012-10-01 | 2012-10-01 |  | 804d |  |  |
| 221 | 6.1.3.1 | Electronics | 1d? | 2012-10-01 | 2012-10-01 |  | 804d |  |  |
| 222 | 6.1.3.2 | Software | 1d? | 2012-10-01 | 2012-10-01 |  | 804d |  |  |
| 223 | 6.1.4 | **Acquisition Camera** | 1d? | 2012-10-01 | 2012-10-01 |  | 804d |  |  |
| 224 | 6.1.4.1 | Electronics | 1d? | 2012-10-01 | 2012-10-01 |  | 804d |  |  |
| 225 | 6.1.4.2 | Software | 1d? | 2012-10-01 | 2012-10-01 |  | 804d |  |  |
| 226 | 6.1.5 | **Low Order Wavefront Sensors** | 1d? | 2012-10-01 | 2012-10-01 |  | 804d |  |  |
| 227 | 6.1.5.1 | Electronics | 1d? | 2012-10-01 | 2012-10-01 |  | 804d |  |  |
| 228 | 6.1.5.2 | Software | 1d? | 2012-10-01 | 2012-10-01 |  | 804d |  |  |
| 229 | 6.1.6 | **High Order Relay** | 1d? | 2012-10-01 | 2012-10-01 |  | 804d |  |  |
| 230 | 6.1.6.1 | Electronics | 1d? | 2012-10-01 | 2012-10-01 |  | 804d |  |  |
| 231 | 6.1.6.2 | Software | 1d? | 2012-10-01 | 2012-10-01 |  | 804d |  |  |

| ID | WBS | Task | Duration | Start | Finish | Total slack |
| --- | --- | --- | --- | --- | --- | --- |
| 232 | 6.1.7 | **NGS Wavefront Sensor** | 1d? | 2012-10-01 | 2012-10-01 | 804d |
| 233 | 6.1.7.1 | Electronics | 1d? | 2012-10-01 | 2012-10-01 | 804d |
| 234 | 6.1.7.2 | Software | 1d? | 2012-10-01 | 2012-10-01 | 804d |
| 235 | 6.1.8 | **Atmospheric Dispersion Corrector** | 1d? | 2012-10-01 | 2012-10-01 | 804d |
| 236 | 6.1.8.1 | Electronics | 1d? | 2012-10-01 | 2012-10-01 | 804d |
| 237 | 6.1.8.2 | Software | 1d? | 2012-10-01 | 2012-10-01 | 804d |
| 238 | 6.1.9 | **AO Enclosures** | 1d? | 2012-10-01 | 2012-10-01 | 804d |
| 239 | 6.1.9.1 | **Electronics Design** | 1d? | 2012-10-01 | 2012-10-01 | 804d |
| 240 | 6.1.9.1.1 | Cold (Bench) Enclosure | 1d? | 2012-10-01 | 2012-10-01 | 804d |
| 241 | 6.1.9.1.2 | **AO Room** | 1d? | 2012-10-01 | 2012-10-01 | 804d |
| 242 | 6.1.9.1.2.1 | Input Hatch | 1d? | 2012-10-01 | 2012-10-01 | 804d |
| 243 | 6.1.9.1.2.2 | Output Hatch | 1d? | 2012-10-01 | 2012-10-01 | 804d |
| 244 | 6.1.9.1.3 | Electronics Vault | 1d? | 2012-10-01 | 2012-10-01 | 804d |
| 245 | 6.1.9.2 | Software Design | 1d? | 2012-10-01 | 2012-10-01 | 804d |
| 246 | 6.1.10 | AO Control Sequencer | 1d? | 2012-10-01 | 2012-10-01 | 804d |
| 247 | 6.2 | **LGSF Control System** | 1d? | 2012-10-01 | 2012-10-01 | 804d |
| 248 | 6.2.1 | **Laser Switchyard** | 1d? | 2012-10-01 | 2012-10-01 | 804d |
| 249 | 6.2.1.1 | Electronics | 1d? | 2012-10-01 | 2012-10-01 | 804d |
| 250 | 6.2.1.2 | Software | 1d? | 2012-10-01 | 2012-10-01 | 804d |
| 251 | 6.2.2 | **Laser Beam Generation System** | 1d? | 2012-10-01 | 2012-10-01 | 804d |
| 252 | 6.2.2.1 | Electronics | 1d? | 2012-10-01 | 2012-10-01 | 804d |
| 253 | 6.2.2.2 | Software | 1d? | 2012-10-01 | 2012-10-01 | 804d |
| 254 | 6.2.3 | **Laser Safety System** | 1d? | 2012-10-01 | 2012-10-01 | 804d |
| 255 | 6.2.3.1 | Electronics | 1d? | 2012-10-01 | 2012-10-01 | 804d |
| 256 | 6.2.3.2 | Software | 1d? | 2012-10-01 | 2012-10-01 | 804d |

| ID | WBS | Task | Duration | Start | Finish | Total slack |
| --- | --- | --- | --- | --- | --- | --- |
| 257 | 6.2.4 | **LTCS** | 1d? | 2012-10-01 | 2012-10-01 | 804d |
| 258 | 6.2.4.1 | Laser Clearinghouse | 1d? | 2012-10-01 | 2012-10-01 | 804d |
| 259 | 6.2.4.2 | **Laser Service Enclosure** | 1d? | 2012-10-01 | 2012-10-01 | 804d |
| 260 | 6.2.4.2.1 | Electronics | 1d? | 2012-10-01 | 2012-10-01 | 804d |
| 261 | 6.2.4.2.2 | Software | 1d? | 2012-10-01 | 2012-10-01 | 804d |
| 262 | 6.2.5 | Laser Control Sequencer | 1d? | 2012-10-01 | 2012-10-01 | 804d |
| 263 | 6.3 | **Control System Infrastructure** | 1d? | 2012-10-01 | 2012-10-01 | 804d |
| 264 | 6.3.1 | **Motion Control** | 1d? | 2012-10-01 | 2012-10-01 | 804d |
| 265 | 6.3.1.1 | Electronics | 1d? | 2012-10-01 | 2012-10-01 | 804d |
| 266 | 6.3.1.2 | Software | 1d? | 2012-10-01 | 2012-10-01 | 804d |
| 267 | 6.3.2 | **Device Control** | 1d? | 2012-10-01 | 2012-10-01 | 804d |
| 268 | 6.3.2.1 | Electronics | 1d? | 2012-10-01 | 2012-10-01 | 804d |
| 269 | 6.3.2.2 | Software | 1d? | 2012-10-01 | 2012-10-01 | 804d |
| 270 | 6.3.3 | **Monitoring** | 1d? | 2012-10-01 | 2012-10-01 | 804d |
| 271 | 6.3.3.1 | **Vibration** | 1d? | 2012-10-01 | 2012-10-01 | 804d |
| 272 | 6.3.3.1.1 | Electronics | 1d? | 2012-10-01 | 2012-10-01 | 804d |
| 273 | 6.3.3.1.2 | Software | 1d? | 2012-10-01 | 2012-10-01 | 804d |
| 274 | 6.3.3.2 | **Temperature** | 1d? | 2012-10-01 | 2012-10-01 | 804d |
| 275 | 6.3.3.2.1 | Electronics | 1d? | 2012-10-01 | 2012-10-01 | 804d |
| 276 | 6.3.3.2.2 | Software | 1d? | 2012-10-01 | 2012-10-01 | 804d |
| 277 | 6.3.3.3 | **Humidity** | 1d? | 2012-10-01 | 2012-10-01 | 804d |
| 278 | 6.3.3.3.1 | Electronics | 1d? | 2012-10-01 | 2012-10-01 | 804d |
| 279 | 6.3.3.3.2 | Software | 1d? | 2012-10-01 | 2012-10-01 | 804d |
| 280 | 6.3.3.4 | **Dust** | 1d? | 2012-10-01 | 2012-10-01 | 804d |
| 281 | 6.3.3.4.1 | Electronics | 1d? | 2012-10-01 | 2012-10-01 | 804d |
| 282 | 6.3.3.4.2 | Software | 1d? | 2012-10-01 | 2012-10-01 | 804d |

| ID | WBS | Task | Duration | Start | Finish | Total slack |
| --- | --- | --- | --- | --- | --- | --- |
| 283 | 6.3.4 | **Electronics** | 1d? | 2012-10-01 | 2012-10-01 | 804d |
| 284 | 6.3.4.1 | Instrument Interface | 1d? | 2012-10-01 | 2012-10-01 | 804d |
| 285 | 6.3.4.2 | Interferometer Interface | 1d? | 2012-10-01 | 2012-10-01 | 804d |
| 286 | 6.3.4.3 | Control Computers | 1d? | 2012-10-01 | 2012-10-01 | 804d |
| 287 | 6.3.4.4 | Realtime Control Computers | 1d? | 2012-10-01 | 2012-10-01 | 804d |
| 288 | 6.3.4.5 | Time Infrastructure (Sync) | 1d? | 2012-10-01 | 2012-10-01 | 804d |
| 289 | 6.3.4.6 | Communication Infrastructure | 1d? | 2012-10-01 | 2012-10-01 | 804d |
| 290 | 6.3.4.7 | **Data Server** | 1d? | 2012-10-01 | 2012-10-01 | 804d |
| 291 | 6.3.4.7.1 | Software | 1d? | 2012-10-01 | 2012-10-01 | 804d |
| 292 | 6.3.4.7.2 | Hardware Selection | 1d? | 2012-10-01 | 2012-10-01 | 804d |
| 293 | 6.3.5 | **Software** | 1d? | 2012-10-01 | 2012-10-01 | 804d |
| 294 | 6.3.5.1 | Telemetry Server | 1d? | 2012-10-01 | 2012-10-01 | 804d |
| 295 | 6.3.5.2 | Health Monitoring | 1d? | 2012-10-01 | 2012-10-01 | 804d |
| 296 | 6.3.5.3 | Logging | 1d? | 2012-10-01 | 2012-10-01 | 804d |
| 297 | 6.3.5.4 | Archiving | 1d? | 2012-10-01 | 2012-10-01 | 804d |
| 298 | 6.3.5.5 | Alarming | 1d? | 2012-10-01 | 2012-10-01 | 804d |
| 299 | 6.3.5.6 | Configuration | 1d? | 2012-10-01 | 2012-10-01 | 804d |
| 300 | 6.3.5.7 | RTC Interface | 1d? | 2012-10-01 | 2012-10-01 | 804d |
| 301 | 6.3.5.8 | Keyword Interface | 1d? | 2012-10-01 | 2012-10-01 | 804d |
| 302 | 6.3.5.9 | EPICS Channel Access Interface | 1d? | 2012-10-01 | 2012-10-01 | 804d |
| 303 | 6.3.5.10 | Atmospheric Profiler Interface | 1d? | 2012-10-01 | 2012-10-01 | 804d |
| 304 | 6.3.5.11 | **Infrastructure Sequences / Scripts** | 1d? | 2012-10-01 | 2012-10-01 | 804d |
| 305 | 6.3.5.11.1 | **Telescope Offloads** | 1d? | 2012-10-01 | 2012-10-01 | 804d |
| 306 | 6.3.5.11.1.1 | Tip Tilt | 1d? | 2012-10-01 | 2012-10-01 | 804d |
| 307 | 6.3.5.11.1.2 | Focus | 1d? | 2012-10-01 | 2012-10-01 | 804d |
| 308 | 6.3.5.11.1.3 | Coma | 1d? | 2012-10-01 | 2012-10-01 | 804d |
| 309 | 6.3.5.11.2 | Dithering | 1d? | 2012-10-01 | 2012-10-01 | 804d |
| 310 | 6.3.5.11.3 | Nodding | 1d? | 2012-10-01 | 2012-10-01 | 804d |
| 311 | 6.3.5.11.4 | Sky Backgrounds | 1d? | 2012-10-01 | 2012-10-01 | 804d |

| ID | WBS | Task | Duration | Start | Finish | Predecessors | Total slack | Free slack | Constraint |
| --- | --- | --- | --- | --- | --- | --- | --- | --- | --- |
| 312 | 7 | **Science Operations Tools** | 1d? | 2012-10-01 | 2012-10-01 | 9 | 804d |  |  |
| 313 | 7.1 | Multi-Systems Command Sequencer | 1d? | 2012-10-01 | 2012-10-01 |  | 804d |  |  |
| 314 | 7.2 | User Interfaces | 1d? | 2012-10-01 | 2012-10-01 |  | 804d |  |  |
| 315 | 7.3 | Pre- & Post-Observing Science Support Tools | 1d? | 2012-10-01 | 2012-10-01 |  | 804d |  |  |
| 316 | 8 | **Telescope & Summit Engineering** | 165d? | 2012-10-01 | 2013-05-17 | 9 | 640d |  |  |
| 317 | 8.1 | **Infrastructure Modifications for AO - part I** | 35d? | 2012-10-01 | 2012-11-16 |  | 770d |  |  |
| 318 | 8.1.1 | Prepare Old AO Packing Materials/Crates | 35d? | 2012-10-01 | 2012-11-16 |  | 770d |  | start no earlier than 2012-07-30 |
| 319 | 8.1.2 | Prepare Keck I AO for NIRC2 | 1d? | 2012-10-01 | 2012-10-01 |  | 804d |  |  |
| 320 | 8.2 | Infastructure Modifications for Laser - part I | 145d? | 2012-10-29 | 2013-05-17 |  | 640d |  | finish no earlier than 2013-05-17 |
| 321 | 8.3 | Infrastructure Modifications for Instruments - part I | 1d? | 2012-10-01 | 2012-10-01 |  | 804d |  |  |
| 322 | 8.4 | **Interferometer Modifications** | 110d? | 2012-10-01 | 2013-03-01 |  | 695d |  |  |
| 323 | 8.4.1 | Procure/Fabricate Matching Windows for Keck I AO | 85d? | 2012-11-05 | 2013-03-01 |  | 695d |  | finish no earlier than 2013-03-01 |
| 324 | 8.4.2 | Install Interferometer Hatch Covers | 1d? | 2012-10-01 | 2012-10-01 |  | 804d |  |  |
| 325 | 8.5 | Common Infrastructure Modifications | 1d? | 2012-10-01 | 2012-10-01 |  | 804d |  |  |
| 326 | 9 | **Telescope Integration & Test** | 690d? | 2013-03-11 | 2015-10-30 | 9 | 0d |  |  |
| 327 | 9.1 | **Remove Old AO System** | 44d? | 2014-12-01 | 2015-01-29 | 26FS+2d | 0d |  |  |
| 328 | 9.1.1 | **NIRC2 Commissioning with Keck I AO** | 44d? | 2014-12-01 | 2015-01-29 |  | 196d |  |  |
| 329 | 9.1.1.1 | Warm NIRC2 | 5d? | 2014-12-01 | 2014-12-05 |  | 235d |  | finish no earlier than 2012-10-07 |
| 330 | 9.1.1.2 | Remove NIRC2 Electronics | 4d? | 2014-12-01 | 2014-12-04 |  | 196d | 0d | finish no earlier than 2012-10-05 |
| 331 | 9.1.1.3 | Install Safety Constraints in NIRC2 for Move | 1d? | 2014-12-05 | 2014-12-05 | 330 | 196d | 0d |  |
| 332 | 9.1.1.4 | Remove NIRC2 Crane (portion over roof) | 1d? | 2014-12-08 | 2014-12-08 | 331 | 196d | 0d |  |
| 333 | 9.1.1.5 | Remove NIRC2 | 1d? | 2014-12-09 | 2014-12-09 | 332 | 196d | 0d |  |
| 334 | 9.1.1.6 | Install NIRC2 in Keck I AO | 1d? | 2014-12-10 | 2014-12-10 | 333 | 196d | 0d |  |
| 335 | 9.1.1.7 | Get NIRC2 operational with Keck I AO | 36d? | 2014-12-11 | 2015-01-29 | 334 | 196d |  | finish no earlier than 2012-11-30 |
| 336 | 9.1.2 | Move Interferometer Module out of AO | 1d? | 2014-12-01 | 2014-12-01 |  | 239d |  |  |
| 337 | 9.1.3 | Remove & Pack AO Bench Components | 5d? | 2014-12-01 | 2014-12-05 |  | 235d |  | start no earlier than 2012-10-02 |
| 338 | 9.1.4 | Remove & Pack Electronics Racks | 5d? | 2014-12-01 | 2014-12-05 |  | 235d |  | finish no earlier than 2012-10-08 |
| 339 | 9.1.5 | Remove & Reinstall Enclosure Roof | 1d? | 2014-12-08 | 2014-12-08 | 331 | 234d |  | start no earlier than 2012-10-10 |
| 340 | 9.1.6 | Remove AO Bench & Supports | 1d? | 2014-12-01 | 2014-12-01 |  | 0d |  | start no earlier than 2012-10-10 |
| 341 | 9.1.7 | Remove & Pack Electronics Cables & Boxes | 3d? | 2014-12-02 | 2014-12-04 | 340 | 0d |  | finish no earlier than 2012-10-15 |
| 342 | 9.1.8 | Remove Extraneous Azimuth Wrap Cabling | 5d? | 2014-12-01 | 2014-12-05 |  | 235d |  | finish no earlier than 2012-10-26 |
| 343 | 9.1.9 | Put Appropriate Components in Spares Inventory | 15d? | 2014-12-01 | 2014-12-19 |  | 225d |  | finish no earlier than 2012-11-09 |
| 344 | 9.1.10 | Dispose or Store Removed Equipment | 30d? | 2014-12-01 | 2015-01-09 |  | 210d |  | finish no earlier than 2012-11-30 |

| ID | WBS | Task | Duration | Start | Finish | Predecessors | Total slack | Free slack | Constraint |
| --- | --- | --- | --- | --- | --- | --- | --- | --- | --- |
| 345 | 9.2 | **Remove Old Laser System** | 185d? | 2013-03-11 | 2013-11-22 |  | 505d |  |  |
| 346 | 9.2.1 | Prepare Old Laser Table Packing Materials/Crates | 50d? | 2013-03-11 | 2013-05-17 |  | 640d |  | start no earlier than 2013-03-11 |
| 347 | 9.2.2 | Drain Preamp & Amp Dye Laser Loops | 3d? | 2013-06-17 | 2013-06-19 | 27 | 503d | 0d | start no earlier than 2013-06-17 |
| 348 | 9.2.3 | Remove & Pack Elevation Ring Electronics | 3d? | 2013-06-17 | 2013-06-19 |  | 617d |  | finish no earlier than 2013-06-19 |
| 349 | 9.2.4 | Remove & Pack Elevation Ring Laser Table | 2d? | 2013-06-20 | 2013-06-21 | 347 | 503d | 2d | start no earlier than 2013-06-20 |
| 350 | 9.2.5 | Remove Extraneous Laser Elevation Wrap Cabling | 3d? | 2013-06-24 | 2013-06-26 |  | 612d |  | finish no earlier than 2013-06-26 |
| 351 | 9.2.6 | Remove Extraneous Laser Azimuth Wrap Cabling | 3d? | 2013-06-26 | 2013-06-28 |  | 610d |  | finish no earlier than 2013-06-28 |
| 352 | 9.2.7 | Drain DMO Dye Loop | 5d? | 2013-09-30 | 2013-10-04 | 397FS+20d | 505d | 0d | finish no earlier than 2013-10-04 |
| 353 | 9.2.8 | Prepare Old Laser Room Packing Materials/Crates | 40d? | 2013-08-05 | 2013-09-27 | 397 | 545d |  | finish no earlier than 2013-09-27 |
| 354 | 9.2.9 | Remove DMO Dye Line & Cabinet | 4d? | 2013-10-07 | 2013-10-10 | 352 | 536d |  | start no earlier than 2013-10-07 |
| 355 | 9.2.10 | Remove & Pack Laser Dome Floor Hardware | 15d? | 2013-10-07 | 2013-10-25 | 352 | 510d | 0d | start no earlier than 2013-10-07 |
| 356 | 9.2.11 | Remove & Pack Laser Dome Floor Enclosure | 10d? | 2013-10-28 | 2013-11-08 | 355 | 515d |  | start no earlier than 2013-10-28 |
| 357 | 9.2.12 | Remove Cabling/Piping to Laser Dome Floor Enclosure | 15d? | 2013-10-28 | 2013-11-15 | 355 | 510d |  | start no earlier than 2013-10-28 |
| 358 | 9.2.13 | Put Appropriate Components in Spares Inventory | 20d? | 2013-10-07 | 2013-11-01 | 352 | 520d |  | start no earlier than 2013-10-07 |
| 359 | 9.2.14 | Dispose or Store Removed Equipment | 35d? | 2013-10-07 | 2013-11-22 | 352 | 505d |  | start no earlier than 2013-10-07 |
| 360 | 9.3 | **AO System Install** | 76d? | 2014-12-05 | 2015-03-20 |  | 0d |  |  |
| 361 | 9.3.1 | **Infrastructure Mods for AO - part II** | 10d? | 2014-12-05 | 2014-12-18 | 341 | 0d |  |  |
| 362 | 9.3.1.1 | Complete Enclosure Vault Modifications | 9d? | 2014-12-05 | 2014-12-17 |  | 0d |  | finish no earlier than 2012-10-26 |
| 363 | 9.3.1.2 | **Install Support Structures** | 5d? | 2014-12-05 | 2014-12-11 | 341 | 4d |  |  |
| 364 | 9.3.1.2.1 | Install AO Bench & Cold Enclosure Support | 4d? | 2014-12-05 | 2014-12-10 |  | 5d |  | finish no earlier than 2012-10-19 |
| 365 | 9.3.1.2.2 | Install Electronics Supports | 4d? | 2014-12-05 | 2014-12-10 |  | 5d | 0d | finish no earlier than 2012-10-19 |
| 366 | 9.3.1.2.3 | Install Science Instrument Support | 5d? | 2014-12-05 | 2014-12-11 |  | 4d |  | start no earlier than 2012-10-22 |
| 367 | 9.3.1.2.4 | Install LGS WFS Support | 5d? | 2014-12-05 | 2014-12-11 |  | 4d |  | start no earlier than 2012-10-22 |
| 368 | 9.3.1.2.5 | Install Interferometer Module Support | 5d? | 2014-12-05 | 2014-12-11 |  | 4d |  | start no earlier than 2012-10-22 |
| 369 | 9.3.1.3 | Clean Electronics Vault | 1d? | 2014-12-11 | 2014-12-11 | 365 | 226d | 0d |  |
| 370 | 9.3.1.4 | Clean AO Room | 1d? | 2014-12-18 | 2014-12-18 | 363, 362 | 0d |  | finish no earlier than 2012-10-29 |
| 371 | 9.3.2 | Install AO Electronics | 5d? | 2014-12-12 | 2014-12-18 | 369 | 226d |  | start no earlier than 2012-10-23 |
| 372 | 9.3.3 | Install AO Bench & Align to Telescope | 4d? | 2014-12-19 | 2014-12-24 | 370 | 0d |  | start no earlier than 2012-10-30 |
| 373 | 9.3.4 | Connect AO Bench Electronics | 2d? | 2014-12-25 | 2014-12-26 | 372 | 0d |  | start no earlier than 2014-10-23 |
| 374 | 9.3.5 | Verify AO Bench Motion & Device Control | 5d? | 2014-12-29 | 2015-01-02 | 373 | 0d |  | start no earlier than 2014-10-27 |
| 375 | 9.3.6 | Verify AO Bench Internal Alignments (+Adjust if Needed) | 5d? | 2015-01-05 | 2015-01-09 | 374 | 0d |  | start no earlier than 2014-11-03 |
| 376 | 9.3.7 | Install LGS WFS | 2d? | 2015-01-12 | 2015-01-13 | 375 | 208d |  | start no earlier than 2014-11-10 |
| 377 | 9.3.8 | Install Science Instrument | 2d? | 2015-01-12 | 2015-01-13 | 375 | 0d |  | start no earlier than 2014-11-10 |
| 378 | 9.3.9 | Clean AO Room | 1d? | 2015-01-14 | 2015-01-14 | 377 | 0d |  |  |
| 379 | 9.3.10 | Connect Science Instrument Electronics | 1d? | 2015-01-15 | 2015-01-15 | 378 | 0d |  |  |
| 380 | 9.3.11 | Cooldown Science Instrument | 9d? | 2015-01-16 | 2015-01-28 | 379 | 0d |  | finish no earlier than 2014-11-26 |
| 381 | 9.3.12 | Connect LGS WFS Electronics | 2d? | 2015-01-16 | 2015-01-19 | 379 | 199d | 0d | start no earlier than 2014-11-14 |
| 382 | 9.3.13 | Verify LGS WFS Motion & Device Control | 2d? | 2015-01-20 | 2015-01-21 | 381 | 199d | 0d | start no earlier than 2014-11-18 |
| 383 | 9.3.14 | Align LGS WFS | 3d? | 2015-01-22 | 2015-01-26 | 382 | 199d |  | finish no earlier than 2014-11-24 |
| 384 | 9.3.15 | Verify Science Instrument Motion & Device Control | 2d? | 2015-01-29 | 2015-01-30 | 380 | 0d |  | start no earlier than 2014-11-27 |
| 385 | 9.3.16 | Align Science Instrument | 3d? | 2015-02-02 | 2015-02-04 | 384 | 0d |  | start no earlier than 2014-12-01 |
| 386 | 9.3.17 | Install Interferometer Module & Align | 10d? | 2015-03-02 | 2015-03-13 |  | 165d |  | start no earlier than 2015-03-02 |
| 387 | 9.3.18 | Install/Align Matching Interferometer Windows for Keck I AO | 10d? | 2015-03-09 | 2015-03-20 |  | 160d |  | start no earlier than 2015-03-09 |

| ID | WBS | Task | Duration | Start | Finish | Predecessors | Total slack | Free slack | Constraint |
| --- | --- | --- | --- | --- | --- | --- | --- | --- | --- |
| 388 | 9.4 | **Laser System Install** | 118d? | 2013-06-26 | 2013-12-06 |  | 495d |  |  |
| 389 | 9.4.1 | Install Support Structures | 1d? | 2013-06-26 | 2013-06-26 | 349 | 501d | 0d | finish no earlier than 2013-06-26 |
| 390 | 9.4.2 | Install Laser Unit 1 - Electronics | 5d? | 2013-06-27 | 2013-07-03 | 209 | 607d |  | finish no earlier than 2013-07-03 |
| 391 | 9.4.3 | Install Laser Unit 1 - Laser | 5d? | 2013-06-27 | 2013-07-03 | 389 | 501d | 0d | start no earlier than 2013-06-27 |
| 392 | 9.4.4 | Install Laser Switchyard | 4d? | 2013-07-04 | 2013-07-09 |  | 603d |  | finish no earlier than 2013-07-09 |
| 393 | 9.4.5 | Install Laser Unit 2 | 5d? | 2013-12-02 | 2013-12-06 | 211 | 470d | 0d | start no earlier than 2013-12-02 |
| 394 | 9.4.6 | Install Laser Unit 3 | 5d? | 2013-12-02 | 2013-12-06 | 211 | 470d | 0d | start no earlier than 2013-12-02 |
| 395 | 9.5 | AO System I&T | 82d? | 2015-02-05 | 2015-05-29 | 385 | 0d |  | start no earlier than 2015-02-05 |
| 396 | 9.6 | **Laser System I&T** | 137d? | 2013-07-04 | 2014-01-10 |  | 470d |  |  |
| 397 | 9.6.1 | Laser Unit 1 I&T | 21d? | 2013-07-04 | 2013-08-01 | 391 | 501d | 1d | start no earlier than 2013-07-04 |
| 398 | 9.6.2 | Laser Unit 1 on-sky I&T with Keck II AO | 40d? | 2013-08-05 | 2013-09-27 | 397 | 545d |  | start no earlier than 2013-08-05 |
| 399 | 9.6.3 | Laser Unit 1 Performance Characterization with Keck II AO | 85d? | 2013-08-05 | 2013-11-29 | 397 | 500d |  | finish no earlier than 2013-11-29 |
| 400 | 9.6.4 | Laser Unit 2 I&T | 25d? | 2013-12-09 | 2014-01-10 | 393 | 470d |  | finish no earlier than 2014-01-10 |
| 401 | 9.6.5 | Laser Unit 3 I&T | 25d? | 2013-12-09 | 2014-01-10 | 394 | 470d |  | start no earlier than 2013-12-09 |
| 402 | 9.7 | LGS AO System On-sky I&T | 85d? | 2015-06-01 | 2015-09-25 | 395 | 25d | 0d | finish no earlier than 2015-09-25 |
| 403 | 9.8 | Performance Characterization | 90d? | 2015-06-29 | 2015-10-30 | 395FS+20d | 0d |  | finish no earlier than 2015-10-30 |
| 404 | 9.9 | Science Verification | 70d? | 2015-07-27 | 2015-10-30 | 395FS+40d | 0d |  | start no earlier than 2015-07-27 |
| 405 | 10 | **Operations Transition** | 1d? | 2012-10-01 | 2012-10-01 | 9 | 804d |  |  |
| 406 | 10.1 | **Operations Plans** | 1d? | 2012-10-01 | 2012-10-01 |  | 804d |  |  |
| 407 | 10.1.1 | AO Operations Plans Revision - Pre-Telescope I&T | 1d? | 2012-10-01 | 2012-10-01 |  | 804d |  |  |
| 408 | 10.1.2 | LGSF Operations Plans Revision - Post-Telescope I&T | 1d? | 2012-10-01 | 2012-10-01 |  | 804d |  |  |
| 409 | 10.1.3 | AO Operations Plans Revision - Post-Telescope I&T | 1d? | 2012-10-01 | 2012-10-01 |  | 804d |  |  |
| 410 | 10.2 | **Operations Handover** | 1d? | 2012-10-01 | 2012-10-01 |  | 804d |  |  |
| 411 | 10.2.1 | LGSF Lab Training | 1d? | 2012-10-01 | 2012-10-01 |  | 804d |  |  |
| 412 | 10.2.2 | LGSF Training | 1d? | 2012-10-01 | 2012-10-01 |  | 804d |  |  |
| 413 | 10.2.3 | AO Lab Training | 1d? | 2012-10-01 | 2012-10-01 |  | 804d |  |  |
| 414 | 10.2.4 | AO Facility Training | 1d? | 2012-10-01 | 2012-10-01 |  | 804d |  |  |

| ID | WBS | Task | Type | Duration | Start | Finish | Predecessors | Total slack | Free slack | Constraint |
| --- | --- | --- | --- | --- | --- | --- | --- | --- | --- | --- |
| 415 | 11 | **Related Activities** |  | 1036d? | 2010-06-11 | 2014-06-02 |  | 370d |  |  |
| 416 | 11.1 | **K2 Launch Telescope (MRI-funded)** |  | 296d? | 2010-07-21 | 2011-09-07 |  | 1082d |  |  |
| 417 | 11.1.1 | LT Preliminary Design Review | milestone | 0d | 2010-07-21 | 2010-07-21 |  | 1378d |  | start no earlier than 2010-07-21 |
| 418 | 11.1.2 | LT Detailed Design | milestone | 0d | 2010-10-29 | 2010-10-29 |  | 1306d |  | start no earlier than 2010-10-29 |
| 419 | 11.1.3 | LT Delivery | milestone | 0d | 2011-01-07 | 2011-01-07 |  | 1256d |  | start no earlier than 2011-01-07 |
| 420 | 11.1.4 | LT Telescope I&T |  | 68d? | 2011-04-04 | 2011-07-06 |  | 1082d | 0d | finish no earlier than 2011-07-06 |
| 421 | 11.1.5 | LT Commissioning |  | 45d? | 2011-07-07 | 2011-09-07 | 420 | 1082d |  | finish no earlier than 2011-09-07 |
| 422 | 11.2 | **TOPTICA Laser (ESO-funded)** |  | 730d | 2010-06-11 | 2013-03-29 |  | 676d |  |  |
| 423 | 11.2.1 | M1: Kick-off Meeting | milestone | 0d | 2010-06-11 | 2010-06-11 |  | 1085d | 260d | start no earlier than 2010-06-11 |
| 424 | 11.2.2 | M2: Laser Final Design Review | milestone | 0d | 2011-06-10 | 2011-06-10 | 423 | 825d | 145d | start no earlier than 2011-06-10 |
| 425 | 11.2.3 | M3: Pre-Production Unit Completion | milestone | 0d | 2011-12-30 | 2011-12-30 | 424 | 680d | 130d | start no earlier than 2011-12-30 |
| 426 | 11.2.4 | M4: Laser Unit 1 Factory Readiness Test | milestone | 0d | 2012-06-29 | 2012-06-29 | 425 | 550d | 66d | start no earlier than 2012-06-29 |
| 427 | 11.2.5 | M6: Remaining Laser Factory Readiness Tests | milestone | 0d | 2013-03-29 | 2013-03-29 | 426 | 676d |  | start no earlier than 2013-03-29 |
| 428 | 11.3 | **New K2 Laser (MRI proposal)** |  | 956d | 2010-10-01 | 2014-06-02 |  | 370d |  |  |
| 429 | 11.3.1 | K2 Laser Project Start | milestone | 0d | 2010-10-01 | 2010-10-01 |  | 1326d | 180d | start no earlier than 2010-10-01 |
| 430 | 11.3.2 | K2 Laser Detailed Design Review | milestone | 0d | 2011-06-10 | 2011-06-10 | 429 | 1146d | 482d | start no earlier than 2011-06-10 |
| 431 | 11.3.3 | K2 Laser Arrival at WMKO HQ | milestone | 0d | 2013-04-16 | 2013-04-16 | 426, 430 | 664d | 56d | start no earlier than 2013-04-16 |
| 432 | 11.3.4 | K2 Laser Pre-Telescope Readiness Review | milestone | 0d | 2013-07-03 | 2013-07-03 | 431 | 608d | 87d | start no earlier than 2013-07-03 |
| 433 | 11.3.5 | Existing K2 Laser Goes Off-Line | milestone | 0d | 2013-11-01 | 2013-11-01 | 432 | 521d | 47d | start no earlier than 2013-11-01 |
| 434 | 11.3.6 | K2 Laser First Light | milestone | 0d | 2014-01-07 | 2014-01-07 | 433 | 474d | 104d | start no earlier than 2014-01-07 |
| 435 | 11.3.7 | K2 Laser Operational Readiness Review | milestone | 0d | 2014-06-02 | 2014-06-02 | 434 | 370d |  | start no earlier than 2014-06-02 |
